# PG032 - Melhoria dos Sistemas de Abastecimento de Água

How a schedule from MS Project changed from version to version. A marks actual dates.

## Version 1 (data date 2019-10-31, saved 2019-11-22, file Cronograma PG32_191122.mpp)

| ID | WBS | Task | Duration | Start | Finish | Predecessors | Complete | Total float |
| --- | --- | --- | --- | --- | --- | --- | --- | --- |
| 1 | 1 | **Marcos** | 1876d | 2016-06-17 A | 2023-11-22 |  |  | 0d |
| 2 | 1.1 | **Cláusula do TTAC** | 509d | 2020-11-04 | 2022-11-22 |  |  | 248d |
| 3 |  | Cláusula 171 - Conclusão das obras de sistemas alternativos de captação e adução e melhoria das estações de tratamento de água para todas localidades. | 0d | 2022-11-22 | 2022-11-22 | 133, 267, 314, 410, 461, 703, 795, 839, 1207, 1278, 1377, 1457, 1561, 1617, 1669, 1774, 1824, 1910, 1994, 2104, 2210, 96, 203, 307, 664, 763, 923, 969, 1026, 1080, 1173, 1310, 1355, 1495, 1526, 1715, 1741, 1853, 1882, 2039, 2069, 2134, 2163 |  | 248d |
| 4 |  | Cláusula 171, Parágrafo 1º - Conclusão dos Levantamentos de Campo, Projetos Conceituais e Básicos em todas localidades. | 0d | 2020-11-04 | 2020-11-04 | 354, 583, 684, 781, 1366, 1633, 1644, 1760, 2088, 119, 224, 231, 66, 176, 482, 548, 887, 903, 1003, 1054, 1336, 1396, 2146 |  | 757d |
| 5 | 1.2 | **Deliberações** | 1876d | 2016-06-17 A | 2023-11-22 |  |  | 0d |
| 6 |  | Deliberação 4, Item 1 - Construção de sistemas alternativos de captação e adução e melhoria das estações de tratamento de água: 1.2) Apresentação de documentos que formalizem a concordância dos prestadores de serviço. | 0d | 2016-06-17 A | 2016-06-17 A | 24FS+78d | 100% |  |
| 7 |  | Deliberação 10 - Aprova parcialmente o cronograma de início da operação assistida de parte dos sistemas alternativos de abastecimento e determina solução específica para o abastecimento de Resplendor. | 0d | 2016-09-12 A | 2016-09-12 A | 24FS+139d | 100% |  |
| 8 |  | Deliberação 16 - Definições e recomendações complementares sobre o Programa de Melhoria dos Sistemas de Abastecimento de Água. | 0d | 2016-09-19 A | 2016-09-19 A | 24FS+144d | 100% |  |
| 9 |  | Deliberação 33, Item 1 - Promover a caracterização da composição da fração coloide e do sobrenadante observado nas águas da bacia do rio Doce após o evento. | 0d | 2017-06-29 A | 2017-06-29 A | 25FS-44d | 100% |  |
| 10 |  | Deliberação 33, Itens i e ii - Relatórios mensais ações de implementação de captações e de melhorias dos sistemas de abastecimento ("relatórios i e ii"). | 0d | 2023-11-22 | 2023-11-22 | 2225 |  | 0d |
| 11 |  | Deliberação 98 - Atualização e ajustes ao Plano de Ações para o Período Chuvoso nos temas relativos ao abastecimento de água para consumo humano. A Fundação deverá providenciar e apresentar em 30 dias a atualização do plano. | 0d | 2017-09-22 A | 2017-09-22 A | 25FS+18d | 100% |  |
| 12 |  | Deliberação 123 - Aprovação e recomendações complementares apontadas na Nota Técnica nº 16 do CT-SHQA sobre documento "Estudos de capacidade de mananciais superficiais e subterrâneos, visando a construção de sistemas alternativos de abastecimento de água' | 0d | 2018-02-05 A | 2018-02-05 A | 25FS+114d | 100% |  |
| 13 |  | Deliberação 124 - Aprovação e recomendações complementares sobre o Plano de Ações para o Período Chuvoso - setembro de 2017, com base na Nota Técnica nº 15 da CT - SHQA. Item 2: Estabelece-se o prazo de 20 dias para reapresentação do plano de ações para o | 0d | 2017-12-08 A | 2017-12-08 A | 25FS+73d | 100% |  |
| 14 |  | Deliberação 124 - O plano de ações para períodos chuvosos deverá ser apresentado pela Fundação Renova às Câmaras Técnicas de Gestão de Rejeitos, CT-FLOR, CT-BIO, CT-Comunicação, CT-Saúde. | 0d | 2018-02-23 A | 2018-02-23 A | 25FS+128d | 100% |  |
| 15 |  | Deliberação 185, Item 2 - A Fundação Renova deverá apresentar, em10 (dez) dias, um cronogramadetalhado preliminar contemplando os estudos de concepção, projetos básicos,projetos detalhados, obras e demais ações, além da distinção das ações que foremrelati | 0d | 2018-08-10 A | 2018-08-10 A | 106, 325, 422, 673, 804, 1218, 1423, 1535, 1571, 1627, 1784, 1920, 2078, 2172FS+101d, 37, 145, 473, 521, 604, 713, 849, 879, 934, 981, 1038, 1092, 1144, 1288, 1319, 1387, 1462, 1505, 1679, 1724, 2005, 2048, 2114FS+101d | 100% |  |
| 16 |  | Deliberação 185, Item 3 - A Fundação Renova deverá apresentar, até o dia 18 de setembro, na reunião da CT-SHQA, um Plano de Aceleração do Programa de Melhoria dos Sistemas de Abastecimento de Água, observando as considerações exaradas na Nota Técnica 22 d | 0d | 2018-09-28 A | 2018-09-28 A | 106, 325, 422, 673, 804, 1218, 1423, 1535, 1571, 1627, 1784, 1920, 2078, 2172FS+136d, 37, 145, 473, 521, 604, 713, 849, 879, 934, 981, 1038, 1092, 1144, 1288, 1319, 1387, 1462, 1505, 1679, 1724, 2005, 2048, 2114FS+136d | 100% |  |
| 17 |  | Deliberação 185, Item 4 - A Fundação Renova deverá apresentar os Termos de entrega e recebimentoassinado pelos prestadores de serviço e pelos Municípios, após a conclusão dasobras de captações alternativas adução e melhorias nos sistemas deabastecimento d | 0d | 2022-11-22 | 2022-11-22 | 133, 267, 314, 410, 461, 594, 703, 795, 839, 1207, 1278, 1377, 1457, 1561, 1617, 1669, 1774, 1824, 1910, 1994, 2104, 2210, 96, 203, 307, 512, 570, 664, 763, 870, 923, 969, 970, 1026, 1027, 1080, 1081, 1173, 1310, 1355, 1495, 1526, 1715, 1741, 1853, 1882, 2039, 2069, 2134, 2163 |  | 248d |
| 18 |  | Deliberação 258, Item 2 - A Fundação Renova deverá apresentar a anuência da Prefeitura e do prestador de servico de abastecimento de água para cada localidade, referentes à clausula 171, em 60 dias. | 0d | 2020-12-31 | 2020-12-31 | 362, 1251, 1591, 1650, 1802 |  | 718d |
| 19 |  | Deliberação 258, Item 4 - A Fundação Renova deveatualizar e revisar, em ate 10 (dez) dias, o cronograma detalhado das ações do Programa | 0d | 2019-01-04 A | 2019-01-04 A | 107FS+216d, 38FS+216d | 100% |  |
| 20 |  | Deliberação 258, Item 5 - A Fundação Renova deve atualizar e revisar, em até 10 (dez) dias, o Plano de Aceleração do Programa | 0d | 2019-01-11 A | 2019-01-11 A | 107FS+221d, 38FS+221d | 100% |  |
| 21 |  | Deliberação 308, Item 2: Determinar à Fundação Renova o atendimento imediato às diretrizes para elaboração de projetos básicos e do fluxograma de procedimento, previstos na Nota Técnica nº 45 da CT-SHQA. | 0d | 2020-11-04 | 2020-11-04 | 354, 583, 684, 781, 1366, 1633, 1644, 1760, 2088, 119, 224, 231, 66, 176, 482, 548, 887, 903, 1003, 1054, 1336, 1396, 2146 |  | 757d |
| 22 |  | Deliberação 315, Item 1: Determinar à Renova que revise e apresente o documento “Definição do Programa - Etapa 3”, no prazo de 30 dias, contemplando as propostas e considerações apresentadas na Nota Técnica nº 48 da CT-SHQA. | 0d | 2019-09-27 A | 2019-09-27 A | 30 | 100% |  |
| 23 | 2 | **Definição** | 984d | 2016-03-02 A | 2019-12-26 |  | 99% | 970d |
| 24 |  | Assinatura do TTAC | 0d | 2016-03-02 A | 2016-03-02 A |  | 100% |  |
| 25 |  | Realizar Estudo de Segurança Hídrica | 300ed | 2016-11-03 A | 2017-08-30 A | 24 | 100% |  |
| 26 |  | Realizar Levantamento de Campo e Diagnósticos | 320ed | 2017-01-02 A | 2017-11-18 A | 25SS+60ed | 100% |  |
| 27 |  | Obter Apoio Técnico | 100d | 2016-03-23 A | 2016-08-09 A | 24FS+15d | 100% |  |
| 28 |  | Elaborar Definição do Programa e Protocolar no CIF | 196d | 2017-03-01 A | 2017-11-29 A | 24FS+245d | 100% |  |
| 29 |  | Revisão e Aprovação da Definição do Programa pela Fundação Renova | 0d | 2017-11-29 A | 2017-11-29 A | 28 | 100% |  |
| 30 |  | Revisar a Definição do Programa conforme a NT 48/2019 da CT-SHQA e protocolar no CIF | 468d | 2017-11-30 A | 2019-09-27 A | 29 | 100% |  |
| 31 |  | Aprovação da Definição do programa pelo CIF | 0d | 2019-12-26 | 2019-12-26 | 30FS+60d |  | 970d |
| 32 |  | Conclusão das obras do período emergencial | 0d | 2017-12-28 A | 2017-12-28 A | 304, 2218, 2219, 2220, 2221, 2224, 2223, 2222 | 100% |  |
| 33 | 3 | **Território Mariana** | 1239d | 2018-02-20 A | 2023-01-28 |  | 8% | 201d |
| 34 | 3.1 | **Camargos (distrito Mariana/MG)** | 1115d | 2018-03-08 A | 2022-08-18 |  | 8% | 313d |
| 35 | 3.1.1 | **Captação Alternativa (Poço Tubular)** | 1115d | 2018-03-08 A | 2022-08-18 |  | 10% | 313d |
| 36 | 3.1.1.1 | **Estudos de Concepção do Sistema - Etapa 1** | 185d | 2018-03-08 A | 2018-11-21 A |  | 100% |  |
| 37 |  | Declaração de Escopo e Premissas de Projeto (DEPP) concluída - Camargos/MG | 0d | 2018-03-23 A | 2018-03-23 A | 25, 26 | 100% |  |
| 38 |  | Aprovação das DEPPs pela Operadora e Prefeitura - Camargos/MG | 0d | 2018-03-08 A | 2018-03-08 A | 25, 26 | 100% |  |
| 39 | 3.1.1.1.3 | **Estudos de Geofísica para Poço Tubular** | 174d | 2018-03-23 A | 2018-11-21 A |  | 100% |  |
| 40 |  | Executar Levantamento de Campo - Poço 1 - Camargos/MG | 24d | 2018-03-23 A | 2018-04-25 A | 37 | 100% |  |
| 41 |  | Emitir Relatório - Poço 1 - Camargos/MG | 22d | 2018-03-27 A | 2018-04-25 A | 40FF | 100% |  |
| 42 |  | Executar Levantamento de Campo - Poço 2 - Camargos/MG | 24d | 2018-10-19 A | 2018-11-21 A | 37 | 100% |  |
| 43 |  | Emitir Relatório - Poço 2 - Camargos/MG | 23d | 2018-10-22 A | 2018-11-21 A | 42FF | 100% |  |
| 44 |  | Conclusão dos Estudos de Geofísica - Camargos/MG | 0d | 2018-11-21 A | 2018-11-21 A | 41, 43 | 100% |  |
| 45 | 3.1.1.1.4 | **Serviços em Poços Tubulares - Poço SAAE Existente - Poço Tamponado** | 6d | 2018-06-27 A | 2018-07-04 A |  | 100% |  |
| 46 |  | Realizar Perfilagem (poço existente) - Camargos/MG | 5d | 2018-06-27 A | 2018-07-03 A | 37 | 100% |  |
| 47 |  | Realizar tamponamento - Poço SAAE Existente - Camargos/MG | 1d | 2018-07-04 A | 2018-07-04 A | 46 | 100% |  |
| 48 |  | Conclusão dos Serviços em poço tubular - Camargos/MG | 0d | 2018-07-04 A | 2018-07-04 A | 47 | 100% |  |
| 49 | 3.1.1.2 | **Estudos de Concepção do Sistema - Etapa 2** | 190d | 2019-06-28 A | 2020-04-02 |  |  | 428d |
| 50 |  | Definição do escopo para Camargos - Poço 2 e Nascente | 0d | 2019-06-28 A | 2019-06-28 A | 48FS+250d | 100% |  |
| 51 | 3.1.1.2.2 | **Serviços em Poços Tubulares - Poço 2 - Captação Alternativa** | 26d | 2020-02-27 | 2020-04-02 |  |  | 404d |
| 52 |  | Realizar Perfuração - Poço 2 - Captação Alternativa - Camargos/MG | 2d | 2020-02-27 | 2020-02-28 | 50, 84 |  | 404d |
| 53 |  | Realizar Teste de bombeamento - Poço 2 - Captação Alternativa - Camargos/MG | 1d | 2020-03-02 | 2020-03-02 | 52 |  | 404d |
| 54 |  | Realizar Laudo de Serviços de Coleta e Análise de Água - Poço 2 - Captação Alternativa - Camargos/MG | 20d | 2020-03-03 | 2020-03-30 | 53 |  | 431d |
| 55 |  | Elaborar Relatório Técnico - Poço 2 - Captação Alternativa - Camargos/MG | 20d | 2020-03-03 | 2020-03-30 | 52, 53 |  | 404d |
| 56 |  | Realizar Instrumentação - Poço 2 - Captação Alternativa - Camargos/MG | 3d | 2020-03-31 | 2020-04-02 | 55 |  | 428d |
| 57 |  | Conclusão dos Serviços em poço tubular - Poço 2 - Captação Alternativa - Camargos/MG | 0d | 2020-04-02 | 2020-04-02 | 52, 53, 54, 55, 56 |  | 428d |
| 58 |  | Conclusão dos Estudos de Concepção das Melhorias do Sistema de Abastecimento de Água - Camargos/MG | 0d | 2020-04-02 | 2020-04-02 | 37, 38, 44, 48, 57 |  | 428d |
| 59 | 3.1.1.3 | **Engenharia Básica e Detalhada** | 500d | 2018-11-30 A | 2020-12-02 |  | 41% | 408d |
| 60 | 3.1.1.3.1 | **Engenharia Captação Alternativa (Poço 2)** | 500d | 2018-11-30 A | 2020-12-02 |  | 41% | 408d |
| 61 |  | Aprovar Plano de Trabalho e abrir OSE - Captação Alternativa - Poço 2 - Camargos/MG | 11d | 2018-11-30 A | 2018-12-14 A | 37 | 100% |  |
| 62 |  | Realizar Levantamento de Campo - Captação Alternativa - Poço 2 - Camargos/MG | 6d | 2018-11-30 A | 2018-12-07 A | 61SS | 100% |  |
| 63 |  | Executar Topografia - Captação Alternativa - Poço 2 - Camargos/MG | 31d | 2018-11-30 A | 2019-01-14 A | 61SS | 100% |  |
| 64 |  | Elaborar Projeto Conceitual - Captação Alternativa - Poço 2 - Camargos/MG | 60d | 2018-12-18 A | 2019-03-15 A | 61SS, 62SS, 63FS-45d | 100% |  |
| 65 |  | Elaborar Projeto Básico - Captação Alternativa - Poço 2 - Camargos/MG | 70d | 2020-05-08 | 2020-08-14 | 64FS+283d |  | 314d |
| 66 |  | Aprovar projeto Básico com Prefeitura/Operadora - Poço 2 - Camargos/MG | 22d | 2020-08-17 | 2020-09-16 | 65 |  | 314d |
| 67 |  | Emitir RT/PQ para Suprimentos - Captação Alternativa - Poço 2 - Camargos/MG | 10d | 2020-11-19 | 2020-12-02 | 68FF |  | 314d |
| 68 |  | Elaborar Projeto Executivo - Captação Alternativa - Poço 2 - Camargos/MG | 53d | 2020-09-17 | 2020-12-02 | 55, 56, 57, 66, 58 |  | 314d |
| 69 |  | Elaboração do Projeto Executivo - Captação Alternativa - Poço 2 - Camargos/MG | 0d | 2020-12-02 | 2020-12-02 | 66, 68 |  | 408d |
| 70 | 3.1.1.4 | **Fundiária** | 308d | 2019-05-02 A | 2020-07-24 |  | 20% | 498d |

| ID | WBS | Task | Duration | Start | Finish | Predecessors | Complete | Total float |
| --- | --- | --- | --- | --- | --- | --- | --- | --- |
| 71 |  | Obter Termos de Autorização de Superficiário - Captação Alternativa - Poço 2 - Camargos/MG | 20d | 2019-05-02 A | 2019-05-29 A | 43FS+108d | 100% |  |
| 72 | 3.1.1.4.2 | **Captação Alternativa - Poço 2 - Desimpedimento da Área e Negociação de Servidão** | 80d | 2020-03-31 | 2020-07-24 |  |  | 498d |
| 73 |  | Realizar Levantamento da documentação da propriedade - Camargos/MG | 10d | 2020-03-31 | 2020-04-14 | 55, 64 |  | 498d |
| 74 |  | Obter assinatura do Contrato de servidão pelo proprietário - Camargos/MG | 20d | 2020-04-15 | 2020-05-14 | 73 |  | 498d |
| 75 |  | Lavrar Escritura Pública de Servidão no cartório de notas - Camargos/MG | 30d | 2020-05-15 | 2020-06-26 | 74 |  | 498d |
| 76 |  | Averbar a escritura pública na matrícula do imóvel - Camargos/MG | 20d | 2020-06-29 | 2020-07-24 | 75 |  | 498d |
| 77 |  | Regularização da Servidão do Imóvel - Poço 2 - Camargos/MG | 0d | 2020-07-24 | 2020-07-24 | 76 |  | 521d |
| 78 |  | Conclusão da Regularização Fundiária para as obras de Melhoria do Sistema de Abastecimento da Localidade - Camargos/MG | 0d | 2020-07-24 | 2020-07-24 | 77 |  | 498d |
| 79 | 3.1.1.5 | **Licenciamento** | 264d | 2019-11-14 | 2020-12-08 |  |  | 404d |
| 80 | 3.1.1.5.1 | **Captação Alternativa - Autorização de Perfuração Poço 2 (AM) - Captação Principal** | 67d | 2019-11-14 | 2020-02-21 |  |  | 404d |
| 81 |  | Realizar Análise Inicial da Demanda - Camargos/MG | 8d | 2019-11-14 | 2019-11-26 | 43, 71FS+118d |  | 404d |
| 82 |  | Protocolar FCE e documentos do FOB - Camargos/MG | 15d | 2019-11-27 | 2019-12-18 | 81 |  | 404d |
| 83 |  | Acompanhar Processo Junto ao Órgão - Camargos/MG | 44d | 2019-12-19 | 2020-02-21 | 82 |  | 404d |
| 84 |  | Obtenção de Autorização de Perfuração - Poço 2 - Camargos/MG | 0d | 2020-02-21 | 2020-02-21 | 83 |  | 404d |
| 85 | 3.1.1.5.2 | **Outorga para Captação Alternativa (Poço 2)** | 174d | 2020-03-31 | 2020-12-08 |  |  | 404d |
| 86 |  | Protocolar FCE e documentos do FOB - Camargos/MG | 44d | 2020-03-31 | 2020-06-03 | 55, 64 |  | 404d |
| 87 |  | Acompanhar Processo Junto ao Órgão - Camargos/MG | 130d | 2020-06-04 | 2020-12-08 | 86 |  | 404d |
| 88 |  | Obtenção da Outorga para captação - Poço 2 - Camargos/MG | 0d | 2020-12-08 | 2020-12-08 | 87 |  | 404d |
| 89 |  | Conclusão do Licenciamento Ambiental da Localidade - Camargos/MG | 0d | 2020-12-08 | 2020-12-08 | 84, 88 |  | 404d |
| 90 | 3.1.1.6 | **Suprimentos** | 94d | 2020-12-03 | 2021-04-23 |  |  | 314d |
| 91 |  | Captações e ETA - Camargos/MG | 94d | 2020-12-03 | 2021-04-23 | 67 |  | 314d |
| 92 |  | Conclusão da Contratação de Suprimentos - Captações e ETA - Camargos/MG | 0d | 2021-04-23 | 2021-04-23 | 91 |  | 314d |
| 93 | 3.1.1.7 | **Infraestrutura** | 330d | 2021-04-26 | 2022-08-18 |  |  | 313d |
| 94 | 3.1.1.7.1 | **Obras** | 81d | 2021-04-26 | 2021-08-17 |  |  | 314d |
| 95 |  | Executar obras de Captação Alternativa (Poço 2) - Camargos/MG | 81d | 2021-04-26 | 2021-08-17 | 68, 69, 76, 77, 88, 92, 78, 89 |  | 314d |
| 96 |  | Assinatura de Termo de Entrega das Obras de Melhoria do Sistema de Abastecimento de Água - Camargos/MG | 0d | 2021-08-17 | 2021-08-17 | 95 |  | 314d |
| 97 | 3.1.1.7.2 | **Operação** | 249d | 2021-08-18 | 2022-08-18 |  |  | 313d |
| 98 |  | Realizar Treinamento Operacional do Sistema - Camargos/MG | 5d | 2021-08-18 | 2021-08-24 | 95, 96 |  | 314d |
| 99 |  | Realizar Testes e Pré-operação - Camargos/MG | 14d | 2021-08-18 | 2021-09-06 | 98SS |  | 314d |
| 100 |  | Realizar Acompanhamento da Funcionalidade do Sistema - Captação Alternativa (Poço Tubular) - Camargos (distrito Mariana/MG) | 365ed | 2021-08-18 | 2022-08-18 | 102SS |  | 1384.12d |
| 101 | 3.1.1.7.2.4 | **Operação Assistida** | 60d | 2021-08-18 | 2021-11-16 |  |  | 314d |
| 102 |  | Realizar Operação Assistida - Camargos/MG | 90ed | 2021-08-18 | 2021-11-16 | 95, 99SS |  | 1384.12d |
| 103 |  | Entrega das obras e conclusão do período de acompanhamento da operação - Camargos/MG | 0d | 2022-08-18 | 2022-08-18 | 96, 102, 100 |  | 313d |
| 104 | 3.1.2 | **ETA (Sistema de Tratamento Simplificado) e Captação Principal (Nascente)** | 1066d | 2018-03-08 A | 2022-06-08 |  | 6% | 362d |
| 105 | 3.1.2.1 | **Estudos de Concepção do Sistema - Etapa 1** | 85d | 2018-03-08 A | 2018-07-04 A |  | 100% |  |
| 106 |  | Declaração de Escopo e Premissas de Projeto (DEPP) concluída - Camargos/MG | 0d | 2018-03-23 A | 2018-03-23 A | 25, 26 | 100% |  |
| 107 |  | Aprovação das DEPPs pela Operadora e Prefeitura - Camargos/MG | 0d | 2018-03-08 A | 2018-03-08 A | 25, 26 | 100% |  |
| 108 | 3.1.2.1.3 | **Serviços em Poços Tubulares - Poço SAAE Existente - Poço Tamponado** | 6d | 2018-06-27 A | 2018-07-04 A |  | 100% |  |
| 109 |  | Realizar Perfilagem (poço existente) - Camargos/MG | 5d | 2018-06-27 A | 2018-07-03 A | 106 | 100% |  |
| 110 |  | Realizar tamponamento - Poço SAAE Existente - Camargos/MG | 1d | 2018-07-04 A | 2018-07-04 A | 109 | 100% |  |
| 111 |  | Conclusão dos Serviços em poço tubular - Camargos/MG | 0d | 2018-07-04 A | 2018-07-04 A | 110 | 100% |  |
| 112 | 3.1.2.2 | **Engenharia Básica e Detalhada** | 420d | 2018-11-30 A | 2020-08-07 |  | 40% | 488d |
| 113 | 3.1.2.2.1 | **Engenharia ETA (Sistema de Tratamento Simplificado) e Captação Principal (Nascente)** | 420d | 2018-11-30 A | 2020-08-07 |  | 40% | 488d |
| 114 |  | Aprovar Plano de Trabalho e abrir OSE - ETA/Captação Principal - Camargos/MG | 11d | 2018-11-30 A | 2018-12-14 A | 106, 111 | 100% |  |
| 115 |  | Realizar Levantamento de Campo - ETA/Captação Principal - Camargos/MG | 6d | 2018-11-30 A | 2018-12-07 A | 114SS | 100% |  |
| 116 |  | Executar Topografia - ETA/Captação Principal - Camargos/MG | 31d | 2018-11-30 A | 2019-01-14 A | 114SS | 100% |  |
| 117 |  | Elaborar Projeto Conceitual - ETA/Captação Principal - Camargos/MG | 60d | 2018-12-18 A | 2019-03-15 A | 115, 116 | 100% |  |
| 118 |  | Elaborar Projeto Básico - ETA/Captação Principal - Camargos/MG | 60d | 2020-01-02 | 2020-03-30 | 117FS+198d |  | 365d |
| 119 |  | Aprovar projeto Básico com Prefeitura/Operadora - ETA/Captação Principal - Camargos/MG | 22d | 2020-03-31 | 2020-05-04 | 118 |  | 365d |
| 120 |  | Emitir RT/PQ para Suprimentos - ETA/Captação Principal - Camargos/MG | 10d | 2020-07-27 | 2020-08-07 | 121FF |  | 365d |
| 121 |  | Elaborar Projeto Executivo - ETA/Captação Principal - Camargos/MG | 68d | 2020-05-05 | 2020-08-07 | 119 |  | 365d |
| 122 |  | Elaboração do Projeto Executivo - ETA/Captação Principal - Camargos/MG | 0d | 2020-08-07 | 2020-08-07 | 121, 119 |  | 488d |
| 123 | 3.1.2.3 | **Fundiária** | 5d | 2018-03-23 A | 2018-03-29 A |  | 100% |  |
| 124 |  | Obter Termos de Autorização de Superficiário - ETA - Camargos/MG | 5d | 2018-03-23 A | 2018-03-29 A | 106 | 100% |  |
| 125 |  | Conclusão da Regularização Fundiária para as obras de Melhoria do Sistema de Abastecimento da Localidade - Camargos/MG | 0d | 2018-03-29 A | 2018-03-29 A | 124 | 100% |  |
| 126 | 3.1.2.4 | **Suprimentos** | 94d | 2020-08-10 | 2020-12-22 |  |  | 365d |
| 127 |  | Captações e ETA - Camargos/MG | 94d | 2020-08-10 | 2020-12-22 | 120 |  | 365d |
| 128 |  | Conclusão da Contratação de Suprimentos - Captações e ETA - Camargos/MG | 0d | 2020-12-22 | 2020-12-22 | 127 |  | 394d |
| 129 | 3.1.2.5 | **Infraestrutura** | 361d | 2020-12-23 | 2022-06-08 |  |  | 362d |
| 130 | 3.1.2.5.1 | **Obras** | 110d | 2020-12-23 | 2021-06-07 |  |  | 365d |
| 131 |  | Executar Melhorias na Captação Superficial e Reservatório - Captação Principal - Camargos/MG | 110d | 2020-12-23 | 2021-06-07 | 127 |  | 365d |
| 132 |  | Executar obras da ETA 2L/s (Sistema de Tratamento Simplificado) - Camargos/MG | 81d | 2020-12-23 | 2021-04-26 | 121, 128, 122 |  | 394d |
| 133 |  | Assinatura de Termo de Entrega das Obras de Melhoria do Sistema de Abastecimento de Água - Camargos/MG | 0d | 2021-06-07 | 2021-06-07 | 132, 131 |  | 365d |
| 134 | 3.1.2.5.2 | **Operação** | 251d | 2021-06-08 | 2022-06-08 |  |  | 362d |
| 135 |  | Realizar Treinamento Operacional do Sistema - Camargos/MG | 5d | 2021-06-08 | 2021-06-14 | 132, 133 |  | 365d |
| 136 |  | Realizar Testes e Pré-operação - Camargos/MG | 14d | 2021-06-08 | 2021-06-25 | 135SS |  | 365d |
| 137 |  | Realizar Acompanhamento da Funcionalidade do Sistema - ETA (Sistema de Tratamento Simplificado) e Captação Principal (Nascente) - Camargos (distrito Mariana/MG) | 365ed | 2021-06-08 | 2022-06-08 | 139SS |  | 1597.12d |
| 138 | 3.1.2.5.2.4 | **Operação Assistida** | 64d | 2021-06-08 | 2021-09-06 |  |  | 363d |
| 139 |  | Realizar Operação Assistida - Camargos/MG | 90ed | 2021-06-08 | 2021-09-06 | 132, 136SS |  | 1597.12d |
| 140 |  | Entrega das obras e conclusão do período de acompanhamento da operação - Camargos/MG | 0d | 2022-06-08 | 2022-06-08 | 133, 139, 137 |  | 362d |

| ID | WBS | Task | Duration | Start | Finish | Predecessors | Complete | Total float |
| --- | --- | --- | --- | --- | --- | --- | --- | --- |
| 141 | 3.2 | **Pedras (distrito Mariana/MG)** | 1239d | 2018-02-20 A | 2023-01-28 |  | 9% | 201d |
| 142 | 3.2.1 | **Captação Alternativa (Poço Tubular)** | 1089d | 2018-02-20 A | 2022-06-24 |  | 18% | 351d |
| 143 | 3.2.1.1 | **Engenharia** | 604d | 2018-02-20 A | 2020-07-13 |  | 62% | 442d |
| 144 | 3.2.1.1.1 | **Estudos de Concepção do Sistema - Etapa 1** | 286d | 2018-02-20 A | 2019-04-01 A |  | 100% |  |
| 145 |  | Declaração de Escopo e Premissas de Projeto (DEPP) concluída - Pedras/MG | 0d | 2018-03-23 A | 2018-03-23 A | 25, 26FS+90d | 100% |  |
| 146 |  | Aprovação das DEPPs pela Operadora e Prefeitura - Pedras/MG | 0d | 2018-03-23 A | 2018-03-23 A | 145 | 100% |  |
| 147 | 3.2.1.1.1.3 | **Estudos de Geofísica para Poço Tubular** | 197d | 2018-02-20 A | 2018-11-21 A |  | 100% |  |
| 148 |  | Executar Levantamento de Campo - Poço 1 - Pedras/MG | 21d | 2018-02-20 A | 2018-03-20 A | 145FS-24d | 100% |  |
| 149 |  | Emitir Relatório - Poço 1 - Pedras/MG | 15d | 2018-02-28 A | 2018-03-20 A | 148FF | 100% |  |
| 150 |  | Executar Levantamento de Campo - Poço 2 - Pedras/MG | 23d | 2018-10-22 A | 2018-11-21 A | 145FS+154d | 100% |  |
| 151 |  | Emitir Relatório - Poço 2 - Pedras/MG | 15d | 2018-11-01 A | 2018-11-21 A | 150FF | 100% |  |
| 152 |  | Conclusão dos Estudos de Geofísica - Pedras/MG | 0d | 2018-11-21 A | 2018-11-21 A | 149, 151 | 100% |  |
| 153 | 3.2.1.1.1.4 | **Serviços em Poços Tubulares - Poço 1 - Poço seco, não será utilizado** | 53d | 2019-01-14 A | 2019-04-01 A |  | 100% |  |
| 154 |  | Realizar Perfuração - Poço 1 - Poço seco, não será utilizado - Pedras/MG | 5d | 2019-01-14 A | 2019-01-18 A | 149 | 100% |  |
| 155 |  | Realizar Tamponamento - Poço 1 - Poço seco, não será utilizado - Pedras/MG | 1d | 2019-01-18 A | 2019-01-18 A | 154FF | 100% |  |
| 156 |  | Elaborar Relatório Técnico - Poço 1 - Poço seco, não será utilizado - Pedras/MG | 48d | 2019-01-21 A | 2019-04-01 A | 154 | 100% |  |
| 157 |  | Conclusão dos Serviços em poço tubular - Poço 1 - Poço seco, não será utilizado - Pedras/MG | 0d | 2019-02-21 A | 2019-02-21 A | 156 | 100% |  |
| 158 | 3.2.1.1.2 | **Estudos de Concepção do Sistema - Etapa 2** | 159d | 2019-04-15 A | 2019-11-29 |  | 80% | 592d |
| 159 | 3.2.1.1.2.1 | **Serviços em Poços Tubulares - Poço 2 - Captação Alternativa** | 159d | 2019-04-15 A | 2019-11-29 |  | 80% | 592d |
| 160 |  | Realizar Perfuração - Poço 2 - Captação Alternativa - Pedras/MG | 3d | 2019-04-15 A | 2019-04-17 A | 191 | 100% |  |
| 161 |  | Realizar Teste de bombeamento - Poço 2 - Captação Alternativa - Pedras/MG | 4d | 2019-04-22 A | 2019-04-25 A | 160 | 100% |  |
| 162 |  | Realizar Laudo de Serviços de Coleta e Análise de Água - Poço 2 - Captação Alternativa - Pedras/MG | 44d | 2019-04-26 A | 2019-06-28 A | 161 | 100% |  |
| 163 |  | Elaborar Relatório Técnico - Poço 2 - Captação Alternativa - Pedras/MG | 44d | 2019-04-26 A | 2019-06-28 A | 161 | 100% |  |
| 164 |  | Realizar Instrumentação - Poço 2 - Captação Alternativa - Pedras/MG | 34d | 2019-10-14 A | 2019-11-29 | 163FS+74d | 25% | 592d |
| 165 |  | Conclusão dos Serviços em poço tubular - Poço 2 - Captação Alternativa - Pedras/MG | 0d | 2019-11-29 | 2019-11-29 | 162, 164 |  | 592d |
| 166 |  | Conclusão dos Estudos de Concepção das Melhorias do Sistema de Abastecimento de Água - Pedras/MG | 0d | 2019-11-29 | 2019-11-29 | 152, 157, 165 |  | 592d |
| 167 | 3.2.1.1.3 | **Engenharia Conceitual - Pedras** | 72d | 2018-11-30 A | 2019-03-15 A |  | 100% |  |
| 168 |  | Aprovar Plano de Trabalho e abrir OSE - Pedras/MG | 11d | 2018-11-30 A | 2018-12-14 A | 145 | 100% |  |
| 169 |  | Realizar Levantamento de Campo - Pedras/MG | 6d | 2018-11-30 A | 2018-12-07 A | 168SS | 100% |  |
| 170 |  | Executar Topografia - Pedras/MG | 23d | 2018-11-30 A | 2019-01-02 A | 168SS | 100% |  |
| 171 |  | Elaborar Projeto Conceitual - Pedras/MG | 60d | 2018-12-18 A | 2019-03-15 A | 169, 170 | 100% |  |
| 172 | 3.2.1.1.4 | **Engenharia Básica e Detalhada** | 169d | 2019-11-04 | 2020-07-13 |  |  | 354d |
| 173 | 3.2.1.1.4.1 | **Engenharia Captação Alternativa (Poço 2) - Etapa 2** | 169d | 2019-11-04 | 2020-07-13 |  |  | 354d |
| 174 |  | Aprovar Plano de Trabalho e Abrir OSE - OeM - Captação Alternativa - Poço 2 - Pedras/MG | 10d | 2019-11-04 | 2019-11-18 | 171FS+160d |  | 354d |
| 175 |  | Elaborar Projeto Básico - Captação Alternativa - Poço 2 - Pedras/MG | 65d | 2019-11-26 | 2020-03-04 | 174FS+5d |  | 354d |
| 176 |  | Aprovar Projeto Básico com Prefeitura e Operadora - Captação Alternativa - Poço 2 - Pedras/MG | 22d | 2020-03-05 | 2020-04-03 | 175 |  | 354d |
| 177 |  | Emitir RT/PQ para Suprimentos - Captação Alternativa - Poço 2 - Pedras/MG | 10d | 2020-06-30 | 2020-07-13 | 178FF |  | 354d |
| 178 |  | Elaborar Projeto Executivo - Captação Alternativa - Poço 2 - Pedras/MG | 67d | 2020-04-06 | 2020-07-13 | 176 |  | 354d |
| 179 |  | Elaboração do Projeto Executivo - Captação Alternativa - Poço 2 - Pedras/MG | 0d | 2020-07-13 | 2020-07-13 | 178 |  | 442d |
| 180 |  | Conclusão e Validação da Engenharia - Pedras/MG | 0d | 2019-11-29 | 2019-11-29 | 166 |  | 592d |
| 181 | 3.2.1.2 | **Fundiária** | 420d | 2018-11-22 A | 2020-07-30 |  | 40% | 429d |
| 182 |  | Obter Termo de Autorização de Superficiário - Captação Alternativa (Poço 2) - Pedras/MG | 54d | 2018-11-22 A | 2019-02-06 A | 151 | 100% |  |
| 183 | 3.2.1.2.2 | **Captação Alternativa (Poço 2) - Desimpedimento de Área e Negociação de Servidão** | 80d | 2020-04-06 | 2020-07-30 |  |  | 429d |
| 184 |  | Realizar Levantamento da documentação da propriedade - Pedras/MG | 10d | 2020-04-06 | 2020-04-20 | 163FS+70d, 171FS+35d, 176, 182FS+35d |  | 429d |
| 185 |  | Obter assinatura do Contrato de servidão pelo proprietário - Pedras/MG | 20d | 2020-04-22 | 2020-05-20 | 184 |  | 429d |
| 186 |  | Lavrar Escritura Pública de Servidão no cartório de notas - Pedras/MG | 30d | 2020-05-21 | 2020-07-02 | 185 |  | 429d |
| 187 |  | Averbar a escritura pública na matrícula do imóvel - Pedras/MG | 20d | 2020-07-03 | 2020-07-30 | 186 |  | 429d |
| 188 |  | Regularização da Servidão do Imóvel - Poço 2 - Pedras/MG | 0d | 2020-07-30 | 2020-07-30 | 187 |  | 429d |
| 189 |  | Conclusão da Regularização Fundiária para as obras de Melhoria do Sistema de Abastecimento da Localidade - Pedras/MG | 0d | 2020-07-30 | 2020-07-30 | 188 |  | 429d |
| 190 | 3.2.1.3 | **Licenciamento** | 256d | 2019-02-14 A | 2020-02-28 |  | 34% | 534d |
| 191 |  | Obter Autorização de Perfuração Captação Alternativa - Poço 2 - Pedras/MG | 39d | 2019-02-14 A | 2019-04-12 A | 151, 182FS+5d | 100% |  |
| 192 | 3.2.1.3.2 | **Outorga para Captação Alternativa - Poço 2** | 76d | 2019-11-05 | 2020-02-28 |  |  | 534d |
| 193 |  | Protocolar FCE e documentos do FOB - Pedras/MG | 10d | 2019-11-05 | 2019-11-19 | 163FS+90d, 171 |  | 534d |
| 194 |  | Acompanhar Processo Junto ao Órgão - Pedras/MG | 66d | 2019-11-20 | 2020-02-28 | 193 |  | 534d |
| 195 |  | Obtenção da Outorga para captação - Poço 2 - Pedras/MG | 0d | 2020-02-28 | 2020-02-28 | 194 |  | 534d |
| 196 |  | Conclusão do Licenciamento Ambiental da Localidade - Pedras/MG | 0d | 2020-02-28 | 2020-02-28 | 191, 195 |  | 534d |
| 197 | 3.2.1.4 | **Suprimentos** | 88d | 2020-07-14 | 2020-11-17 |  |  | 354d |
| 198 |  | Realizar contratação - Captações e ETA - Pedras/MG | 88d | 2020-07-14 | 2020-11-17 | 177 |  | 354d |
| 199 |  | Conclusão da Contratação de Suprimentos para as obras de Melhoria do Sistema de Abastecimento de Água- Pedras/MG | 0d | 2020-11-17 | 2020-11-17 | 198 |  | 354d |
| 200 | 3.2.1.5 | **Infraestrutura** | 397d | 2020-11-18 | 2022-06-24 |  |  | 351d |
| 201 | 3.2.1.5.1 | **Obras** | 81d | 2020-11-18 | 2021-03-18 |  |  | 354d |
| 202 |  | Executar obras de Captação Alternativa (Urbanização e Adução) - Poço 2 - Pedras/MG | 81d | 2020-11-18 | 2021-03-18 | 165, 179, 187, 188, 195, 198, 199, 180, 189, 196 |  | 354d |
| 203 |  | Assinatura de Termo de Entrega das Obras de Melhoria do Sistema de Abastecimento de Água - Pedras/MG | 0d | 2021-03-18 | 2021-03-18 | 202 |  | 667d |
| 204 | 3.2.1.5.2 | **Operação** | 316d | 2021-03-19 | 2022-06-24 |  |  | 351d |
| 205 |  | Realizar Treinamento Operacional do Sistema - Pedras/MG | 5d | 2021-03-19 | 2021-03-25 | 202 |  | 354d |
| 206 |  | Realizar Testes e Pré-operação - Pedras/MG | 14d | 2021-03-26 | 2021-04-15 | 205 |  | 354d |
| 207 |  | Realizar Acompanhamento da Funcionalidade do Sistema - Captação Alternativa (Poço Tubular) - Pedras (distrito Mariana/MG) | 365ed | 2021-06-24 | 2022-06-24 | 209 |  | 1549.12d |
| 208 | 3.2.1.5.2.4 | **Operação Assistida** | 61d | 2021-03-26 | 2021-06-24 |  |  | 353d |
| 209 |  | Realizar Operação Assistida - Pedras/MG | 90ed | 2021-03-26 | 2021-06-24 | 202, 206SS |  | 1549.12d |
| 210 |  | Entrega das obras e conclusão do período de acompanhamento da operação - Pedras/MG | 0d | 2022-06-24 | 2022-06-24 | 203, 207 |  | 351d |

| ID | WBS | Task | Duration | Start | Finish | Predecessors | Complete | Total float |
| --- | --- | --- | --- | --- | --- | --- | --- | --- |
| 211 | 3.2.2 | **ETA (Sistema de Tratamento Simplificado) e Captação Principal (Nascente)** | 1216d | 2018-03-23 A | 2023-01-28 |  |  | 201d |
| 212 | 3.2.2.1 | **Engenharia** | 252d | 2019-11-04 | 2020-11-10 |  |  | 202d |
| 213 | 3.2.2.1.1 | **Estudos de Concepção do Sistema** | 62d | 2020-08-12 | 2020-11-10 |  |  | 202d |
| 214 | 3.2.2.1.1.1 | **Serviço em Nascente - Captação Principal** | 62d | 2020-08-12 | 2020-11-10 |  |  | 202d |
| 215 |  | Realizar Recuperação de Nascente - Captação Principal - Pedras/MG | 40d | 2020-08-12 | 2020-10-07 | 237FS+80d |  | 202d |
| 216 |  | Elaborar Relatório Técnico - Captação Principal - Pedras/MG | 22d | 2020-10-08 | 2020-11-10 | 215 |  | 202d |
| 217 |  | Realizar Laudo de Serviços de Coleta e Análise de Água - Captação Principal - Pedras/MG | 22d | 2020-10-08 | 2020-11-10 | 215 |  | 419d |
| 218 |  | Conclusão dos Serviços em nascente - Captação Principal - Pedras/MG | 0d | 2020-11-10 | 2020-11-10 | 216, 217 |  | 419d |
| 219 |  | Conclusão dos Estudos de Concepção das Melhorias do Sistema de Abastecimento de Água - Pedras/MG | 0d | 2020-11-10 | 2020-11-10 | 218 |  | 753d |
| 220 | 3.2.2.1.2 | **Engenharia Básica e Detalhada** | 169d | 2019-11-04 | 2020-07-13 |  |  | 202d |
| 221 | 3.2.2.1.2.1 | **Engenharia Captação Principal (Nascente)** | 169d | 2019-11-04 | 2020-07-13 |  |  | 202d |
| 222 |  | Aprovar Plano de Trabalho e Abrir OSE - OeM - Captação Principal - Pedras/MG | 10d | 2019-11-04 | 2019-11-18 | 171FS+160d |  | 202d |
| 223 |  | Elaborar Projeto Básico - Captação Principal - Nascente - Pedras/MG | 65d | 2019-11-26 | 2020-03-04 | 222FS+5d |  | 202d |
| 224 |  | Aprovar Projeto Básico com Prefeitura/Operadora - Captação Principal - Nascente - Pedras/MG | 22d | 2020-03-05 | 2020-04-03 | 223 |  | 414d |
| 225 |  | Emitir RT/PQ para Suprimentos - Captação Principal - Nascente - Pedras/MG | 10d | 2020-06-30 | 2020-07-13 | 226FF |  | 414d |
| 226 |  | Elaborar Projeto Executivo - Captação Principal - Nascente - Pedras/MG | 67d | 2020-04-06 | 2020-07-13 | 223, 224 |  | 414d |
| 227 |  | Elaboração do Projeto Executivo - Captação Principal - Nascente - Pedras/MG | 0d | 2020-07-13 | 2020-07-13 | 226 |  | 502d |
| 228 | 3.2.2.1.2.2 | **Engenharia ETA (Sistema de Tratamento Simplificado)** | 169d | 2019-11-04 | 2020-07-13 |  |  | 414d |
| 229 |  | Aprovar Plano de Trabalho e Abrir OSE - OeM - ETA - Pedras/MG | 10d | 2019-11-04 | 2019-11-18 | 171FS+160d |  | 414d |
| 230 |  | Elaborar Projeto Básico - ETA - Pedras/MG | 65d | 2019-11-26 | 2020-03-04 | 229FS+5d |  | 414d |
| 231 |  | Aprovar Projeto Básico com Prefeitura/Operadora - ETA - Pedras/MG | 22d | 2020-03-05 | 2020-04-03 | 230 |  | 414d |
| 232 |  | Emitir RT/PQ para Suprimentos - ETA - Pedras/MG | 10d | 2020-06-30 | 2020-07-13 | 233FF |  | 414d |
| 233 |  | Elaborar Projeto Executivo - ETA - Pedras/MG | 67d | 2020-04-06 | 2020-07-13 | 231, 224 |  | 414d |
| 234 |  | Elaboração do Projeto Executivo - ETA - Pedras/MG | 0d | 2020-07-13 | 2020-07-13 | 233 |  | 502d |
| 235 |  | Conclusão e Validação da Engenharia - Pedras/MG | 0d | 2020-11-10 | 2020-11-10 | 219 |  | 753d |
| 236 | 3.2.2.2 | **Fundiária** | 602d | 2018-03-23 A | 2020-08-11 |  | 3% | 815d |
| 237 |  | Obter Termo de Autorização de Superficiário - Captação Principal (Nascente) - Pedras/MG | 30d | 2020-03-05 | 2020-04-16 | 223 |  | 202d |
| 238 |  | Obter Termo de Autorização de Superficiário - ETA - Pedras/MG | 5d | 2018-03-23 A | 2018-03-29 A |  | 100% |  |
| 239 | 3.2.2.2.3 | **Captação Principal (Nascente) - Desimpedimento de Área e Negociação de Servidão** | 80d | 2020-04-17 | 2020-08-11 |  |  | 481d |
| 240 |  | Realizar Levantamento da documentação da propriedade - Pedras/MG | 10d | 2020-04-17 | 2020-05-04 | 237, 224 |  | 481d |
| 241 |  | Obter assinatura do Contrato de servidão pelo proprietário - Pedras/MG | 20d | 2020-05-05 | 2020-06-01 | 240 |  | 481d |
| 242 |  | Lavrar Escritura Pública de Servidão no cartório de notas - Pedras/MG | 30d | 2020-06-02 | 2020-07-14 | 241 |  | 481d |
| 243 |  | Averbar a escritura pública na matrícula do imóvel - Pedras/MG | 20d | 2020-07-15 | 2020-08-11 | 242 |  | 481d |
| 244 |  | Regularização da Servidão - Nascente - Pedras/MG | 0d | 2020-08-11 | 2020-08-11 | 243 |  | 481d |
| 245 | 3.2.2.2.4 | **ETA/Reservatório - Desimpedimento de Área e Negociação de Servidão** | 80d | 2020-03-05 | 2020-06-30 |  |  | 511d |
| 246 |  | Realizar Levantamento da documentação da propriedade - Pedras/MG | 10d | 2020-03-05 | 2020-03-18 | 238, 230 |  | 511d |
| 247 |  | Obter assinatura do Contrato de servidão pelo proprietário - Pedras/MG | 20d | 2020-03-19 | 2020-04-16 | 246 |  | 511d |
| 248 |  | Lavrar Escritura Pública de Servidão no cartório de notas - Pedras/MG | 30d | 2020-04-17 | 2020-06-01 | 247 |  | 511d |
| 249 |  | Averbar a escritura pública na matrícula do imóvel - Pedras/MG | 20d | 2020-06-02 | 2020-06-30 | 248 |  | 511d |
| 250 |  | Regularização da Servidão - ETA/Resrvatório - Pedras/MG | 0d | 2020-06-30 | 2020-06-30 | 249 |  | 511d |
| 251 |  | Conclusão da Regularização Fundiária para as obras de Melhoria do Sistema de Abastecimento da Localidade - Pedras/MG | 0d | 2020-08-11 | 2020-08-11 | 244, 249, 250 |  | 815d |
| 252 | 3.2.2.3 | **Licenciamento** | 367d | 2020-04-06 | 2021-09-23 |  |  | 352d |
| 253 | 3.2.2.3.1 | **Captação Alternativa (Nascente) - Certidão de Uso Insignificante e DAIA para acumulação de água** | 217d | 2020-11-11 | 2021-09-23 |  |  | 202d |
| 254 |  | Enviar a documentação ao SAAE para obter a certidão de uso insignificante - Pedras/MG | 1d | 2020-11-11 | 2020-11-11 | 216, 237 |  | 202d |
| 255 |  | Realizar Análise Inicial da Demanda para DAIA para acumulação de água - Pedras/MG | 10d | 2020-11-12 | 2020-11-25 | 216, 254 |  | 202d |
| 256 |  | Elaborar Estudos Ambientais para DAIA para acumulação de água - Pedras/MG | 30d | 2020-11-26 | 2021-01-11 | 255 |  | 202d |
| 257 |  | Acompanhar Processo Junto ao Órgão para DAIA para acumulação de água - Pedras/MG | 176d | 2021-01-12 | 2021-09-23 | 256 |  | 202d |
| 258 |  | Obtenção de DAIA para acumulação de água - Nascente - Pedras/MG | 0d | 2021-09-23 | 2021-09-23 | 257 |  | 202d |
| 259 |  | Realizar diagnóstico para verificar a necessidade de licença do SAA - Pedras/MG | 120d | 2020-04-06 | 2020-09-25 | 231 |  | 449d |
| 260 |  | Conclusão do Licenciamento Ambiental da Localidade - Pedras/MG | 0d | 2021-09-23 | 2021-09-23 | 258, 259 |  | 536d |
| 261 | 3.2.2.4 | **Suprimentos** | 88d | 2020-07-14 | 2020-11-17 |  |  | 414d |
| 262 |  | Realizar contratação - Captações e ETA - Pedras/MG | 88d | 2020-07-14 | 2020-11-17 | 225, 232 |  | 414d |
| 263 |  | Conclusão da Contratação de Suprimentos para as obras de Melhoria do Sistema de Abastecimento de Água- Pedras/MG | 0d | 2020-11-17 | 2020-11-17 | 262 |  | 414d |
| 264 | 3.2.2.5 | **Infraestrutura** | 547d | 2020-11-18 | 2023-01-28 |  |  | 201d |
| 265 |  | Executar obras na Captação Principal (Nascente) - Pedras/MG | 81d | 2021-09-24 | 2022-01-20 | 243, 244, 258, 262, 263, 218, 227 |  | 202d |
| 266 |  | Executar obras da ETA (Sistema de Tratamento Simplificado/Melhorias no reservatório) - Pedras/MG | 81d | 2020-11-18 | 2021-03-18 | 249, 250, 259, 262, 263, 234 |  | 414d |
| 267 |  | Assinatura de Termo de Entrega das Obras de Melhoria do Sistema de Abastecimento de Água - Pedras/MG | 0d | 2022-01-20 | 2022-01-20 | 265, 266 |  | 455d |
| 268 | 3.2.2.5.4 | **Operação** | 254d | 2022-01-21 | 2023-01-28 |  |  | 201d |
| 269 |  | Realizar Treinamento Operacional do Sistema - Pedras/MG | 5d | 2022-01-21 | 2022-01-27 | 265, 266 |  | 202d |
| 270 |  | Realizar Testes e Pré-operação - Pedras/MG | 14d | 2022-01-28 | 2022-02-16 | 269 |  | 202d |
| 271 |  | Realizar Acompanhamento da Funcionalidade do Sistema - ETA (Sistema de Tratamento Simplificado) e Captação Principal (Nascente) - Pedras (distrito Mariana/MG) | 365ed | 2022-01-28 | 2023-01-28 | 273SS |  | 895.12d |
| 272 | 3.2.2.5.4.4 | **Operação Assistida** | 59d | 2022-01-28 | 2022-04-28 |  |  | 202d |
| 273 |  | Realizar Operação Assistida - Pedras/MG | 90ed | 2022-01-28 | 2022-04-28 | 265, 266, 270SS |  | 895.12d |
| 274 |  | Entrega das obras e conclusão do período de acompanhamento da operação - Pedras/MG | 0d | 2023-01-28 | 2023-01-28 | 267, 271 |  | 201d |
| 275 | 4 | **Território Alto Rio Doce** | 1365d | 2016-12-20 A | 2022-05-13 |  | 16% | 380d |
| 276 | 4.1 | **Gesteira (distrito Barra Longa/MG)** | 1105d | 2016-12-20 A | 2021-04-29 |  | 29% | 640d |
| 277 | 4.1.1 | **Captação Principal/Alternativa/ETA** | 651d | 2016-12-20 A | 2019-06-28 A |  | 100% |  |
| 278 | 4.1.1.1 | **Estudos de Concepção do Sistema** | 395d | 2016-12-20 A | 2018-06-25 A |  | 100% |  |
| 279 |  | Elaboração do Relatório Obra - Gesteira/MG | 0d | 2018-03-23 A | 2018-03-23 A | 26 | 100% |  |
| 280 | 4.1.1.1.2 | **Serviços em Poços Tubulares - Captação Principal** | 395d | 2016-12-20 A | 2018-06-25 A |  | 100% |  |

| ID | WBS | Task | Duration | Start | Finish | Predecessors | Complete | Total float |
| --- | --- | --- | --- | --- | --- | --- | --- | --- |
| 281 |  | Realizar Perfilagem (Poço Beira Rio) - Gesteira/MG | 1d | 2018-06-21 A | 2018-06-21 A | 279FS+65d | 100% |  |
| 282 |  | Realizar Limpeza (Poço Beira Rio) - Gesteira/MG | 1d | 2018-06-22 A | 2018-06-22 A | 281 | 100% |  |
| 283 |  | Elaborar Relatório Técnico (Poço Beira Rio) - Gesteira/MG | 26d | 2018-05-21 A | 2018-06-25 A | 281FF, 282FF | 100% |  |
| 284 |  | Realizar Laudo Serviços de Coleta e Análise de Água (Poço Beira Rio) - Gesteira/MG | 26d | 2018-05-21 A | 2018-06-25 A | 283FF | 100% |  |
| 285 |  | Realizar Perfuração/Instrumentação (Poço Posto de Saúde) - Gesteira/MG | 2d | 2016-12-20 A | 2016-12-21 A | 24 | 100% |  |
| 286 |  | Elaborar Relatório Técnico (Poço Posto de Saúde) - Gesteira/MG | 19d | 2016-12-22 A | 2017-01-17 A | 285 | 100% |  |
| 287 |  | Realizar Laudo Serviços de Coleta e Análise de Água (Poço Posto de Saúde) - Gesteira/MG | 9d | 2017-10-03 A | 2017-10-13 A | 285FS+203d | 100% |  |
| 288 |  | Conclusão dos Serviços em poço tubular - Gesteira/MG | 0d | 2017-10-13 A | 2017-10-13 A | 287 | 100% |  |
| 289 |  | Conclusão dos Estudos de Concepção das Melhorias do Sistema de Abastecimento de Água - Gesteira/MG | 0d | 2018-06-25 A | 2018-06-25 A | 281, 282, 283, 284, 285, 286, 288 | 100% |  |
| 290 | 4.1.1.2 | **Engenharia Básica e Detalhada** | 433d | 2017-10-20 A | 2019-06-28 A |  | 100% |  |
| 291 |  | Elaborar projeto de Engenharia Captação Principal - Poço Beira Rio (existente) - Gesteira/MG | 60d | 2018-03-09 A | 2018-05-31 A | 26 | 100% |  |
| 292 | 4.1.1.2.2 | **Engenharia** | 33d | 2017-10-20 A | 2017-12-05 A |  | 100% |  |
| 293 |  | Elaborar Projeto Executivo Melhorias de ETA - Melhorias na ETA - Gesteira/MG | 33d | 2017-10-20 A | 2017-12-05 A | 288, 26SS | 100% |  |
| 294 | 4.1.1.2.3 | **Engenharia (Adutora Poço Beira-Rio e Reservatório)** | 245d | 2018-07-11 A | 2019-06-28 A |  | 100% |  |
| 295 |  | Aprovar Plano de Trabalho /abertura OSE + Levantamento de Campo (Projeto Reservatório + adutora) - Melhorias na ETA - Gesteira/MG | 81d | 2018-07-11 A | 2018-10-31 A | 293 | 100% |  |
| 296 |  | Emitir RT/PQ para Suprimentos - Melhorias na ETA - Gesteira/MG | 11d | 2019-05-17 A | 2019-05-31 A | 297FF | 100% |  |
| 297 |  | Elaborar Projeto Executivo - Melhorias na ETA - Gesteira/MG | 174d | 2018-10-18 A | 2019-06-28 A | 295SS+71d | 100% |  |
| 298 |  | Elaboração do Projeto Executivo - Melhorias na ETA - Gesteira/MG | 0d | 2019-06-28 A | 2019-06-28 A | 297, 289 | 100% |  |
| 299 | 4.1.1.3 | **Fundiária** | 95d | 2018-07-23 A | 2018-11-30 A |  | 100% |  |
| 300 |  | Obter Autorização de Acesso e Documento do Superficiário - Gesteira/MG | 95d | 2018-07-23 A | 2018-11-30 A | 279 | 100% |  |
| 301 |  | Conclusão da Regularização Fundiária para as obras de Melhoria do Sistema de Abastecimento da Localidade - Gesteira/MG | 0d | 2018-11-30 A | 2018-11-30 A | 300 | 100% |  |
| 302 | 4.1.1.4 | **Infraestrutura** | 174d | 2017-11-01 A | 2018-07-02 A |  | 100% |  |
| 303 | 4.1.1.4.1 | **Obras - Etapa 1** | 174d | 2017-11-01 A | 2018-07-02 A |  | 100% |  |
| 304 |  | Executar Melhorias na ETA - Gesteira/MG | 2.1mo | 2017-11-01 A | 2017-12-28 A | 24, 296 | 100% |  |
| 305 |  | Executar Captação Principal - Poço Beira Rio - Gesteira/MG | 22d | 2018-06-01 A | 2018-07-02 A | 291 | 100% |  |
| 306 |  | Executar Captação Alternativa (Poço - área Posto de Saúde) - Gesteira/MG | 42d | 2017-11-01 A | 2017-12-28 A | 304SS | 100% |  |
| 307 |  | Assinatura de Termo de Entrega das Obras de Melhoria do Sistema de Abastecimento de Água - Gesteira/MG | 0d | 2018-07-02 A | 2018-07-02 A | 305, 306, 298 | 100% |  |
| 308 | 4.1.2 | **Reforma do Reservatório + Adutora Poço Centro de Saúde + Melhorias no Acesso** | 390d | 2019-09-27 A | 2021-04-29 |  |  | 640d |
| 309 | 4.1.2.1 | **Infraestrutura** | 390d | 2019-09-27 A | 2021-04-29 |  |  | 640d |
| 310 | 4.1.2.1.1 | **Obras - Etapa 2** | 142d | 2019-09-27 A | 2020-04-28 |  |  | 888d |
| 311 |  | Definição de novo escopo - Reforma do Reservatório + Adutora Poço Centro de Saúde + Melhorias no Acesso - Gesteira/MG | 0d | 2019-09-27 A | 2019-09-27 A | 307FS+315d | 100% |  |
| 312 |  | Executar Reforma Adutora Poço Beira Rio existente - Gesteira/MG | 110d | 2019-11-13 | 2020-04-28 | 311FS+32d |  | 640d |
| 313 |  | Executar Melhoria em ETA - Ampliação do reservatório - Gesteira/MG | 110d | 2019-11-13 | 2020-04-28 | 311FS+32d |  | 640d |
| 314 |  | Assinatura de Termo de Entrega das Obras de Melhoria do Sistema de Abastecimento de Água - Gesteira/MG | 0d | 2020-04-28 | 2020-04-28 | 312, 313 |  | 888d |
| 315 | 4.1.2.1.2 | **Operação** | 248d | 2020-04-29 | 2021-04-29 |  |  | 640d |
| 316 |  | Realizar Treinamento Operacional do Sistema - Gesteira/MG | 5d | 2020-04-29 | 2020-05-06 | 312, 313 |  | 640d |
| 317 |  | Realizar Testes e Pré-operação - Gesteira/MG | 14d | 2020-04-29 | 2020-05-19 | 316SS |  | 640d |
| 318 |  | Realizar Acompanhamento da Funcionalidade do Sistema - Reforma do Reservatório + Adutora Poço Centro de Saúde + Melhorias no Acesso - Gesteira (distrito Barra Longa/MG) | 365ed | 2020-04-29 | 2021-04-29 | 320SS |  | 2812.12d |
| 319 | 4.1.2.1.2.4 | **Operação Assistida** | 248d | 2020-04-29 | 2021-04-29 |  |  | 640d |
| 320 |  | Realizar Operação Assistida - Gesteira/MG | 90ed | 2020-04-29 | 2020-07-28 | 312, 313, 317SS |  | 2812.12d |
| 321 |  | Entrega das obras e conclusão do período de acompanhamento da operação - Gesteira/MG | 0d | 2021-04-29 | 2021-04-29 | 318, 320 |  | 640d |
| 322 | 4.2 | **Barreto (distrito Barra Longa/MG)** | 1082d | 2018-01-19 A | 2022-05-13 |  | 6% | 380d |
| 323 | 4.2.1 | **Captação Principal/Alternativa/ETA/Adução** | 1082d | 2018-01-19 A | 2022-05-13 |  | 6% | 380d |
| 324 | 4.2.1.1 | **Estudos de Concepção do Sistema - Etapa 1** | 350d | 2018-01-19 A | 2019-06-03 A |  | 100% |  |
| 325 |  | Declaração de Escopo e Premissas de Projeto (DEPP) concluída - Barreto/MG | 0d | 2018-03-23 A | 2018-03-23 A | 25, 26 | 100% |  |
| 326 |  | Revisão de Definições - Barreto/MG | 0d | 2018-03-23 A | 2018-03-23 A | 325 | 100% |  |
| 327 |  | Aprovação das DEPPs pela Operadora e Prefeitura - Barreto/MG | 0d | 2018-04-16 A | 2018-04-16 A | 325, 326FS+17d | 100% |  |
| 328 | 4.2.1.1.4 | **Estudos de Geofísica para Poço Tubular** | 24d | 2018-01-19 A | 2018-02-21 A |  | 100% |  |
| 329 |  | Executar Levantamento de Campo - Barreto/MG | 24d | 2018-01-19 A | 2018-02-21 A | 26FS+44d | 100% |  |
| 330 |  | Emitir Relatório - Barreto/MG | 15d | 2018-02-01 A | 2018-02-21 A | 329FF | 100% |  |
| 331 |  | Conclusão dos Estudos de Geofísica para Poço Tubular - Barreto/MG | 0d | 2018-02-21 A | 2018-02-21 A | 330 | 100% |  |
| 332 | 4.2.1.1.5 | **Serviços em Poços Tubulares - Poço Seco** | 6d | 2019-04-08 A | 2019-04-15 A |  | 100% |  |
| 333 |  | Realizar Perfuração - Barreto/MG | 5d | 2019-04-08 A | 2019-04-12 A | 327 | 100% |  |
| 334 |  | Realizar Tamponamento - Barreto/MG | 1d | 2019-04-15 A | 2019-04-15 A | 333 | 100% |  |
| 335 |  | Conclusão dos Serviços em Poços Tubulares - Captação Principal concluído - Barreto/MG | 0d | 2019-04-15 A | 2019-04-15 A | 334 | 100% |  |
| 336 | 4.2.1.1.6 | **Captações Superficiais (Captação Alternativa) - Nascente 1 (Córrego Sem Nome)** | 104d | 2018-05-01 A | 2018-09-21 A |  | 100% |  |
| 337 |  | Realizar Recuperação de Nascente - Nascente 1 (Córrego Sem Nome) - Captação Alternativa - Barreto/MG | 60d | 2018-05-01 A | 2018-07-23 A | 327, 365 | 100% |  |
| 338 |  | Elaborar Relatório Técnico - Nascente 1 (Córrego Sem Nome) - Captação Alternativa - Barreto/MG | 22d | 2018-07-24 A | 2018-08-22 A | 337 | 100% |  |
| 339 |  | Realizar Laudo de Serviços de Coleta e Análise de Água Preliminar - Nascente 1 (Córrego Sem Nome) - Captação Alternativa - Barreto/MG | 18d | 2018-08-29 A | 2018-09-21 A | 26 | 100% |  |
| 340 |  | Realizar Laudo de Serviços de Coleta e Análise de Água Final - Nascente 1 (Córrego Sem Nome) - Captação Alternativa - Barreto/MG | 22d | 2018-07-24 A | 2018-08-22 A | 337 | 100% |  |
| 341 |  | Conclusão da Recuperação da Nascente 1 - Captação Alternativa- Barreto/MG | 0d | 2018-08-22 A | 2018-08-22 A | 338, 340 | 100% |  |
| 342 |  | Definição de Nacente para Captação - Nascente 2 (Córrego Barroso) - Captação Principal - Barreto/MG | 0d | 2019-06-03 A | 2019-06-03 A | 334FS+32d | 100% |  |
| 343 | 4.2.1.2 | **Estudos de Concepção do Sistema - Etapa 2** | 79d | 2020-04-23 | 2020-08-13 |  |  | 411d |
| 344 | 4.2.1.2.1 | **Captações Superficiais (Captação Principal) - Nascente 2 (Córrego Barreto)** | 79d | 2020-04-23 | 2020-08-13 |  |  | 411d |
| 345 |  | Realizar Recuperação de Nascente - Nascente 2 (Córrego Barreto) - Captação Principal - Barreto/MG | 57d | 2020-04-23 | 2020-07-14 | 342, 366FS+90d |  | 411d |
| 346 |  | Elaborar Relatório Técnico - Nascente 2 (Córrego Barreto) - Captação Principal - Barreto/MG | 22d | 2020-07-15 | 2020-08-13 | 345 |  | 411d |
| 347 |  | Realizar Laudo de Serviços de Coleta e Análise de Água - Nascente 2 (Córrego Barreto) - Captação Principal - Barreto/MG | 22d | 2020-07-15 | 2020-08-13 | 345 |  | 813d |
| 348 |  | Conclusão da Recuperação da Nascente 2 (Córrego Barreto) - Captação Principal - Barreto/MG | 0d | 2020-08-13 | 2020-08-13 | 347 |  | 813d |
| 349 |  | Conclusão dos Estudos de Concepção das Melhorias do Sistema de Abastecimento de Água - Barreto/MG | 0d | 2020-08-13 | 2020-08-13 | 331, 335, 341, 348 |  | 813d |
| 350 | 4.2.1.3 | **Engenharia Básica e Detalhada** | 197d | 2019-11-22 | 2020-09-09 |  |  | 382d |

| ID | WBS | Task | Duration | Start | Finish | Predecessors | Complete | Total float |
| --- | --- | --- | --- | --- | --- | --- | --- | --- |
| 351 | 4.2.1.3.1 | **Engenharia Captação Principal/Alternativa/ETA/Adução** | 177d | 2019-11-22 | 2020-08-11 |  |  | 382d |
| 352 |  | Aprovar Plano de Trabalho e abrir OSE - Captação Principal/Alternativa/ETA/Adução - Barreto/MG | 10d | 2019-11-22 | 2019-12-05 | 342FS+120d |  | 382d |
| 353 |  | Executar Topografia - Captação Principal/Alternativa/ETA/Adução - Barreto/MG | 15d | 2019-12-06 | 2019-12-31 | 352 |  | 382d |
| 354 |  | Elaborar Projeto Básico - Captação Principal/Alternativa/ETA/Adução - Barreto/MG | 60d | 2020-01-02 | 2020-03-30 | 353 |  | 382d |
| 355 |  | Aprovar Projeto Básico - Captação Principal/Alternativa/ETA/Adução - Barreto/MG | 22d | 2020-03-31 | 2020-05-04 | 354 |  | 382d |
| 356 |  | Emitir RT/PQ para Suprimentos - Captação Principal/Alternativa/ETA/Adução - Barreto/MG | 10d | 2020-07-29 | 2020-08-11 | 354, 355, 357FF |  | 382d |
| 357 |  | Elaborar Projeto Executivo - Captação Principal/Alternativa/ETA/Adução - Barreto/MG | 70d | 2020-05-05 | 2020-08-11 | 354, 339, 340, 355 |  | 382d |
| 358 |  | Elaboração do Projeto Executivo - Captação Alternativa - Nascente 1 - Barreto/MG | 0d | 2020-08-11 | 2020-08-11 | 354, 357 |  | 470d |
| 359 |  | Elaboração do Projeto Executivo - Captação Principal - Nascente 2 - Barreto/MG | 0d | 2020-08-11 | 2020-08-11 | 357 |  | 482d |
| 360 |  | Elaboração do Projeto Executivo - ETA- Barreto/MG | 0d | 2020-08-11 | 2020-08-11 | 357 |  | 470d |
| 361 | 4.2.1.3.2 | **Validação dos Projetos** | 20d | 2020-08-12 | 2020-09-09 |  |  | 795d |
| 362 |  | Validar Projetos com Prefeitura e Operadora - Barreto/MG | 20d | 2020-08-12 | 2020-09-09 | 354, 357, 359 |  | 795d |
| 363 |  | Validação com Prefeitura e Operadora dos Projetos de Melhoria do Sistema de Abastecimento de Água - Barreto/MG | 0d | 2020-09-09 | 2020-09-09 | 362 |  | 795d |
| 364 | 4.2.1.4 | **Fundiária** | 578d | 2018-04-17 A | 2020-07-31 |  | 6% | 477d |
| 365 |  | Obter Termo de Autorização do Superficiário - Captação Alternativa (Nascente 1) - Barreto/MG | 10d | 2018-04-17 A | 2018-04-30 A | 327 | 100% |  |
| 366 |  | Obter Termo de Autorização do Superficiário - Captação Alternativa (Nascente 2) - Barreto/MG | 10d | 2019-11-22 | 2019-12-05 | 342FS+120d |  | 411d |
| 367 |  | Obter Termo de Autorização de Superficiário - ETA / UTR - Barreto/MG | 10d | 2018-04-17 A | 2018-04-30 A | 327 | 100% |  |
| 368 | 4.2.1.4.4 | **Captação Alternativa (Nascente 1) - Desimpedimento de Área e Negociação de Servidão** | 80d | 2019-12-06 | 2020-04-06 |  |  | 557d |
| 369 |  | Realizar Levantamento da documentação da propriedade - Barreto/MG | 10d | 2019-12-06 | 2019-12-20 | 365, 375SS |  | 557d |
| 370 |  | Obter assinatura do Contrato de servidão pelo proprietário - Barreto/MG | 20d | 2019-12-23 | 2020-01-22 | 369 |  | 557d |
| 371 |  | Lavrar Escritura Pública de Servidão no cartório de notas - Barreto/MG | 30d | 2020-01-23 | 2020-03-09 | 370 |  | 557d |
| 372 |  | Averbar a escritura pública na matrícula do imóvel - Barreto/MG | 20d | 2020-03-10 | 2020-04-06 | 371 |  | 557d |
| 373 |  | Regularização da Servidão - Nascente 1 - Barreto/MG | 0d | 2020-04-06 | 2020-04-06 | 372 |  | 557d |
| 374 | 4.2.1.4.5 | **Captação Alternativa (Nascente 2) - Desimpedimento de Área e Negociação de Servidão** | 80d | 2019-12-06 | 2020-04-06 |  |  | 477d |
| 375 |  | Realizar Levantamento da documentação da propriedade - Barreto/MG | 10d | 2019-12-06 | 2019-12-20 | 366 |  | 477d |
| 376 |  | Obter assinatura do Contrato de servidão pelo proprietário - Barreto/MG | 20d | 2019-12-23 | 2020-01-22 | 375 |  | 557d |
| 377 |  | Lavrar Escritura Pública de Servidão no cartório de notas - Barreto/MG | 30d | 2020-01-23 | 2020-03-09 | 376 |  | 557d |
| 378 |  | Averbar a escritura pública na matrícula do imóvel - Barreto/MG | 20d | 2020-03-10 | 2020-04-06 | 377 |  | 557d |
| 379 |  | Regularização da Servidão (Nascente 2) - Barreto/MG | 0d | 2020-04-06 | 2020-04-06 | 378 |  | 557d |
| 380 | 4.2.1.4.6 | **ETA (STA Simplificado)/Adutora - Desimpedimento de Área e Negociação de Servidão** | 160d | 2019-12-06 | 2020-07-31 |  |  | 477d |
| 381 |  | Realizar Levantamento da documentação da propriedade - Barreto/MG | 10d | 2019-12-06 | 2019-12-20 | 367, 375SS |  | 477d |
| 382 |  | Obter assinatura do Contrato de servidão pelo proprietário - Barreto/MG | 20d | 2019-12-23 | 2020-01-22 | 381 |  | 477d |
| 383 |  | Lavrar Escritura Pública de Servidão no cartório de notas - Barreto/MG | 110d | 2020-01-23 | 2020-07-03 | 382 |  | 477d |
| 384 |  | Averbar a escritura pública na matrícula do imóvel - Barreto/MG | 20d | 2020-07-06 | 2020-07-31 | 383 |  | 477d |
| 385 |  | Regularização da Servidão - ETA (STA Simplificado)/Adutora - Barreto/MG | 0d | 2020-07-31 | 2020-07-31 | 384 |  | 477d |
| 386 |  | Conclusão da Regularização Fundiária para as obras de Melhoria do Sistema de Abastecimento da Localidade - Barreto/MG | 0d | 2020-07-31 | 2020-07-31 | 365, 367, 373, 379, 385 |  | 477d |
| 387 | 4.2.1.5 | **Licenciamento** | 248d | 2019-11-22 | 2020-11-23 |  |  | 411d |
| 388 | 4.2.1.5.1 | **Captação Alternativa (Nascente 1) - Certidão de Uso Insignificante e DAIA para acumulação de água** | 217d | 2019-11-22 | 2020-10-07 |  |  | 430d |
| 389 |  | Enviar a documentação à prefeitura para obter a certidão de uso insignificante - Barreto/MG | 1d | 2019-11-22 | 2019-11-22 | 338, 365, 366SS |  | 430d |
| 390 |  | Realizar Análise Inicial da Demanda para DAIA para acumulação de água - Barreto/MG | 10d | 2019-11-25 | 2019-12-06 | 338, 389 |  | 430d |
| 391 |  | Elaborar Estudos Ambientais para DAIA para acumulação de água - Barreto/MG | 30d | 2019-12-09 | 2020-01-23 | 390 |  | 430d |
| 392 |  | Acompanhar Processo Junto ao Órgão para DAIA para acumulação de água - Barreto/MG | 176d | 2020-01-24 | 2020-10-07 | 391 |  | 430d |
| 393 |  | Obtenção de DAIA para acumulação de água - Nascente 1 - Barreto/MG | 0d | 2020-10-07 | 2020-10-07 | 392 |  | 430d |
| 394 | 4.2.1.5.2 | **Captação Alternativa (Nascente 2) - Certidão de Uso Insignificante e DAIA para acumulação de água** | 238d | 2019-12-06 | 2020-11-23 |  |  | 411d |
| 395 |  | Enviar a documentação à prefeitura para obter a certidão de uso insignificante - Barreto/MG | 1d | 2019-12-06 | 2019-12-06 | 366 |  | 579d |
| 396 |  | Realizar Análise Inicial da Demanda para DAIA para acumulação de água - Barreto/MG | 10d | 2020-08-14 | 2020-08-27 | 346, 395 |  | 411d |
| 397 |  | Elaborar Estudos Ambientais para DAIA para acumulação de água - Barreto/MG | 15d | 2020-08-28 | 2020-09-18 | 396 |  | 411d |
| 398 |  | Acompanhar Processo Junto ao Órgão para DAIA para acumulação de água - Barreto/MG | 44d | 2020-09-21 | 2020-11-23 | 397 |  | 411d |
| 399 |  | Obtenção de DAIA para acumulação de água - Nascente 2 - Barreto/MG | 0d | 2020-11-23 | 2020-11-23 | 398 |  | 411d |
| 400 |  | Realizar diagnóstico para verificar a necessidade de licença do SAA - Barreto/MG | 22d | 2020-08-12 | 2020-09-11 | 356 |  | 448d |
| 401 |  | Conclusão do Licenciamento Ambiental da Localidade - Barreto/MG | 0d | 2020-11-23 | 2020-11-23 | 393, 399, 400 |  | 411d |
| 402 | 4.2.1.6 | **Suprimentos** | 88d | 2020-08-12 | 2020-12-16 |  |  | 382d |
| 403 |  | Suprimentos - Captações, ETA, Adução - Barreto/MG | 88d | 2020-08-12 | 2020-12-16 | 356 |  | 382d |
| 404 |  | Conclusão da Contratação de Suprimentos das obras de Melhoria do Sistema de Abastecimento de Água - Barreto/MG | 0d | 2020-12-16 | 2020-12-16 | 403 |  | 382d |
| 405 | 4.2.1.7 | **Infraestrutura** | 347d | 2020-12-17 | 2022-05-13 |  |  | 380d |
| 406 | 4.2.1.7.1 | **Obras** | 97d | 2020-12-17 | 2021-05-12 |  |  | 382d |
| 407 |  | Executar Captação Alternativa/Adução (Nascente 1) / Captação Principal/Adução (Nascente 2) - Barreto/MG | 97d | 2020-12-17 | 2021-05-12 | 357, 372, 373, 393, 404, 358 |  | 382d |
| 408 |  | Executar Captação Principal/Adução (Nascente 2) - Barreto/MG | 85d | 2020-12-17 | 2021-04-26 | 378, 379, 399, 403, 359, 401 |  | 394d |
| 409 |  | Executar ETA (Sistema de Tratamento Simplificado) - Barreto/MG | 97d | 2020-12-17 | 2021-05-12 | 384, 385, 400, 404, 360, 386 |  | 382d |
| 410 |  | Assinatura de Termo de Entrega das Obras de Melhoria do Sistema de Abastecimento de Água - Barreto/MG | 0d | 2021-05-12 | 2021-05-12 | 407, 408, 409 |  | 382d |
| 411 | 4.2.1.7.2 | **Operação** | 250d | 2021-05-13 | 2022-05-13 |  |  | 380d |
| 412 |  | Realizar Treinamento Operacional do Sistema - Barreto/MG | 5d | 2021-05-13 | 2021-05-19 | 407, 408, 409, 410 |  | 382d |
| 413 |  | Realizar Testes e Pré-operação - Barreto/MG | 14d | 2021-05-13 | 2021-06-01 | 412SS |  | 382d |
| 414 |  | Realizar Acompanhamento da Funcionalidade do Sistema - Engenharia Captação Principal/Alternativa/ETA/Adução - Barreto (distrito Barra Longa/MG) | 365ed | 2021-05-13 | 2022-05-13 | 416SS |  | 1675.12d |
| 415 | 4.2.1.7.2.4 | **Operação Assistida** | 63d | 2021-05-13 | 2021-08-11 |  |  | 381d |
| 416 |  | Realizar Operação Assistida - Barreto/MG | 90ed | 2021-05-13 | 2021-08-11 | 407, 408, 409, 413SS |  | 1675.12d |
| 417 |  | Entrega das obras e conclusão do período de acompanhamento da operação - Barreto/MG | 0d | 2022-05-13 | 2022-05-13 | 414, 416 |  | 380d |
| 418 | 5 | **Território Calha do Rio Doce** | 967d | 2017-11-20 A | 2021-09-21 |  | 34% | 539d |
| 419 | 5.1 | **Ipaba do Paraíso (distrito Santana do Paraíso/MG)** | 967d | 2017-11-20 A | 2021-09-21 |  | 34% | 539d |
| 420 | 5.1.1 | **Sistemas de Abastecimento Individuais** | 967d | 2017-11-20 A | 2021-09-21 |  | 34% | 539d |

| ID | WBS | Task | Duration | Start | Finish | Predecessors | Complete | Total float |
| --- | --- | --- | --- | --- | --- | --- | --- | --- |
| 421 | 5.1.1.1 | **Estudos de Concepção do Sistema - Etapa 1** | 282d | 2018-03-23 A | 2019-04-30 A |  | 100% |  |
| 422 |  | Declaração de Escopo e Premissas de Projeto (DEPP) concluída - Ipaba do Paraíso/MG | 0d | 2018-03-23 A | 2018-03-23 A | 25, 26 | 100% |  |
| 423 |  | Obter anuências dos proprietários - Ipaba do Paraíso/MG | 282d | 2018-03-23 A | 2019-04-30 A | 25, 26, 422 | 100% |  |
| 424 | 5.1.1.2 | **Engenharia Básica e Detalhada** | 194d | 2018-11-05 A | 2019-08-13 A |  | 100% |  |
| 425 |  | Aprovar Plano de Trabalho e abrir OSE - Ipaba do Paraíso/MG | 15d | 2018-11-05 A | 2018-11-23 A | 422 | 100% |  |
| 426 |  | Realizar 1º Levantamento Campo - Ipaba do Paraíso/MG | 1d | 2018-12-05 A | 2018-12-05 A | 425, 443 | 100% |  |
| 427 |  | Realizar 2º Levantamento Campo - Ipaba do Paraíso/MG | 1d | 2019-02-01 A | 2019-02-01 A | 425, 443 | 100% |  |
| 428 |  | Elaborar arranjo para obtenção de Dados de Entrada Licenciamento e Fundiário - Ipaba do Paraíso/MG | 30d | 2019-05-22 A | 2019-07-03 A | 425FS+120d, 443FS+120d | 100% |  |
| 429 |  | Elaborar Projeto Executivo (11 casas) - Ipaba do Paraíso/MG | 162d | 2018-12-19 A | 2019-08-13 A | 438FF, 439FF, 426FS+9d, 427FF, 444FF | 100% |  |
| 430 |  | Elaboração do Projeto Executivo (11 casas) - Ipaba do Paraíso/MG | 0d | 2019-08-13 A | 2019-08-13 A | 428, 429 | 100% |  |
| 431 | 5.1.1.3 | **Licenciamento - Cisternas** | 21d | 2018-03-23 A | 2018-04-20 A |  | 100% |  |
| 432 |  | Obter Certidão de Uso Insignificante Individuais (Cisternas) - Ipaba do Paraíso/MG | 21d | 2018-03-23 A | 2018-04-20 A | 422 | 100% |  |
| 433 | 5.1.1.4 | **Estudos de Concepção do Sistema - Etapa 2** | 88d | 2019-11-19 | 2020-03-30 |  |  | 659d |
| 434 | 5.1.1.4.1 | **Serviços em Cisternas e Poços** | 88d | 2019-11-19 | 2020-03-30 |  |  | 659d |
| 435 |  | Realizar Estudo de Geofísica - Ipaba do Paraíso/MG | 44d | 2019-11-19 | 2020-01-23 | 451FS+118d |  | 659d |
| 436 |  | Realizar Limpeza e Desinfecção (13 cisternas/poços existentes) - Ipaba do Paraíso/MG | 22d | 2020-01-24 | 2020-02-27 | 423, 450, 437SS |  | 659d |
| 437 |  | Realizar Perfuração/Instrumentação - Ipaba do Paraíso/MG | 22d | 2020-01-24 | 2020-02-27 | 423, 450, 454, 435 |  | 659d |
| 438 |  | Elaborar Relatório Técnico dos poços perfurados- Ipaba do Paraíso/MG | 22d | 2020-02-28 | 2020-03-30 | 436, 437 |  | 659d |
| 439 |  | Realizar Coleta e Análise de Água - Ipaba do Paraíso/MG | 22d | 2020-02-28 | 2020-03-30 | 437 |  | 659d |
| 440 |  | Conclusão da Recuperação das Cisternas e Perfuração dos Poços - Ipaba do Paraíso/MG | 0d | 2020-03-30 | 2020-03-30 | 438, 439 |  | 659d |
| 441 |  | Conclusão dos Estudos de Concepção das Melhorias do Sistema de Abastecimento de Água - Ipaba do Paraíso/MG | 0d | 2020-03-30 | 2020-03-30 | 440 |  | 907d |
| 442 | 5.1.1.5 | **Engenharia Básica e Detalhada - Poços** | 431d | 2018-11-05 A | 2020-07-28 |  | 20% | 825d |
| 443 |  | Aprovar Plano de Trabalho e abrir OSE - Ipaba do Paraíso/MG | 15d | 2018-11-05 A | 2018-11-23 A | 422 | 100% |  |
| 444 |  | Realizar 3º Levantamento Campo - Ipaba do Paraíso/MG | 1d | 2019-06-28 A | 2019-06-28 A | 425FS+146d, 443FS+146d | 100% |  |
| 445 |  | Elaborar Projeto Executivo (5 casas - Pendente Perfuração) - Ipaba do Paraíso/MG | 66d | 2020-04-24 | 2020-07-28 | 439FS+16d |  | 825d |
| 446 |  | Elaboração do Projeto Executivo (5 casas - Pendente Perfuração) - Ipaba do Paraíso/MG | 0d | 2020-07-28 | 2020-07-28 | 445 |  | 825d |
| 447 |  | Conclusão e Validação da Engenharia - Ipaba do Paraíso/MG | 0d | 2020-07-28 | 2020-07-28 | 441, 446 |  | 825d |
| 448 | 5.1.1.6 | **Fundiária** | 443d | 2017-11-20 A | 2019-08-12 A |  | 100% |  |
| 449 |  | Obter Termos de Autorização de Superficiários (Possuidores dos Imóveis) - Ipaba do Paraíso/MG | 313d | 2017-11-20 A | 2019-01-31 A | 26 | 100% |  |
| 450 |  | Obter confirmação da Vale quanto a posse dos terrenos na área de servidão da empresa - Ipaba do Paraíso/MG | 59d | 2019-05-21 A | 2019-08-12 A | 423FS+13d, 449 | 100% |  |
| 451 |  | Realizar Cadastro dos Proprietários - Ipaba do Paraíso/MG | 102d | 2019-01-02 A | 2019-05-31 A | 26FS+291d | 100% |  |
| 452 |  | Conclusão da Regularização Fundiária para as obras de Melhoria do Sistema de Abastecimento da Localidade - Ipaba do Paraíso/MG | 0d | 2019-08-12 A | 2019-08-12 A | 450, 451, 447 | 100% |  |
| 453 | 5.1.1.7 | **Licenciamento - Poços** | 231d | 2019-10-15 A | 2020-09-18 |  | 6% | 788d |
| 454 |  | Obter Autorização para Perfuração (Poços) - Ipaba do Paraíso/MG | 51d | 2019-10-15 A | 2019-12-30 | 450FS+44d, 451FS+44d | 25% | 540d |
| 455 |  | Obter Outorga para Captação Subterrânea (Poços) - Ipaba do Paraíso/MG | 180d | 2019-12-31 | 2020-09-18 | 454 |  | 540d |
| 456 |  | Conclusão do Licenciamento Ambiental dos Sistemas Individuais - Ipaba do Paraíso/MG | 0d | 2020-09-18 | 2020-09-18 | 432, 455 |  | 788d |
| 457 | 5.1.1.8 | **Infraestrutura** | 435d | 2019-12-19 | 2021-09-21 |  |  | 539d |
| 458 | 5.1.1.8.1 | **Obras** | 186d | 2019-12-19 | 2020-09-18 |  |  | 636d |
| 459 |  | Executar obras dos Sistema Individuais de Abastecimento de Água - Etapa 1 - Ipaba do Paraíso/MG | 90d | 2019-12-19 | 2020-05-05 | 430FS+88d |  | 636d |
| 460 |  | Executar obras dos Sistema Individuais de Abastecimento de Água - Etapa 2 - Ipaba do Paraíso/MG | 70d | 2020-06-12 | 2020-09-18 | 450, 451, 432, 455FF, 440FF, 430FS+88d, 452 |  | 540d |
| 461 |  | Assinatura de Termo de Entrega das Obras de Melhoria do Sistema de Abastecimento de Água - Ipaba do Paraíso/MG | 0d | 2020-09-18 | 2020-09-18 | 459, 460, 456 |  | 788d |
| 462 | 5.1.1.8.2 | **Operação** | 249d | 2020-09-21 | 2021-09-21 |  |  | 539d |
| 463 |  | Realizar Treinamento Operacional do Sistema - Ipaba do Paraíso/MG | 5d | 2020-09-21 | 2020-09-25 | 459, 460 |  | 540d |
| 464 |  | Realizar Testes e Pré-operação - Ipaba do Paraíso/MG | 14d | 2020-09-28 | 2020-10-16 | 463 |  | 769d |
| 465 |  | Realizar Acompanhamento da Funcionalidade do Sistema - Sistemas de Abastecimento Individuais - Ipaba do Paraíso (distrito Santana do Paraíso/MG) | 365ed | 2020-09-21 | 2021-09-21 | 467SS |  | 2377.12d |
| 466 | 5.1.1.8.2.4 | **Operação Assistida** | 249d | 2020-09-21 | 2021-09-21 |  |  | 539d |
| 467 |  | Realizar Operação Assistida | 90ed | 2020-09-21 | 2020-12-20 | 463SS |  | 2377.12d |
| 468 |  | Entrega das obras e conclusão do período de acompanhamento da operação - Barreto/MG | 0d | 2021-09-21 | 2021-09-21 | 467, 465 |  | 539d |
| 469 | 6 | **Território Médio Rio Doce** | 1939d | 2016-03-23 A | 2023-11-22 |  | 26% | 0d |
| 470 | 6.1 | **Cachoeira Escura (distrito Belo Oriente/MG)** | 1249d | 2018-01-16 A | 2023-01-07 |  | 33% | 216d |
| 471 | 6.1.1 | **Captação Principal e Melhorias na ETA** | 1079d | 2018-03-14 A | 2022-07-01 |  | 25% | 345d |
| 472 | 6.1.1.1 | **Estudos de Concepção do Sistema - Etapa 1** | 7d | 2018-03-14 A | 2018-03-23 A |  | 100% |  |
| 473 |  | Declaração de Escopo e Premissas de Projeto (DEPP) concluída - Cachoeira Escura/MG | 0d | 2018-03-23 A | 2018-03-23 A | 25, 26 | 100% |  |
| 474 |  | Aprovação das DEPPs pela Operadora e Prefeitura - Cachoeira Escura/MG | 0d | 2018-03-14 A | 2018-03-14 A | 25, 26 | 100% |  |
| 475 | 6.1.1.2 | **Engenharia Básica e Detalhada** | 395d | 2018-09-20 A | 2020-04-20 |  | 79% | 570d |
| 476 | 6.1.1.2.1 | **Engenharia Captação Principal (Melhorias) - SE 32159** | 395d | 2018-09-20 A | 2020-04-20 |  | 65% | 570d |
| 477 |  | Aprovar Plano de Trabalho e abrir OSE - Captação Principal - Rio Doce - Cachoeira Escura/MG | 35d | 2018-11-22 A | 2019-01-10 A | 473 | 100% |  |
| 478 |  | Realizar Levantamento de Campo - Captação Principal - Rio Doce - Cachoeira Escura/MG | 3d | 2019-02-12 A | 2019-02-14 A | 477 | 100% |  |
| 479 |  | Executar Topografia - Captação Principal - Rio Doce - Cachoeira Escura/MG | 62d | 2018-09-20 A | 2018-12-14 A | 477 | 100% |  |
| 480 |  | Executar Atividades Preliminares - Projeto Básico - Captação Principal - Rio Doce - Cachoeira Escura/MG | 57d | 2019-07-08 A | 2019-09-25 A | 479 | 100% |  |
| 481 |  | Elaborar Projeto Básico - Captação Principal - Rio Doce - Cachoeira Escura/MG | 50d | 2019-10-07 A | 2019-12-17 | 478, 479, 480 | 55% | 347d |
| 482 |  | Aprovar Projeto Básico - Captação Principal - Rio Doce - Cachoeira Escura/MG | 22d | 2019-12-18 | 2020-01-21 | 481 |  | 347d |
| 483 |  | Emitir RT/PQ para Suprimentos - Captação Principal - Rio Doce - Cachoeira Escura/MG | 10d | 2019-10-16 A | 2019-10-29 A | 482SS+7d | 100% |  |
| 484 |  | Elaborar Projeto Executivo - Captação Principal - Rio Doce - Cachoeira Escura/MG | 60d | 2020-01-22 | 2020-04-20 | 482 |  | 495d |
| 485 |  | Elaboração do Projeto Executivo - Captação Principal - Rio Doce - Cachoeira Escura/MG | 0d | 2020-04-20 | 2020-04-20 | 483, 484 |  | 570d |
| 486 | 6.1.1.2.2 | **Engenharia Melhorias ETA - Etapa 1** | 261d | 2018-10-16 A | 2019-10-28 A |  | 100% |  |
| 487 |  | Aprovar Plano de Trabalho e abrir OSE - Melhorias na ETA - Cachoeira Escura/MG | 30d | 2018-12-10 A | 2019-01-21 A |  | 100% |  |
| 488 |  | Realizar Levantamento de Campo - Melhorias na ETA - Cachoeira Escura/MG | 2d | 2019-02-13 A | 2019-02-14 A | 487 | 100% |  |
| 489 |  | Executar Topografia - Melhorias na ETA - Cachoeira Escura/MG | 30d | 2018-12-19 A | 2019-01-30 A | 487FS-30d | 100% |  |
| 490 |  | Emitir RT/PQ para Suprimentos - Melhorias na ETA - Cachoeira Escura/MG | 10d | 2019-10-15 A | 2019-10-28 A | 493FF | 100% |  |

| ID | WBS | Task | Duration | Start | Finish | Predecessors | Complete | Total float |
| --- | --- | --- | --- | --- | --- | --- | --- | --- |
| 491 |  | Elaborar Projeto Executivo (Pequenas Melhorias) SE 32219 - Melhorias na ETA - Cachoeira Escura/MG | 26d | 2018-10-16 A | 2018-11-20 A |  | 100% |  |
| 492 | 6.1.1.2.3 | **Engenharia Melhorias ETA - Etapa 2** | 156d | 2019-04-01 A | 2019-11-11 |  | 91% | 676d |
| 493 |  | Elaborar Projeto Executivo (Redimensionamento das Bombas e relocação do painel) SE 32158 - Melhorias na ETA - Cachoeira Escura/MG | 156d | 2019-04-01 A | 2019-11-11 | 488, 489 | 91% | 676d |
| 494 |  | Elaboração do Projeto Executivo - Melhorias na ETA - Cachoeira Escura/MG | 0d | 2019-11-11 | 2019-11-11 | 491, 493 |  | 676d |
| 495 | 6.1.1.3 | **Fundiária** | 197d | 2018-10-18 A | 2019-07-31 A |  | 100% |  |
| 496 |  | Captação Principal - Anuência Prefeitura para execução da obra no local - Cachoeira Escura/MG | 197d | 2018-10-18 A | 2019-07-31 A | 473FS+209ed | 100% |  |
| 497 |  | Conclusão da Regularização Fundiária para as obras de Melhoria do Sistema de Abastecimento da Localidade - Cachoeira Escura/MG | 0d | 2019-07-31 A | 2019-07-31 A | 496 | 100% |  |
| 498 | 6.1.1.4 | **Licenciamento** | 208d | 2020-01-22 | 2020-11-20 |  |  | 347d |
| 499 |  | Obter Outorga para Adequação da Captação no Rio Doce - Captação Principal - Cachoeira Escura/MG | 208d | 2020-01-22 | 2020-11-20 | 482, 496 |  | 347d |
| 500 | 6.1.1.4.2 | **DAIA para Captação Principal** | 190d | 2020-01-22 | 2020-10-26 |  |  | 355d |
| 501 |  | Protocolar FCE e documentos do FOB - Cachoeira Escura/MG | 10d | 2020-01-22 | 2020-02-04 | 482 |  | 355d |
| 502 |  | Acompanhar Processo Junto ao Órgão - Pedido de Informação Complementar - Cachoeira Escura/MG | 180d | 2020-02-05 | 2020-10-26 | 501 |  | 355d |
| 503 |  | Obtenção da DAIA para Captação Principal - Captação rio Doce - Cachoeira Escura/MG | 0d | 2020-10-26 | 2020-10-26 | 502 |  | 355d |
| 504 |  | Conclusão do Licenciamento Ambiental da Localidade - Cahoeira Escura/MG | 0d | 2020-11-20 | 2020-11-20 | 499, 503 |  | 745d |
| 505 | 6.1.1.5 | **Infraestrutura** | 808d | 2019-04-03 A | 2022-07-01 |  | 5% | 345d |
| 506 | 6.1.1.5.1 | **Obras - Etapa 1** | 83d | 2019-04-03 A | 2019-08-01 A |  | 100% |  |
| 507 |  | Executar pequenas Melhorias na ETA (Urbanização)- Cachoeira Escura/MG | 83d | 2019-04-03 A | 2019-08-01 A | 491FS+91d | 100% |  |
| 508 | 6.1.1.5.2 | **Obras - Etapa 2** | 298d | 2020-04-20 | 2021-07-01 |  |  | 495d |
| 509 |  | Contrato Guarda-Chuva(Captações e Melhorias ETA) - Cachoeira Escura/MG | 0d | 2020-04-20 | 2020-04-20 | 483, 485, 490, 491, 493, 494 |  | 570d |
| 510 |  | Executar Captação Principal (Melhorias - rio Doce) - Cachoeira Escura/MG | 150d | 2020-11-23 | 2021-07-01 | 484, 496, 499, 503FS+10d, 497 |  | 347d |
| 511 |  | Executar obras de Melhorias de ETA (Elevatórias) - Cachoeira Escura/MG | 75d | 2020-04-22 | 2020-08-06 | 493, 509 |  | 570d |
| 512 |  | Assinatura de Termo de Entrega das Obras de Melhoria do Sistema de Abastecimento de Água - Cachoeira Escura/MG | 0d | 2021-07-01 | 2021-07-01 | 507, 510, 511 |  | 595d |
| 513 | 6.1.1.5.3 | **Operação** | 250d | 2021-07-01 | 2022-07-01 |  |  | 345d |
| 514 |  | Realizar Treinamento Operacional do Sistema - Cachoeira Escura/MG | 5d | 2021-07-02 | 2021-07-08 | 510, 511 |  | 576d |
| 515 |  | Realizar Testes e Pré-operação - Cachoeira Escura/MG | 14d | 2021-07-09 | 2021-07-28 | 514 |  | 576d |
| 516 |  | Realizar Acompanhamento da Funcionalidade do Sistema - Captação Principal e Melhorias na ETA - Cachoeira Escura (distrito Belo Oriente/MG) | 365ed | 2021-07-01 | 2022-07-01 | 518SS |  | 1527d |
| 517 | 6.1.1.5.3.4 | **Operação Assistida** | 63d | 2021-07-01 | 2021-09-29 |  |  | 346d |
| 518 |  | Realizar Operação Assistida - Cachoeira Escura/MG | 90ed | 2021-07-01 | 2021-09-29 | 510, 511 |  | 1527d |
| 519 | 6.1.2 | **Captação Alternativa** | 1161d | 2018-01-16 A | 2022-08-30 |  | 54% | 304d |
| 520 | 6.1.2.1 | **Estudos de Concepção do Sistema - Etapa 1** | 287d | 2018-03-14 A | 2019-04-26 A |  | 100% |  |
| 521 |  | Declaração de Escopo e Premissas de Projeto (DEPP) concluída - Cachoeira Escura/MG | 0d | 2018-03-23 A | 2018-03-23 A | 25, 26 | 100% |  |
| 522 |  | Aprovação das DEPPs pela Operadora e Prefeitura - Cachoeira Escura/MG | 0d | 2018-03-14 A | 2018-03-14 A | 25, 26 | 100% |  |
| 523 |  | Revisar Definições - Cachoeira Escura/MG | 273d | 2018-03-23 A | 2019-04-22 A | 521 | 100% |  |
| 524 | 6.1.2.1.4 | **Serviços em Poços Tubulares (Poço Interligado a ETA)** | 247d | 2018-05-09 A | 2019-04-26 A |  | 100% |  |
| 525 |  | Realizar Perfilagem 1 (do poço interligado a ETA) - Cachoeira Escura/MG | 2d | 2018-05-09 A | 2018-05-10 A | 521FS+33d | 100% |  |
| 526 |  | Realizar Recuperação do poço interligado a ETA - Cachoeira Escura/MG | 7d | 2018-09-04 A | 2018-09-12 A | 525 | 100% |  |
| 527 |  | Realizar Perfilagem 2 (do poço interligado a ETA) - Cachoeira Escura/MG | 2d | 2018-08-23 A | 2018-08-24 A | 526 | 100% |  |
| 528 |  | Elaborar Relatório Técnico - Cachoeira Escura/MG | 6d | 2018-11-13 A | 2018-11-20 A | 525, 526FS+44d, 527 | 100% |  |
| 529 |  | Realizar Laudo de Serviços de Coleta e Análise de Água - Poço interligado a ETA - 1ª Campanha de amostragem - Cachoeira Escura/MG | 22d | 2018-11-07 A | 2018-12-06 A | 527FS+52d | 100% |  |
| 530 |  | Realizar Laudo de Serviços de Coleta e Análise de Água - Poço interligado a ETA - Nova campanha de amostragem - Cachoeira Escura/MG | 19d | 2019-03-29 A | 2019-04-26 A | 523FS-15d, 528 | 100% |  |
| 531 |  | Conclusão dos Serviços em Poços - Poço interligado a ETA - Cachoeira Escura/MG | 0d | 2019-04-26 A | 2019-04-26 A | 530 | 100% |  |
| 532 | 6.1.2.2 | **Estudos de Concepção do Sistema - Etapa 2** | 33d | 2019-05-02 A | 2019-06-17 A |  | 100% |  |
| 533 | 6.1.2.2.1 | **Serviços em Poços Tubulares (3 poços tubulares: 2 COPASA + 1 CENIBRA)** | 33d | 2019-05-02 A | 2019-06-17 A |  | 100% |  |
| 534 |  | Realizar Perfilagem - 3 Poços - Cachoeira Escura/MG | 8d | 2019-05-02 A | 2019-05-13 A | 523FS+6d | 100% |  |
| 535 |  | Realizar Recuperação - 3 Poços - Cachoeira Escura/MG | 7d | 2019-05-03 A | 2019-05-13 A | 534FS-7d | 100% |  |
| 536 |  | Realizar Teste de bombeamento - 3 Poços - Cachoeira Escura/MG | 3d | 2019-05-09 A | 2019-05-13 A | 535FS-3d | 100% |  |
| 537 |  | Realizar Teste de interferência (Poços COPASA) - 3 Poços - Cachoeira Escura/MG | 1d | 2019-05-13 A | 2019-05-13 A | 536FS-1d | 100% |  |
| 538 |  | Elaborar Relatóro Técnico - 3 Poços - Cachoeira Escura/MG | 25d | 2019-05-14 A | 2019-06-17 A | 537 | 100% |  |
| 539 |  | Conclusão dos Serviços em Poços - 3 Poços - Cachoeira Escura/MG | 0d | 2019-06-17 A | 2019-06-17 A | 538 | 100% |  |
| 540 |  | Conclusão dos Estudos de Concepção das Melhorias do Sistema de Abastecimento de Água - Cachoeira Escura/MG | 0d | 2019-06-17 A | 2019-06-17 A | 531, 539 | 100% |  |
| 541 | 6.1.2.3 | **Engenharia Básica e Detalhada** | 472d | 2018-07-31 A | 2020-06-18 |  | 48% | 425d |
| 542 | 6.1.2.3.1 | **Engenharia Captação Alternativa (3 novos poços) - SE 32316** | 472d | 2018-07-31 A | 2020-06-18 |  | 48% | 425d |
| 543 |  | Elaboração do Projeto Executivo - Adequação do Poço Interligado a ETA- Cachoeira Escura/MG | 0d | 2018-07-31 A | 2018-07-31 A | 521 | 100% |  |
| 544 |  | Aprovar Plano de Trabalho e abrir OSE - Captação Alternativa - 3 novos poços - Cachoeira Escura/MG | 53d | 2019-04-16 A | 2019-07-03 A | 523 | 100% |  |
| 545 |  | Executar Topografia - Captação Alternativa - 3 novos poços - Cachoeira Escura/MG | 40d | 2019-01-07 A | 2019-03-01 A | 544 | 100% |  |
| 546 |  | Elaborar Arranjo para obtenção de Dados de Entrada Licenciamento e Fundiário - Captação Alternativa - 3 novos poços - Cachoeira Escura/MG | 58d | 2019-07-01 A | 2019-09-19 A | 539, 540FS+8d, 545 | 100% |  |
| 547 |  | Elaborar Projeto Básico - Captação Alternativa - 3 novos poços - Cachoeira Escura/MG | 74d | 2019-11-01 | 2020-02-19 | 546FS+30d |  | 305d |
| 548 |  | Aprovar Projeto Básico - Captação Alternativa - 3 novos poços - Cachoeira Escura/MG | 22d | 2020-02-20 | 2020-03-25 | 547 |  | 305d |
| 549 |  | Emitir RT/PQ para Suprimentos - Captação Alternativa - 3 novos poços - Cachoeira Escura/MG | 12d | 2020-06-02 | 2020-06-18 | 548, 550FF |  | 425d |
| 550 |  | Elaborar Projeto Executivo - Captação Alternativa - 3 novos poços - Cachoeira Escura/MG | 57d | 2020-03-26 | 2020-06-18 | 548 |  | 425d |
| 551 |  | Elaboração do Projeto Executivo - Captação Alternativa - 3 novos poços - Cachoeira Escura/MG | 0d | 2020-06-18 | 2020-06-18 | 548, 549, 550 |  | 425d |
| 552 | 6.1.2.4 | **Fundiária** | 684d | 2018-03-23 A | 2020-12-08 |  | 50% | 305d |
| 553 |  | Obter Termo de Autorização para estudos (Poços COPASA) - Captação Alternativa - Cachoeira Escura/MG | 177d | 2018-03-23 A | 2018-11-26 A | 521 | 100% |  |
| 554 |  | Captação Alternativa - Desimpedimento de área adutora (Poços Copasa) - Cachoeira Escura/MG | 177d | 2020-03-26 | 2020-12-08 | 546, 548 |  | 305d |
| 555 |  | Conclusão da Regularização Fundiária para as obras de Melhoria do Sistema de Abastecimento da Localidade - Cachoeira Escura/MG | 0d | 2020-12-08 | 2020-12-08 | 553, 554 |  | 305d |
| 556 | 6.1.2.5 | **Licenciamento** | 466d | 2018-01-16 A | 2019-11-11 |  | 99% | 571d |
| 557 |  | Obter Outorga para Captação Alternativa (Poço dentro da ETA e UTR) - Cachoeira Escura/MG | 367ed | 2018-01-16 A | 2019-01-18 A | 553FS-225d | 100% |  |
| 558 | 6.1.2.5.2 | **DAIA para Captação Alternativa (Poço dentro da ETA e UTR)** | 466d | 2018-01-16 A | 2019-11-11 |  | 98% | 571d |
| 559 |  | Protocolar FCE e documentos do FOB - Cachoeira Escura/MG | 1d | 2018-01-16 A | 2018-01-16 A |  | 100% |  |
| 560 |  | Acompanhar Processo Junto ao Órgão - Pedido de Informação Complementar - Cachoeira Escura/MG | 283d | 2018-01-17 A | 2019-02-18 A | 559 | 100% |  |

| ID | WBS | Task | Duration | Start | Finish | Predecessors | Complete | Total float |
| --- | --- | --- | --- | --- | --- | --- | --- | --- |
| 561 |  | Definir proposta de compensação ambiental com Prefeitura de GV - Cachoeira Escura/MG | 44d | 2019-02-19 A | 2019-04-26 A | 560 | 100% |  |
| 562 |  | Protocolar proposta de compensação ambiental - Cachoeira Escura/MG | 10d | 2019-05-02 A | 2019-05-15 A | 561FS+2d | 100% |  |
| 563 |  | Acompanhar Processo Junto ao Órgão - Cachoeira Escura/MG | 126d | 2019-05-16 A | 2019-11-11 | 562 | 94% | 571d |
| 564 |  | Obtenção da DAIA para captação - (Poço dentro da ETA e UTR) - Cachoeira Escura/MG | 0d | 2019-11-11 | 2019-11-11 | 563 |  | 571d |
| 565 |  | Conclusão do Licenciamento Ambiental da Localidade - Cahoeira Escura/MG | 0d | 2019-11-11 | 2019-11-11 | 557, 563, 564 |  | 571d |
| 566 | 6.1.2.6 | **Infraestrutura** | 549d | 2020-06-18 | 2022-08-30 |  |  | 304d |
| 567 | 6.1.2.6.1 | **Obras** | 300d | 2020-06-18 | 2021-08-30 |  |  | 425d |
| 568 |  | Contrato Guarda-Chuva(Captações e Melhorias ETA) - Cachoeira Escura/MG | 0d | 2020-06-18 | 2020-06-18 | 549, 551 |  | 425d |
| 569 |  | Executar obras de Captação Alternativa (3 poços + 3km de adutora) - Cachoeira Escura/MG | 180d | 2020-12-09 | 2021-08-30 | 543, 550, 554, 557, 563, 564, 568, 555, 565 |  | 305d |
| 570 |  | Assinatura de Termo de Entrega das Obras de Melhoria do Sistema de Abastecimento de Água - Cachoeira Escura/MG | 0d | 2021-08-30 | 2021-08-30 | 569 |  | 553d |
| 571 | 6.1.2.6.2 | **Operação** | 249d | 2021-08-30 | 2022-08-30 |  |  | 304d |
| 572 |  | Realizar Treinamento Operacional do Sistema - Cachoeira Escura/MG | 5d | 2021-08-31 | 2021-09-06 | 569 |  | 534d |
| 573 |  | Realizar Testes e Pré-operação - Cachoeira Escura/MG | 14d | 2021-09-08 | 2021-09-27 | 572 |  | 534d |
| 574 |  | Realizar Acompanhamento da Funcionalidade do Sistema - Captação Alternativa - Cachoeira Escura (distrito Belo Oriente/MG) | 365ed | 2021-08-30 | 2022-08-30 | 576SS |  | 1347d |
| 575 | 6.1.2.6.2.4 | **Operação Assistida** | 60d | 2021-08-30 | 2021-11-28 |  |  | 305d |
| 576 |  | Realizar Operação Assistida - Cachoeira Escura/MG | 90ed | 2021-08-30 | 2021-11-28 | 569 |  | 1347d |
| 577 | 6.1.3 | **UTR** | 789d | 2019-11-04 | 2023-01-07 |  |  | 216d |
| 578 | 6.1.3.1 | **Engenharia** | 331d | 2019-11-04 | 2021-03-09 |  |  | 216d |
| 579 | 6.1.3.1.1 | **Engenharia Básica e Detalhada** | 331d | 2019-11-04 | 2021-03-09 |  |  | 216d |
| 580 | 6.1.3.1.1.1 | **Engenharia UTR - 40L/s** | 331d | 2019-11-04 | 2021-03-09 |  |  | 216d |
| 581 |  | Aprovar Plano de Trabalho e abrir OSE - UTR - Cachoeira Escura/MG | 15d | 2019-11-04 | 2019-11-25 | 523FS+136d |  | 216d |
| 582 |  | Elaborar arranjo para obtenção de Dados de Entrada Licenciamento e Fundiário - UTR - Cachoeira Escura/MG | 105d | 2019-11-26 | 2020-05-04 | 581 |  | 216d |
| 583 |  | Elaborar Projeto Básico - UTR - Cachoeira Escura/MG | 123d | 2020-05-05 | 2020-10-27 | 582 |  | 216d |
| 584 |  | Aprovar Projeto Básico - UTR - Cachoeira Escura/MG | 22d | 2020-10-28 | 2020-11-27 | 583 |  | 226d |
| 585 |  | Emitir RT/PQ para Suprimentos - UTR - Cachoeira Escura/MG | 10d | 2020-10-28 | 2020-11-11 | 583 |  | 216d |
| 586 |  | Elaborar Projeto Executivo - UTR - Cachoeira Escura/MG | 66d | 2020-11-30 | 2021-03-09 | 583, 584 |  | 226d |
| 587 |  | Elaboração do Projeto Executivo - UTR - Cachoeira Escura/MG | 0d | 2021-03-09 | 2021-03-09 | 583, 586 |  | 226d |
| 588 | 6.1.3.2 | **Suprimentos** | 88d | 2020-11-12 | 2021-03-23 |  |  | 216d |
| 589 |  | Contratação UTR - Cachoeira Escura/MG | 88d | 2020-11-12 | 2021-03-23 | 585 |  | 216d |
| 590 |  | Conclusão da Contratação de Suprimentos das obras de Melhoria do Sistema de Abastecimento de Água - Cachoeira Escura/MG | 0d | 2021-03-23 | 2021-03-23 | 589 |  | 216d |
| 591 | 6.1.3.3 | **Infraestrutura** | 448d | 2021-03-24 | 2023-01-07 |  |  | 216d |
| 592 | 6.1.3.3.1 | **Obras** | 200d | 2021-03-24 | 2022-01-07 |  |  | 216d |
| 593 |  | Executar UTR - Cachoeira Escura/MG | 200d | 2021-03-24 | 2022-01-07 | 586, 587, 590 |  | 216d |
| 594 |  | Assinatura de Termo de Entrega das Obras de Melhoria do Sistema de Abastecimento de Água - Cachoeira Escura/MG | 0d | 2022-01-07 | 2022-01-07 | 593 |  | 464d |
| 595 | 6.1.3.3.2 | **Operação** | 248d | 2022-01-07 | 2023-01-07 |  |  | 216d |
| 596 |  | Realizar Treinamento Operacional do Sistema - Cachoeira Escura/MG | 5d | 2022-01-10 | 2022-01-14 | 593 |  | 445d |
| 597 |  | Realizar Testes e Pré-operação - Cachoeira Escura/MG | 14d | 2022-01-17 | 2022-02-03 | 596 |  | 445d |
| 598 |  | Realizar Acompanhamento da Funcionalidade do Sistema - UTR - Cachoeira Escura (distrito Belo Oriente/MG) | 365ed | 2022-01-07 | 2023-01-07 | 600SS |  | 957d |
| 599 | 6.1.3.3.2.4 | **Operação Assistida** | 61d | 2022-01-07 | 2022-04-07 |  |  | 216d |
| 600 |  | Realizar Operação Assistida - Cachoeira Escura/MG | 90ed | 2022-01-07 | 2022-04-07 | 593 |  | 957d |
| 601 | 6.2 | **Senhora da Penha (distrito Fernandes Tourinho/MG)** | 1203d | 2017-10-25 A | 2022-08-05 |  | 19% | 320d |
| 602 | 6.2.1 | **Engenharia Captação Alternativa - Poço 3** | 1159d | 2017-10-25 A | 2022-06-04 |  | 29% | 364d |
| 603 | 6.2.1.1 | **Estudos de Concepção do Sistema - Etapa 1** | 335d | 2017-10-25 A | 2019-02-07 A |  | 100% |  |
| 604 |  | Declaração de Escopo e Premissas de Projeto (DEPP) concluída - Senhora da Penha/MG | 0d | 2018-03-23 A | 2018-03-23 A | 25, 26 | 100% |  |
| 605 |  | Aprovação das DEPPs pela Operadora e Prefeitura - Senhora da Penha/MG | 0d | 2017-10-25 A | 2017-10-25 A | 25SS+20d, 26SS+213d | 100% |  |
| 606 |  | Revisar Revisão de Definições - Senhora da Penha/MG | 81d | 2018-10-17 A | 2019-02-07 A | 615 | 100% |  |
| 607 |  | Aprovação da Revisão de Definição pela Prefeitura - Senhora da Penha/MG | 0d | 2019-02-07 A | 2019-02-07 A | 606 | 100% |  |
| 608 | 6.2.1.1.5 | **Estudos de Geofísica para Poço Tubular - Poço 2** | 150d | 2018-05-08 A | 2018-12-03 A |  | 100% |  |
| 609 |  | Executar Levantamento de Campo - Poço 2 - Senhora da Penha/MG | 3d | 2018-05-08 A | 2018-05-10 A | 604 | 100% |  |
| 610 |  | Emitir Relatório - Poço 2 - Senhora da Penha/MG | 7d | 2018-05-11 A | 2018-05-21 A | 609 | 100% |  |
| 611 |  | Conclusão dos Estudos de Geofísica para Poço Tubular - Poço 2 - Senhora da Penha/MG | 0d | 2018-05-21 A | 2018-05-21 A | 610 | 100% |  |
| 612 | 6.2.1.1.5.4 | **Serviços em Poços Tubulares (Poço 2 - Tamponado)** | 58d | 2018-09-13 A | 2018-12-03 A |  | 100% |  |
| 613 |  | Realizar Perfuração - Poço 2 - Senhora da Penha/MG | 3d | 2018-09-13 A | 2018-09-17 A | 610, 611 | 100% |  |
| 614 |  | Realizar Teste de Bombeamento - Poço 2 - Senhora da Penha/MG | 2d | 2018-09-17 A | 2018-09-18 A | 613 | 100% |  |
| 615 |  | Realizar Laudo dos Serviços de Coleta e Análise de Água - Poço 2 - Senhora da Penha/MG | 20d | 2018-09-19 A | 2018-10-16 A | 614 | 100% |  |
| 616 |  | Realizar Tamponamento - Poço 2 - Senhora da Penha/MG | 6d | 2018-11-24 A | 2018-12-03 A | 615 | 100% |  |
| 617 |  | Conclusão dos Serviços em poço tubular - Poço 2 - Senhora da Penha/MG | 0d | 2018-12-03 A | 2018-12-03 A | 616 | 100% |  |
| 618 | 6.2.1.2 | **Estudos de Concepção do Sistema - Etapa 2** | 264d | 2019-04-08 A | 2020-04-30 |  | 45% | 508d |
| 619 | 6.2.1.2.1 | **Estudos de Geofísica para Poço Tubular - Poço 3** | 16d | 2019-07-09 A | 2019-07-30 A |  | 100% |  |
| 620 |  | Executar Levantamento de Campo - Poço 3 - Senhora da Penha/MG | 4d | 2019-07-09 A | 2019-07-12 A | 654FS+6d | 100% |  |
| 621 |  | Emitir Relatório - Poço 3 - Senhora da Penha/MG | 12d | 2019-07-15 A | 2019-07-30 A | 620 | 100% |  |
| 622 |  | Conclusão dos Estudos de Geofísica para Poço Tubular - Poço 3 - Senhora da Penha/MG | 0d | 2019-07-30 A | 2019-07-30 A | 621 | 100% |  |
| 623 | 6.2.1.2.2 | **Serviços em Poços Tubulares (Poço 1 Existente) - Vazão Insuficiente** | 38d | 2019-04-08 A | 2019-06-03 A |  | 100% |  |
| 624 |  | Realizar Perfilagem (Poço 1 existente) - Captação Alternativa) - Vazão Insuficiente - Senhora da Penha/MG | 5d | 2019-04-08 A | 2019-04-12 A | 607FS+15d | 100% |  |
| 625 |  | Realizar Recuperação (Poço 1 existente) - Captação Alternativa) - Vazão Insuficiente - Senhora da Penha/MG | 5d | 2019-04-08 A | 2019-04-12 A | 624SS | 100% |  |
| 626 |  | Elaborar Relatório Técnico (Poço 1 existente) - Captação Alternativa) - Vazão Insuficiente - Senhora da Penha/MG | 23d | 2019-05-02 A | 2019-06-03 A | 624FS+10d, 625 | 100% |  |
| 627 |  | Realizar Laudo dos Serviços de Coleta e Análise de Água (Poço 1 existente) - Captação Alternativa) - Vazão Insuficiente - Senhora da Penha/MG | 5d | 2019-04-15 A | 2019-04-23 A | 625SS | 100% |  |
| 628 |  | Conclusão dos Serviços em poço tubular - Captação Alternativa) - Vazão Insuficiente - Senhora da Penha/MG | 0d | 2019-06-03 A | 2019-06-03 A | 626 | 100% |  |
| 629 | 6.2.1.2.3 | **Serviços em Poços Tubulares (Poço 3 - Captação Alternativa)** | 42d | 2020-03-02 | 2020-04-30 |  |  | 366d |
| 630 |  | Realizar Perfuração - Captação Alternativa - Poço 3 - Senhora da Penha/MG | 10d | 2020-03-02 | 2020-03-13 | 622, 658, 655 |  | 366d |

| ID | WBS | Task | Duration | Start | Finish | Predecessors | Complete | Total float |
| --- | --- | --- | --- | --- | --- | --- | --- | --- |
| 631 |  | Realizar Teste de bombeamento - Captação Alternativa - Poço 3 - Senhora da Penha/MG | 5d | 2020-03-16 | 2020-03-20 | 630 |  | 366d |
| 632 |  | Realizar Serviços de Coleta e Análise de Água - Captação Alternativa - Poço 3 - Senhora da Penha/MG | 24d | 2020-03-23 | 2020-04-27 | 631 |  | 366d |
| 633 |  | Elaborar Relatório Técnico - Captação Alternativa - Poço 3 - Senhora da Penha/MG | 24d | 2020-03-23 | 2020-04-27 | 631 |  | 508d |
| 634 |  | Realizar Instrumentação - Captação Alternativa - Poço 3 - Senhora da Penha/MG | 3d | 2020-04-28 | 2020-04-30 | 633 |  | 508d |
| 635 |  | Conclusão dos Serviços em poço tubular - Captação Alternativa - Poço 3 - Senhora da Penha/MG | 0d | 2020-04-30 | 2020-04-30 | 632, 634 |  | 508d |
| 636 |  | Conclusão dos Estudos de Concepção das Melhorias do Sistema de Abastecimento de Água - Senhora da Penha/MG | 0d | 2020-04-30 | 2020-04-30 | 611, 617, 628, 635 |  | 508d |
| 637 | 6.2.1.3 | **Engenharia Básica e Detalhada (Conceito Antigo) - Poço 1** | 422d | 2018-01-17 A | 2019-09-11 A |  | 100% |  |
| 638 |  | Aprovar Plano de Trabalho e abrir OSE - Captação Alternativa - Senhora da Penha/MG | 233d | 2018-01-17 A | 2018-12-07 A | 26 | 100% |  |
| 639 |  | Realizar Levantamento de Campo - Captação Alternativa - Avaliação Poços - Senhora da Penha/MG | 15d | 2018-06-20 A | 2018-07-10 A | 638 | 100% |  |
| 640 |  | Elaborar Projeto As Built do Poço - Captação Alternativa - Senhora da Penha/MG | 225d | 2018-07-11 A | 2019-05-30 A | 639 | 100% |  |
| 641 |  | Elaborar Projeto Executivo - Poço 1 - STA - Senhora da Penha/MG | 65d | 2019-04-15 A | 2019-09-11 A | 627FS-50d, 628FS-50d, 639FS-50d, 640FS-50d | 100% |  |
| 642 |  | Elaboração do Projeto Executivo - Poço 1 e STA (Não será Utilizado) - Senhora da Penha/MG | 0d | 2019-09-11 A | 2019-09-11 A | 641 | 100% |  |
| 643 | 6.2.1.4 | **Engenharia Básica e Detalhada Captação Alternativa - Poço 3** | 145d | 2020-04-28 | 2020-11-23 |  |  | 366d |
| 644 |  | Aprovar Plano de Trabalho e abrir OSE - Captação Alternativa - Senhora da Penha/MG | 5d | 2020-04-28 | 2020-05-05 | 631, 632 |  | 366d |
| 645 |  | Realizar Levantamento de Campo - Captação Alternativa - Avaliação Poços - Senhora da Penha/MG | 6d | 2020-05-06 | 2020-05-13 | 644 |  | 421d |
| 646 |  | Realizar Sondagem - Captação Alternativa - Senhora da Penha/MG | 22d | 2020-07-08 | 2020-08-06 | 648FF |  | 388d |
| 647 |  | Executar Topografia - Captação Alternativa - Senhora da Penha/MG | 5d | 2020-05-14 | 2020-05-20 | 645 |  | 421d |
| 648 |  | Elaborar Projeto Básico - Captação Alternativa Poço 3 - Senhora da Penha/MG | 71d | 2020-04-28 | 2020-08-06 | 644SS, 647FF |  | 366d |
| 649 |  | Aprovar Projeto Básico - Captação Alternativa Poço 3 - Senhora da Penha/MG | 22d | 2020-08-07 | 2020-09-08 | 648 |  | 366d |
| 650 |  | Emitir RT/PQ para Suprimentos - Captação Alternativa - Senhora da Penha/MG | 10d | 2020-11-10 | 2020-11-23 | 648, 651FF |  | 366d |
| 651 |  | Elaborar Projeto Executivo - Captação Alternativa - Poço 3 - Senhora da Penha/MG | 52d | 2020-09-09 | 2020-11-23 | 646, 648, 649 |  | 366d |
| 652 |  | Elaboração do Projeto Executivo - Captação Alternativa - Senhora da Penha/MG | 0d | 2020-11-23 | 2020-11-23 | 651, 650, 636 |  | 366d |
| 653 | 6.2.1.5 | **Fundiária** | 136d | 2019-06-10 A | 2019-12-20 |  | 41% | 366d |
| 654 |  | Obter Termo de Autorização do Superficiário (Poço 3) - Geofísica - Captação Alternativa - Senhora da Penha/MG | 14d | 2019-06-10 A | 2019-06-28 A | 607FS+80d | 100% |  |
| 655 |  | Obter Termo de Autorização do Superficiário (Poço 3) - Perfuração - Captação Alternativa - Senhora da Penha/MG | 52d | 2019-10-08 A | 2019-12-20 | 654FS+70d | 25% | 366d |
| 656 |  | Conclusão da Regularização Fundiária para as obras de Melhoria do Sistema de Abastecimento da Localidade - Senhora da Penha/MG | 0d | 2019-12-20 | 2019-12-20 | 655 |  | 366d |
| 657 | 6.2.1.6 | **Licenciamento** | 44d | 2019-12-23 | 2020-02-28 |  |  | 366d |
| 658 |  | Captação Alternativa - Autorização de perfuração (Poço 3) - Senhora da Penha/MG | 44d | 2019-12-23 | 2020-02-28 | 622, 655, 656 |  | 366d |
| 659 |  | Conclusão do Licenciamento Ambiental da Localidade - Senhora da Penha/MG | 0d | 2020-02-28 | 2020-02-28 | 658 |  | 680d |
| 660 | 6.2.1.7 | **Infraestrutura** | 380d | 2020-11-23 | 2022-06-04 |  |  | 364d |
| 661 | 6.2.1.7.1 | **Obras** | 130d | 2020-11-23 | 2021-06-04 |  |  | 366d |
| 662 |  | Captação Alternativa (Aditivo contrato guarda-chuva existente - Infraestrutura) - Senhora da Penha/MG | 0d | 2020-11-23 | 2020-11-23 | 642, 652 |  | 366d |
| 663 |  | Executar Captação Alternativa - Senhora da Penha/MG | 130d | 2020-11-24 | 2021-06-04 | 641, 662, 659FF |  | 366d |
| 664 |  | Assinatura de Termo de Entrega das Obras de Melhoria do Sistema de Abastecimento de Água - Senhora da Penha/MG | 0d | 2021-06-04 | 2021-06-04 | 663 |  | 614d |
| 665 | 6.2.1.7.2 | **Operação** | 250d | 2021-06-04 | 2022-06-04 |  |  | 364d |
| 666 |  | Realizar Treinamento Operacional do Sistema - Senhora da Penha/MG | 5d | 2021-06-07 | 2021-06-11 | 663 |  | 595d |
| 667 |  | Realizar Testes e Pré-operação - Senhora da Penha/MG | 14d | 2021-06-14 | 2021-07-01 | 666 |  | 595d |
| 668 |  | Realizar Acompanhamento da Funcionalidade do Sistema - Engenharia Captação Alternativa - Poço 3 - Senhora da Penha (distrito Fernandes Tourinho/MG) | 365ed | 2021-06-04 | 2022-06-04 | 670SS |  | 1608d |
| 669 | 6.2.1.7.2.4 | **Operação Assistida** | 64d | 2021-06-04 | 2021-09-02 |  |  | 364d |
| 670 |  | Realizar Operação Assistida - Senhora da Penha/MG | 90ed | 2021-06-04 | 2021-09-02 | 663 |  | 1608d |
| 671 | 6.2.2 | **Engenharia Captação Principal, Nova ETA e UTR** | 1097d | 2018-03-23 A | 2022-08-05 |  | 9% | 320d |
| 672 | 6.2.2.1 | **Estudos de Concepção do Sistema - Etapa 1** | 229d | 2018-03-23 A | 2019-02-07 A |  | 100% |  |
| 673 |  | Declaração de Escopo e Premissas de Projeto (DEPP) concluída - Senhora da Penha/MG | 0d | 2018-03-23 A | 2018-03-23 A | 25, 26 | 100% |  |
| 674 |  | Aprovação das DEPPs pela Operadora e Prefeitura - Senhora da Penha/MG | 0d | 2018-03-23 A | 2018-03-23 A | 673 | 100% |  |
| 675 |  | Revisar Revisão de Definições - Senhora da Penha/MG | 81d | 2018-10-17 A | 2019-02-07 A |  | 100% |  |
| 676 |  | Aprovação da Revisão de Definição pela Prefeitura - Senhora da Penha/MG | 0d | 2019-02-07 A | 2019-02-07 A | 675 | 100% |  |
| 677 | 6.2.2.2 | **Engenharia Básica e Detalhada** | 177d | 2019-12-27 | 2020-09-11 |  |  | 322d |
| 678 | 6.2.2.2.1 | **Engenharia Captação Principal, Nova ETA e UTR** | 177d | 2019-12-27 | 2020-09-11 |  |  | 322d |
| 679 |  | Aprovar Plano de Trabalho e abrir OSE - Captação Principal, ETA/UTR - Senhora da Penha/MG | 33d | 2019-12-27 | 2020-02-12 | 676FS+218d |  | 322d |
| 680 |  | Realizar Levantamento de Campo - Captação Principal, ETA/UTR - Senhora da Penha/MG | 5d | 2020-02-13 | 2020-02-19 | 679 |  | 461d |
| 681 |  | Realizar Sondagem - Captação Principal, ETA/UTR - Senhora da Penha/MG | 22d | 2020-03-02 | 2020-03-31 | 679FS+9d |  | 435d |
| 682 |  | Executar Topografia - Captação Principal, ETA/UTR - Senhora da Penha/MG | 30d | 2020-02-13 | 2020-03-30 | 679 |  | 436d |
| 683 |  | Elaborar arranjo para obtenção de Dados de Entrada Licenciamento e Fundiário - Captação Principal, ETA/UTR - Senhora da Penha/MG | 22d | 2020-01-20 | 2020-02-18 | 679SS+15d |  | 322d |
| 684 |  | Elaborar Projeto Básico - Captação Principal, ETA/UTR - Senhora da Penha/MG | 85d | 2020-01-20 | 2020-05-25 | 683SS |  | 322d |
| 685 |  | Aprovar projeto básico - Captação Principal, ETA/UTR - Senhora da Penha/MG | 22d | 2020-05-26 | 2020-06-25 | 684 |  | 322d |
| 686 |  | Emitir RT/PQ para Suprimentos - Captação Principal, ETA/UTR - Senhora da Penha/MG | 15d | 2020-08-21 | 2020-09-11 | 684, 687FF |  | 322d |
| 687 |  | Elaborar Projeto Executivo - Captação Principal, ETA/UTR - Senhora da Penha/MG | 55d | 2020-06-26 | 2020-09-11 | 683, 685, 680FF, 681FF, 682FF |  | 322d |
| 688 |  | Elaboração do Projeto Executivo - Captação Principal, ETA/UTR - Senhora da Penha/MG | 0d | 2020-09-11 | 2020-09-11 | 687 |  | 415d |
| 689 | 6.2.2.3 | **Fundiária** | 334d | 2019-01-22 A | 2020-05-28 |  | 41% | 489d |
| 690 |  | Obter Termo de Autorização de Superficiário - Captação Principal (Rio Doce) - Senhora da Penha/MG | 105d | 2019-01-22 A | 2019-06-26 A | 676FS-13d | 100% |  |
| 691 |  | Captação Principal - rio Doce - Desimpedimento de área - Senhora da Penha/MG | 161d | 2019-06-27 A | 2020-02-14 | 690 | 20% | 557d |
| 692 |  | Obter Termo de Autorização de Superficiário / Desimpedimento de área - Nova ETA / UTR - Senhora da Penha/MG | 66d | 2020-02-19 | 2020-05-28 | 683 |  | 489d |
| 693 |  | Conclusão da Regularização Fundiária para as obras de Melhoria do Sistema de Abastecimento da Localidade - Senhora da Penha/MG | 0d | 2020-05-28 | 2020-05-28 | 690, 691, 692 |  | 489d |
| 694 | 6.2.2.4 | **Licenciamento** | 176d | 2020-02-19 | 2020-11-04 |  |  | 509d |
| 695 |  | Captação Principal + Nova ETA (mais adução) e UTR - Outorga/DAIA - Senhora da Penha/MG | 176d | 2020-02-19 | 2020-11-04 | 683 |  | 509d |
| 696 |  | Conclusão do Licenciamento Ambiental da Localidade - Senhora da Penha/MG | 0d | 2020-11-04 | 2020-11-04 | 695 |  | 757d |
| 697 | 6.2.2.5 | **Suprimentos** | 88d | 2020-09-14 | 2021-01-20 |  |  | 322d |
| 698 |  | Contratação (Captação rio Doce, STA, Nova ETA's/UTR's) - Senhora da Penha/MG | 88d | 2020-09-14 | 2021-01-20 | 686 |  | 322d |
| 699 |  | Conclusão da Contratação de Suprimentos das obras de Melhoria do Sistema de Abastecimento de Água - Senhora da Penha/MG | 0d | 2021-01-20 | 2021-01-20 | 698 |  | 705d |
| 700 | 6.2.2.6 | **Infraestrutura** | 380d | 2021-01-28 | 2022-08-05 |  |  | 320d |

| ID | WBS | Task | Duration | Start | Finish | Predecessors | Complete | Total float |
| --- | --- | --- | --- | --- | --- | --- | --- | --- |
| 701 | 6.2.2.6.1 | **Obras** | 130d | 2021-01-28 | 2021-08-05 |  |  | 322d |
| 702 |  | Executar Captação Principal (Balsa, Adutora 1,5km), Nova ETA e UTR - Senhora da Penha/MG | 130d | 2021-01-28 | 2021-08-05 | 691, 695FF, 698FS+5d, 754, 688, 693 |  | 322d |
| 703 |  | Assinatura de Termo de Entrega das Obras de Melhoria do Sistema de Abastecimento de Água - Senhora da Penha/MG | 0d | 2021-08-05 | 2021-08-05 | 702, 696, 699 |  | 570d |
| 704 | 6.2.2.6.2 | **Operação** | 250d | 2021-08-05 | 2022-08-05 |  |  | 320d |
| 705 |  | Realizar Treinamento Operacional do Sistema - Senhora da Penha/MG | 5d | 2021-08-06 | 2021-08-12 | 702 |  | 551d |
| 706 |  | Realizar Testes e Pré-operação - Senhora da Penha/MG | 14d | 2021-08-13 | 2021-09-01 | 705 |  | 551d |
| 707 |  | Realizar Acompanhamento da Funcionalidade do Sistema - Engenharia Captação Principal, Nova ETA e UTR - Senhora da Penha (distrito Fernandes Tourinho/MG) | 365ed | 2021-08-05 | 2022-08-05 | 709SS |  | 1422d |
| 708 | 6.2.2.6.2.4 | **Operação Assistida** | 61d | 2021-08-05 | 2021-11-03 |  |  | 322d |
| 709 |  | Realizar Operação Assistida - Senhora da Penha/MG | 90ed | 2021-08-05 | 2021-11-03 | 702 |  | 1422d |
| 710 | 6.3 | **Pedra Corrida (distrito Periquito/MG)** | 1274d | 2018-01-16 A | 2023-02-10 |  | 32% | 191d |
| 711 | 6.3.1 | **Captação Principal, Alternativa e Melhorias em ETA** | 747d | 2018-01-16 A | 2021-01-02 |  | 50% | 718d |
| 712 | 6.3.1.1 | **Estudos de Concepção do Sistema** | 198d | 2018-03-14 A | 2018-12-14 A |  | 100% |  |
| 713 |  | Declaração de Escopo e Premissas de Projeto (DEPP) concluída - Pedra Corrida/MG | 0d | 2018-03-23 A | 2018-03-23 A | 25, 26 | 100% |  |
| 714 |  | Aprovação das DEPPs pela Operadora e Prefeitura - Pedra Corrida/MG | 0d | 2018-03-14 A | 2018-03-14 A | 25, 26 | 100% |  |
| 715 | 6.3.1.1.3 | **Serviços em Poços Tubulares - Captação Alternativa** | 36d | 2018-10-26 A | 2018-12-14 A |  | 100% |  |
| 716 |  | Realizar Perfilagem (Poço 1) - Captação Alternativa - Pedra Corrida/MG | 1d | 2018-10-26 A | 2018-10-26 A | 713 | 100% |  |
| 717 |  | Realizar Recuperação (Poço 1) - Captação Alternativa - Pedra Corrida/MG | 1d | 2018-10-26 A | 2018-10-26 A | 716SS | 100% |  |
| 718 |  | Realizar Teste de Interferência entre o Poço 1 (captação alternativa) e poço vizinho particular - Captação Alternativa - Pedra Corrida/MG | 7d | 2018-11-23 A | 2018-12-03 A | 713 | 100% |  |
| 719 |  | Elaborar Relatório Técnico - Captação Alternativa - Pedra Corrida/MG | 9d | 2018-12-04 A | 2018-12-14 A | 716, 717, 718 | 100% |  |
| 720 |  | Realizar Instrumentação - Captação Alternativa - Pedra Corrida/MG | 12d | 2018-11-15 A | 2018-11-30 A | 719FS-60d | 100% |  |
| 721 |  | Realizar Laudo de Serviços de Coleta e Análise de Água - Captação Alternativa - Pedra Corrida/MG | 15d | 2018-11-20 A | 2018-12-10 A | 717FS+16d | 100% |  |
| 722 |  | Conclusão dos Serviços em poço tubular - Captação Alternativa - Pedra Corrida/MG | 0d | 2018-12-10 A | 2018-12-10 A | 721 | 100% |  |
| 723 | 6.3.1.2 | **Engenharia Básica e Detalhada** | 258d | 2018-07-04 A | 2019-07-10 A |  | 100% |  |
| 724 | 6.3.1.2.1 | **Engenharia Captação Principal (Pequenas Melhorias)** | 168d | 2018-09-25 A | 2019-05-27 A |  | 100% |  |
| 725 |  | Aprovar Plano de Trabalho e abrir OSE - Captação Principal - Pedra Corrida/MG | 79d | 2018-09-25 A | 2019-01-14 A | 713 | 100% |  |
| 726 |  | Realizar Levantamento de Campo - Captação Principal - Pedra Corrida/MG | 1d | 2018-12-07 A | 2018-12-07 A | 725 | 100% |  |
| 727 |  | Emitir RT/PQ para Suprimentos - Captação Principal - Pedra Corrida/MG | 10d | 2019-05-14 A | 2019-05-27 A | 728FF | 100% |  |
| 728 |  | Elaborar Projeto Executivo - Captação Principal - Pedra Corrida/MG | 125d | 2018-11-23 A | 2019-05-27 A | 726FS-20d | 100% |  |
| 729 |  | Elaboração do Projeto Executivo - Captação Principal - Pedra Corrida/MG | 0d | 2019-05-27 A | 2019-05-27 A | 728 | 100% |  |
| 730 | 6.3.1.2.2 | **Engenharia Captação Alternativa (Poço 1 + STA)** | 258d | 2018-07-04 A | 2019-07-10 A |  | 100% |  |
| 731 |  | Aprovar Plano de Trabalho /abertura OSE + Levantamento de Campo - Captação Alternativa - Poço 1 + STA - Pedra Corrida/MG | 15d | 2018-07-04 A | 2018-07-24 A | 713 | 100% |  |
| 732 |  | Levantar Dados de Entrada (topografia) - Captação Alternativa - Poço 1 + STA - Pedra Corrida/MG | 29d | 2018-07-25 A | 2018-09-03 A | 731 | 100% |  |
| 733 |  | Elaborar Projeto As Built do Poço - Captação Alternativa - Poço 1 + STA - Pedra Corrida/MG | 63d | 2018-07-25 A | 2018-10-19 A | 731 | 100% |  |
| 734 |  | Emitir RT/PQ para Infra (CGC) - Captação Alternativa - Poço 1 + STA - Pedra Corrida/MG | 10d | 2019-05-20 A | 2019-07-10 A | 735FF | 100% |  |
| 735 |  | Elaborar Projeto Executivo - Captação Alternativa - Poço 1 + STA - Pedra Corrida/MG | 236d | 2018-07-25 A | 2019-07-01 A | 719FF, 731, 732FF | 100% |  |
| 736 |  | Elaboração do Projeto Executivo - Captação Alternativa - Poço 1 + STA - Pedra Corrida/MG | 0d | 2019-07-01 A | 2019-07-01 A | 735, 729 | 100% |  |
| 737 | 6.3.1.2.3 | **Engenharia Melhorias ETA** | 168d | 2018-09-25 A | 2019-05-27 A |  | 100% |  |
| 738 |  | Aprovar Plano de Trabalho /abertura OSE - Melhorias na ETA - Pedra Corrida/MG | 79d | 2018-09-25 A | 2019-01-14 A | 713 | 100% |  |
| 739 |  | Realizar Levantamento de Campo - Melhorias na ETA - Pedra Corrida/MG | 1d | 2018-12-07 A | 2018-12-07 A | 738SS+53d | 100% |  |
| 740 |  | Emitir RT/PQ para Suprimentos - Melhorias na ETA - Pedra Corrida/MG | 10d | 2019-05-14 A | 2019-05-27 A | 741FF | 100% |  |
| 741 |  | Elaborar Projeto Executivo - Melhorias na ETA - Pedra Corrida/MG | 125d | 2018-11-23 A | 2019-05-27 A | 721, 722, 739 | 100% |  |
| 742 |  | Elaboração do Projeto Executivo - Melhorias na ETA - Pedra Corrida/MG | 0d | 2019-05-27 A | 2019-05-27 A | 740, 741 | 100% |  |
| 743 | 6.3.1.3 | **Fundiária** | 332d | 2018-05-21 A | 2019-09-09 A |  | 100% |  |
| 744 |  | Obter Declaração de posse Prefeitura - Desimpedimento de área - Captação Alternativa (Poço 1) - Pedra Corrida/MG | 145d | 2018-05-21 A | 2018-12-07 A | 713FS+41d | 100% |  |
| 745 |  | Realizar Desimpedimento de área - Captação Alternativa - Adutora - Pedra Corrida/MG | 49d | 2019-07-02 A | 2019-09-09 A | 735, 744 | 100% |  |
| 746 |  | Conclusão da Regularização Fundiária para as obras de Melhoria do Sistema de Abastecimento da Localidade - Pedra Corrida/MG | 0d | 2019-09-09 A | 2019-09-09 A | 744, 745 | 100% |  |
| 747 | 6.3.1.4 | **Licenciamento** | 497d | 2018-01-16 A | 2019-12-30 |  | 81% | 968d |
| 748 |  | Obter Outorga para Captação Alternativa (Poço 1) - Pedra Corrida/MG | 264d | 2018-01-16 A | 2019-01-21 A | 26FS+41d | 100% |  |
| 749 |  | Obter DAIA para Captação Alternativa (Poço 1) - Pedra Corrida/MG | 497d | 2018-01-16 A | 2019-12-30 | 26FS+41d | 70% | 720d |
| 750 |  | Conclusão do Licenciamento Ambiental da Localidade - Pedra Corrida/MG | 0d | 2019-12-30 | 2019-12-30 | 748, 749 |  | 968d |
| 751 | 6.3.1.5 | **Infraestrutura** | 399d | 2019-05-27 A | 2021-01-02 |  | 8% | 718d |
| 752 | 6.3.1.5.1 | **Obras** | 152d | 2019-05-27 A | 2020-01-03 |  | 38% | 965d |
| 753 | 6.3.1.5.1.1 | **Captação Principal e Melhorias em ETA** | 149d | 2019-05-27 A | 2019-12-30 |  | 62% | 968d |
| 754 |  | Captação Principal e Melhorias na ETA (contrato guarda-chuva existente - Infraestrutura) - Pedra Corrida/MG | 0d | 2019-05-27 A | 2019-05-27 A | 727, 728, 741, 742 | 100% |  |
| 755 |  | Executar Captação Principal (Melhorias) - Pedra Corrida/MG | 84d | 2019-07-08 A | 2019-11-01 | 728FS+28d, 754 | 70% | 757d |
| 756 |  | Executar Melhorias de ETA - Pedra Corrida/MG | 84d | 2019-07-08 A | 2019-11-01 | 741FS+28d, 754 | 70% | 757d |
| 757 |  | Realizar fornecimento dos Pallets de Contenção de Químicos (Melhorias em ETA) - Pedra Corrida/MG | 39d | 2019-10-04 A | 2019-11-28 | 756SS+63d | 25% | 987d |
| 758 |  | Conclusão das Obras de Captação Principal e Melhorias em ETA - Pedra Corrida/MG | 0d | 2019-12-30 | 2019-12-30 | 755, 756, 757, 746, 750 |  | 968d |
| 759 | 6.3.1.5.1.2 | **Captação Alternativa** | 75d | 2019-09-16 A | 2020-01-03 |  | 4% | 965d |
| 760 |  | Executar Captação Alternativa (Adutora - Poço 1) - Pedra Corrida/MG | 75d | 2019-09-16 A | 2020-01-03 | 720, 734, 735, 744, 745, 748, 749FF, 736 | 4% | 717d |
| 761 |  | Executar Urbanização do Poço 1 - Pedra Corrida/MG | 75d | 2019-09-16 A | 2020-01-03 | 760SS | 4% | 965d |
| 762 |  | Conclusão das Obras de Captação Alternativa - Pedra Corrida/MG | 0d | 2020-01-03 | 2020-01-03 | 760, 761 |  | 965d |
| 763 |  | Assinatura de Termo de Entrega das Obras de Melhoria do Sistema de Abastecimento de Água - Pedra Corrida/MG | 0d | 2020-01-03 | 2020-01-03 | 755, 756, 758, 760, 762 |  | 965d |
| 764 | 6.3.1.5.2 | **Operação** | 247d | 2020-01-03 | 2021-01-02 |  |  | 717d |
| 765 |  | Realizar Treinamento Operacional do Sistema - Pedra Corrida/MG | 5d | 2020-01-06 | 2020-01-10 | 755, 756, 760 |  | 946d |
| 766 |  | Realizar Testes e Pré-operação - Pedra Corrida/MG | 14d | 2020-01-13 | 2020-01-30 | 765 |  | 946d |
| 767 |  | Realizar Acompanhamento da Funcionalidade do Sistema - Captação Principal, Alternativa e Melhorias em ETA - Pedra Corrida (distrito Periquito/MG) | 365ed | 2020-01-03 | 2021-01-02 | 769SS |  | 3162d |
| 768 | 6.3.1.5.2.4 | **Operação Assistida** | 61d | 2020-01-03 | 2020-04-02 |  |  | 717d |
| 769 |  | Realizar Operação Assistida - Pedra Corrida/MG | 90ed | 2020-01-03 | 2020-04-02 | 755, 756, 760 |  | 3162d |
| 770 | 6.3.2 | **UTR** | 932d | 2019-05-20 A | 2023-02-10 |  | 1% | 191d |

| ID | WBS | Task | Duration | Start | Finish | Predecessors | Complete | Total float |
| --- | --- | --- | --- | --- | --- | --- | --- | --- |
| 771 | 6.3.2.1 | **Estudos de Concepção do Sistema** | 10d | 2019-05-20 A | 2019-05-31 A |  | 100% |  |
| 772 | 6.3.2.1.1 | **Coleta e Análise do Lodo de ETA** | 10d | 2019-05-20 A | 2019-05-31 A |  | 100% |  |
| 773 |  | Executar Coleta e Análise do Lodo de ETA - Pedra Corrida/MG | 10d | 2019-05-20 A | 2019-05-31 A |  | 100% |  |
| 774 |  | Conclusão das Coletas e Análises de Lodo de ETA - Pedra Corrida/MG | 0d | 2019-05-31 A | 2019-05-31 A | 773 | 100% |  |
| 775 |  | Conclusão dos Estudos de Concepção das Melhorias do Sistema de Abastecimento de Água - Pedra Corrida/MG | 0d | 2019-05-31 A | 2019-05-31 A | 774 | 100% |  |
| 776 | 6.3.2.2 | **Engenharia Básica e Detalhada** | 284d | 2019-10-24 A | 2020-12-15 |  | 1% | 728d |
| 777 | 6.3.2.2.1 | **Engenharia UTR** | 284d | 2019-10-24 A | 2020-12-15 |  | 1% | 728d |
| 778 |  | Aprovar Plano de Trabalho /abertura OSE - UTR - Pedra Corrida/MG | 8d | 2019-10-24 A | 2019-11-04 |  | 25% | 192d |
| 779 |  | Realizar Sondagem - UTR - Pedra Corrida/MG | 6d | 2019-11-05 | 2019-11-12 | 778 |  | 192d |
| 780 |  | Elaborar arranjo para obtenção de Dados de Entrada Licenciamento - UTR - Pedra Corrida/MG | 38d | 2020-03-26 | 2020-05-21 | 774, 778, 779FS+88d |  | 192d |
| 781 |  | Elaborar Projeto Básico - UTR - Pedra Corrida/MG | 65d | 2020-05-22 | 2020-08-21 | 780 |  | 192d |
| 782 |  | Aprovar Projeto Básico - UTR - Pedra Corrida/MG | 22d | 2020-08-24 | 2020-09-23 | 781 |  | 192d |
| 783 |  | Emitir RT/PQ para Suprimentos - UTR - Pedra Corrida/MG | 10d | 2020-12-02 | 2020-12-15 | 781, 784FF |  | 192d |
| 784 |  | Elaborar Projeto Executivo - UTR - Pedra Corrida/MG | 57d | 2020-09-24 | 2020-12-15 | 781, 782 |  | 192d |
| 785 |  | Elaboração do Projeto Executivo - UTR - Pedra Corrida/MG | 0d | 2020-12-15 | 2020-12-15 | 781, 784, 775 |  | 728d |
| 786 | 6.3.2.3 | **Licenciamento** | 180d | 2020-05-22 | 2021-02-08 |  |  | 444d |
| 787 |  | Obter DAIA para execução da UTR - Pedra Corrida/MG | 180d | 2020-05-22 | 2021-02-08 | 780 |  | 444d |
| 788 |  | Conclusão do Licenciamento Ambiental da Localidade - Pedra Corrida/MG | 0d | 2021-02-08 | 2021-02-08 | 787 |  | 692d |
| 789 | 6.3.2.4 | **Suprimentos** | 88d | 2020-12-16 | 2021-04-28 |  |  | 192d |
| 790 |  | Contratação MAS 2 (UTR's) - Pedra Corrida/MG | 88d | 2020-12-16 | 2021-04-28 | 783 |  | 192d |
| 791 |  | Conclusão da Contratação de Suprimentos das obras de Melhoria do Sistema de Abastecimento de Água - Pedra Corrida/MG | 0d | 2021-04-28 | 2021-04-28 | 790, 785 |  | 640d |
| 792 | 6.3.2.5 | **Infraestrutura** | 449d | 2021-04-29 | 2023-02-10 |  |  | 191d |
| 793 | 6.3.2.5.1 | **Obras** | 200d | 2021-04-29 | 2022-02-10 |  |  | 192d |
| 794 |  | Executar UTR - Pedra Corrida/MG | 200d | 2021-04-29 | 2022-02-10 | 784, 790, 1201, 787FF |  | 192d |
| 795 |  | Assinatura de Termo de Entrega das Obras de Melhoria do Sistema de Abastecimento de Água - Pedra Corrida/MG | 0d | 2022-02-10 | 2022-02-10 | 794, 788, 791 |  | 440d |
| 796 | 6.3.2.5.2 | **Operação** | 249d | 2022-02-10 | 2023-02-10 |  |  | 191d |
| 797 |  | Realizar Treinamento Operacional do Sistema - Pedra Corrida/MG | 5d | 2022-02-11 | 2022-02-17 | 794 |  | 421d |
| 798 |  | Realizar Testes e Pré-operação - Pedra Corrida/MG | 14d | 2022-02-18 | 2022-03-14 | 797 |  | 421d |
| 799 |  | Realizar Acompanhamento da Funcionalidade do Sistema - UTR - Pedra Corrida (distrito Periquito/MG) | 365ed | 2022-02-10 | 2023-02-10 | 801SS |  | 855d |
| 800 | 6.3.2.5.2.4 | **Operação Assistida** | 59d | 2022-02-10 | 2022-05-11 |  |  | 192d |
| 801 |  | Realizar Operação Assistida - Pedra Corrida/MG | 90ed | 2022-02-10 | 2022-05-11 | 794 |  | 855d |
| 802 | 6.4 | **Alpercata/MG (sede)** | 1360d | 2018-03-23 A | 2023-08-29 |  | 1% | 57d |
| 803 | 6.4.1 | **Captação Principal, Nova ETA e UTR** | 1360d | 2018-03-23 A | 2023-08-29 |  | 1% | 57d |
| 804 |  | Declaração de Escopo e Premissas de Projeto (DEPP) concluída - Alpercata/MG | 0d | 2018-03-23 A | 2018-03-23 A | 25, 26 | 100% |  |
| 805 |  | Aprovação das DEPPs pela Operadora e Prefeitura - Alpercata/MG | 0d | 2018-03-23 A | 2018-03-23 A | 25, 26 | 100% |  |
| 806 | 6.4.1.3 | **Estudos de Concepção do Sistema** | 128d | 2019-07-09 A | 2020-01-10 |  | 30% | 57d |
| 807 |  | Pleito da COPASA no CIF de nova solução para a localidade - Alpercata/MG | 0d | 2019-07-09 A | 2019-07-09 A | 805 | 100% |  |
| 808 |  | Obter aprovação do CIF da solução pleiteada pela COPASA - Alpercata/MG | 128d | 2019-07-09 A | 2020-01-10 | 807 | 30% | 57d |
| 809 |  | Conclusão da Definição da Concepção - Alpercata/MG | 0d | 2020-01-10 | 2020-01-10 | 808 |  | 57d |
| 810 | 6.4.1.4 | **Engenharia Básica e Detalhada** | 236d | 2020-02-28 | 2021-02-05 |  |  | 57d |
| 811 | 6.4.1.4.1 | **Engenharia Captação Principal, Nova ETA e UTR (Pleito COPASA)** | 236d | 2020-02-28 | 2021-02-05 |  |  | 57d |
| 812 |  | Aprovar Plano de Trabalho e abrir OSE - Captação Principal, Nova ETA e UTR - Alpercata/MG | 11d | 2020-03-06 | 2020-03-20 | 809FS+36d |  | 57d |
| 813 |  | Realizar Levantamento de Campo - Captação Principal, Nova ETA e UTR - Alpercata/MG | 6d | 2020-03-23 | 2020-03-30 | 812 |  | 71d |
| 814 |  | Executar Topografia - Captação Principal, Nova ETA e UTR - Alpercata/MG | 22d | 2020-02-28 | 2020-03-30 | 812FF+6d |  | 57d |
| 815 |  | Executar Sondagem - Captação Principal, Nova ETA e UTR - Alpercata/MG | 26d | 2020-04-23 | 2020-05-29 | 813FS+15d |  | 71d |
| 816 |  | Elaborar arranjo conceitual para obtenção de Dados de Entrada Licenciamento e Fundiário - Captação Principal, Nova ETA e UTR - Alpercata/MG | 55d | 2020-03-31 | 2020-06-19 | 814 |  | 57d |
| 817 |  | Elaborar Projeto Básico - Captação Principal, Nova ETA e UTR - Alpercata/MG | 70d | 2020-06-22 | 2020-09-28 | 816, 815 |  | 57d |
| 818 |  | Aprovar Projeto Básico - Captação Principal, Nova ETA e UTR - Alpercata/MG | 22d | 2020-09-29 | 2020-10-29 | 817 |  | 57d |
| 819 |  | Emitir RT/PQ para Suprimentos - Captação Principal, Nova ETA e UTR - Alpercata/MG | 10d | 2021-01-25 | 2021-02-05 | 817, 820FF |  | 57d |
| 820 |  | Elaborar Projeto Executivo - Captação Principal, Nova ETA e UTR - Alpercata/MG | 67d | 2020-10-30 | 2021-02-05 | 817, 818 |  | 57d |
| 821 |  | Elaboração do Projeto Executivo - Captação Principal, Nova ETA e UTR - Alpercata/MG | 0d | 2021-02-05 | 2021-02-05 | 820 |  | 145d |
| 822 | 6.4.1.5 | **Fundiária** | 134d | 2020-06-22 | 2020-12-31 |  |  | 170d |
| 823 |  | Regularização Fundiária (Captação, ETA e UTR) - Alpercata/MG | 134d | 2020-06-22 | 2020-12-31 | 816 |  | 170d |
| 824 |  | Conclusão da Regularização Fundiária para as obras de Melhoria do Sistema de Abastecimento da Localidade - Alpercata/MG | 0d | 2020-12-31 | 2020-12-31 | 823 |  | 170d |
| 825 | 6.4.1.6 | **Licenciamento** | 180d | 2020-06-22 | 2021-03-11 |  |  | 124d |
| 826 |  | Licenciamento Ambiental (Captação, ETA e UTR) - Alpercata/MG | 180d | 2020-06-22 | 2021-03-11 | 816 |  | 124d |
| 827 |  | Conclusão do Licenciamento Ambiental da Localidade - Alpercata/MG | 0d | 2021-03-11 | 2021-03-11 | 826 |  | 124d |
| 828 | 6.4.1.7 | **Suprimentos** | 88d | 2021-02-08 | 2021-06-17 |  |  | 57d |
| 829 |  | Processo contratação (Captação, ETA e UTR) - Alpercata/MG | 88d | 2021-02-08 | 2021-06-17 | 819 |  | 57d |
| 830 |  | Conclusão da Contratação de Suprimentos das obras de Melhoria do Sistema de Abastecimento de Água - Alpercata/MG | 0d | 2021-06-17 | 2021-06-17 | 829 |  | 57d |
| 831 | 6.4.1.8 | **Infraestrutura** | 548d | 2021-06-18 | 2023-08-29 |  |  | 57d |
| 832 | 6.4.1.8.1 | **Obras** | 323d | 2021-06-18 | 2022-09-30 |  |  | 57d |
| 833 |  | Executar Melhorias na Captação Principal - Alpercata/MG | 300d | 2021-06-18 | 2022-08-29 | 820, 821, 824, 827, 830 |  | 57d |
| 834 |  | Executar Nova ETA - Alpercata/MG | 300d | 2021-06-18 | 2022-08-29 | 821, 824, 827, 830 |  | 57d |
| 835 |  | Executar UTR - Alpercata/MG | 300d | 2021-06-18 | 2022-08-29 | 821, 824, 827, 830 |  | 57d |
| 836 |  | Executar Reservatório - Alpercata/MG | 300d | 2021-06-18 | 2022-08-29 | 821, 824, 827, 830 |  | 57d |
| 837 |  | Executar Adutora - Alpercata/MG | 300d | 2021-06-18 | 2022-08-29 | 821, 824, 827, 830 |  | 57d |
| 838 |  | Executar Elevatória - Alpercata/MG | 300d | 2021-06-18 | 2022-08-29 | 824, 827, 830 |  | 57d |
| 839 |  | Assinatura de Termo de Entrega das Obras de Melhoria do Sistema de Abastecimento de Água - Alpercata/MG | 0d | 2022-09-30 | 2022-09-30 | 833, 834, 835FS+23d, 836, 837FS+23d, 838 |  | 282d |
| 840 | 6.4.1.8.2 | **Operação** | 248d | 2022-08-29 | 2023-08-29 |  |  | 57d |

| ID | WBS | Task | Duration | Start | Finish | Predecessors | Complete | Total float |
| --- | --- | --- | --- | --- | --- | --- | --- | --- |
| 841 |  | Realizar Treinamento Operacional do Sistema - Alpercata/MG | 5d | 2022-08-30 | 2022-09-05 | 833, 834, 835, 836, 837, 838 |  | 286d |
| 842 |  | Realizar Testes e Pré-operação - Alpercata/MG | 14d | 2022-09-06 | 2022-09-26 | 841 |  | 286d |
| 843 |  | Realizar Acompanhamento da Funcionalidade do Sistema - Captação Principal, Nova ETA e UTR - Alpercata/MG (sede) | 365ed | 2022-08-29 | 2023-08-29 | 845SS |  | 255d |
| 844 | 6.4.1.8.2.4 | **Operação Assistida** | 60d | 2022-08-29 | 2022-11-27 |  |  | 57d |
| 845 |  | Realizar Operação Assistida - Alpercata/MG | 90ed | 2022-08-29 | 2022-11-27 | 833, 834, 835, 836, 837, 838 |  | 255d |
| 846 | 6.5 | **Governador Valadares/MG (sede)** | 1939d | 2016-03-23 A | 2023-11-22 |  | 27% | 0d |
| 847 | 6.5.1 | **Captação Alternativa** | 1468d | 2016-03-23 A | 2021-12-30 |  | 46% | 471d |
| 848 | 6.5.1.1 | **Estudos de Concepção do Sistema** | 100d | 2017-11-03 A | 2018-03-23 A |  | 100% |  |
| 849 |  | Declaração de Escopo e Premissas de Projeto (DEPP) concluída - Governador Valadares/MG | 0d | 2018-03-23 A | 2018-03-23 A | 25, 26 | 100% |  |
| 850 |  | Aprovação das DEPPs pela Operadora e Prefeitura - Governador Valadares/MG | 0d | 2018-03-08 A | 2018-03-08 A | 25, 26 | 100% |  |
| 851 | 6.5.1.1.3 | **Captação Superficial - Rio Corrente Grande** | 20d | 2017-11-03 A | 2017-11-30 A |  | 100% |  |
| 852 |  | Realizar Laudo de Serviços de Coleta e Análise de Água - Rio Corrente Grande - Governador Valadares/MG | 20d | 2017-11-03 A | 2017-11-30 A | 849FS-100d | 100% |  |
| 853 |  | Conclusão do Laudo de Serviços de Coleta e Análise de Água- Rio Corrente Grande - Governador Valadares/MG | 0d | 2017-11-30 A | 2017-11-30 A | 852 | 100% |  |
| 854 | 6.5.1.2 | **Engenharia Básica e Detalhada** | 432d | 2016-03-23 A | 2017-11-16 A |  | 100% |  |
| 855 |  | Engenharia Captação Alternativa (rio Corrente Grande) - Governador Valadares/MG | 432d | 2016-03-23 A | 2017-11-16 A | 24 | 100% |  |
| 856 | 6.5.1.3 | **Fundiária** | 395d | 2018-03-23 A | 2019-10-09 A |  | 100% |  |
| 857 |  | Obter Termos de Autorização de Superficiário e Desimpedimento de área - Captação Alternativa - rio Corrente Grande - Governador Valadares/MG | 244d | 2018-10-22 A | 2019-10-09 A | 855FS+241d, 26 | 100% |  |
| 858 |  | Obter Termos de Autorização de Superficiário - Captação Alternativa - rio Suaçuí Grande (ETA Recanto dos Sonhos) - Governador Valadares/MG | 115d | 2018-03-23 A | 2018-08-30 A | 849 | 100% |  |
| 859 |  | Conclusão da Regularização Fundiária para as obras de Melhoria do Sistema de Abastecimento da Localidade - Governador Valadares/MG | 0d | 2019-10-09 A | 2019-10-09 A | 857, 858 | 100% |  |
| 860 | 6.5.1.4 | **Licenciamento** | 845d | 2016-03-23 A | 2019-06-28 A |  | 100% |  |
| 861 |  | Obter Outorga para Captação Alternativa - Rio Corrente Grande - Governador Valadares/MG | 342d | 2016-03-23 A | 2017-07-13 A | 24 | 100% |  |
| 862 | 6.5.1.4.2 | **DAIA para Supressão de Vegetação e intervenção em APP - Adutora GV - Captação Alternativa Rio Corrente Grande** | 46d | 2019-04-24 A | 2019-06-28 A |  | 100% |  |
| 863 |  | Protocolar pedido de informação complementar - Governador Valadares/MG | 1d | 2019-04-24 A | 2019-04-24 A | 24 | 100% |  |
| 864 |  | Acompanhar Processo Junto ao Órgão - Governador Valadares/MG | 45d | 2019-04-25 A | 2019-06-28 A | 863 | 100% |  |
| 865 |  | Obtenção de DAIA para Supressão de Vegetação e intervenção em APP - Governador Valadares/MG | 0d | 2019-06-28 A | 2019-06-28 A | 864 | 100% |  |
| 866 |  | Conclusão do Licenciamento Ambiental da Localidade - Governador Valadares/MG | 0d | 2019-06-28 A | 2019-06-28 A | 861, 865 | 100% |  |
| 867 | 6.5.1.5 | **Infraestrutura** | 885d | 2018-06-18 A | 2021-12-30 |  | 14% | 471d |
| 868 | 6.5.1.5.1 | **Obras** | 636d | 2018-06-18 A | 2020-12-29 |  | 43% | 720d |
| 869 |  | Captação Alternativa (Adutora Rio Corrente Grande) - Governador Valadares/MG | 636d | 2018-06-18 A | 2020-12-29 | 855SS, 857SS, 861SS, 853, 859FF, 866FF | 43% | 472d |
| 870 |  | Assinatura de Termo de Entrega das Obras de Melhoria do Sistema de Abastecimento de Água - Governador Valadares/MG | 0d | 2020-12-29 | 2020-12-29 | 869 |  | 720d |
| 871 | 6.5.1.5.2 | **Operação** | 249d | 2020-12-30 | 2021-12-30 |  |  | 471d |
| 872 |  | Realizar Treinamento Operacional do Sistema - Governador Valadares/MG | 5d | 2020-12-30 | 2021-01-06 | 869 |  | 472d |
| 873 |  | Realizar Testes e Pré-operação - Governador Valadares/MG | 14d | 2021-01-07 | 2021-01-26 | 872 |  | 701d |
| 874 |  | Realizar Acompanhamento da Funcionalidade do Sistema - Captação Alternativa - Governador Valadares/MG (sede) | 365ed | 2020-12-30 | 2021-12-30 | 875SS |  | 2077.12d |
| 875 |  | Realizar Operação Assistida - Governador Valadares/MG | 90ed | 2020-12-30 | 2021-03-30 | 872SS |  | 2077.12d |
| 876 | 6.5.2 | **ETA Central** | 1428d | 2018-03-08 A | 2023-11-22 |  | 20% | 0d |
| 877 | 6.5.2.1 | **Engenharia** | 710d | 2018-03-08 A | 2020-12-31 |  | 56% | 387d |
| 878 | 6.5.2.1.1 | **Estudos de Concepção do Sistema** | 11d | 2018-03-08 A | 2018-03-23 A |  | 100% |  |
| 879 |  | Declaração de Escopo e Premissas de Projeto (DEPP) concluída - Governador Valadares/MG | 0d | 2018-03-23 A | 2018-03-23 A | 25, 26 | 100% |  |
| 880 |  | Aprovação das DEPPs pela Operadora e Prefeitura - Governador Valadares/MG | 0d | 2018-03-08 A | 2018-03-08 A | 25, 26 | 100% |  |
| 881 | 6.5.2.1.2 | **Engenharia Básica e Detalhada** | 661d | 2018-05-16 A | 2020-12-31 |  | 56% | 387d |
| 882 | 6.5.2.1.2.1 | **Engenharia Captação Principal - ETA Central (Melhorias) - SE 32008** | 556d | 2018-05-16 A | 2020-07-30 |  | 56% | 375d |
| 883 |  | Levantar Dados de Entrada (levantamento de campo, topografia e sondagem) - Captação Principal - ETA Central - Governador Valadares/MG | 81d | 2018-05-16 A | 2018-09-05 A | 879 | 100% |  |
| 884 |  | Elaborar arranjo conceitual - Captação Principal - ETA Central - Governador Valadares/MG | 216d | 2018-09-06 A | 2019-07-16 A | 883 | 100% |  |
| 885 |  | Realizar testes para definição do dimensionamento do novo conjunto flutuante - Captação Principal - ETA Central - Governador Valadares/MG | 114d | 2019-07-17 A | 2019-12-30 | 884 | 25% | 375d |
| 886 |  | Realizar Sondagem Mista - Captação Principal - ETA Central - Governador Valadares/MG | 22d | 2019-11-11 | 2019-12-11 | 884, 885FF-10d |  | 530d |
| 887 |  | Elaborar Projeto Básico - Captação Principal - ETA Central - Governador Valadares/MG | 70d | 2020-01-09 | 2020-04-22 | 884, 885FS+6d |  | 375d |
| 888 |  | Aprovar Projeto Básico - Captação Principal - ETA Central - Governador Valadares/MG | 22d | 2020-04-23 | 2020-05-25 | 887 |  | 375d |
| 889 |  | Emitir RT/PQ para Suprimentos - Captação Principal - ETA Central - Governador Valadares/MG | 11d | 2020-07-16 | 2020-07-30 | 890FF |  | 375d |
| 890 |  | Elaborar Projeto Executivo - Captação Principal - ETA Central - Governador Valadares/MG | 47d | 2020-05-26 | 2020-07-30 | 884, 885, 886FF, 887SS+30d, 888 |  | 375d |
| 891 |  | Elaboração do Projeto Executivo - Captação Principal - ETA Central - Governador Valadares/MG | 0d | 2020-07-30 | 2020-07-30 | 889, 890 |  | 375d |
| 892 | 6.5.2.1.2.2 | **Engenharia Melhorias ETA - ETA Central - SE 32260** | 258d | 2018-12-10 A | 2019-12-19 |  | 96% | 642d |
| 893 |  | Levantar Dados de Entrada (levantamento de campo, topografia e sondagem) - Melhorias na ETA - ETA Central - Governador Valadares/MG | 4d | 2018-12-10 A | 2018-12-13 A | 879 | 100% |  |
| 894 |  | Emitir RT/PQ para Suprimentos - Melhorias na ETA - ETA Central - Governador Valadares/MG | 5d | 2019-09-09 A | 2019-09-13 A | 895FF | 100% |  |
| 895 |  | Elaborar Projeto Executivo - Melhorias na ETA - ETA Central - Governador Valadares/MG | 187d | 2018-12-14 A | 2019-09-13 A | 893 | 100% |  |
| 896 |  | Elaborar Projeto Executivo (Acréscimo do Macromedidor na SE) - Melhorias na ETA - ETA Central - Governador Valadares/MG | 67d | 2019-09-16 A | 2019-12-19 | 895 | 85% | 642d |
| 897 |  | Elaboração do Projeto Executivo - Melhorias na ETA - ETA Central - Governador Valadares/MG | 0d | 2019-12-19 | 2019-12-19 | 894, 895, 896 |  | 642d |
| 898 | 6.5.2.1.2.3 | **Engenharia UTR - ETA Central** | 546d | 2018-10-24 A | 2020-12-31 |  | 25% | 100d |
| 899 |  | Aprovar Plano de Trabalho e abrir OSE - UTR - ETA Central - Governador Valadares/MG | 3d | 2018-12-19 A | 2018-12-21 A | 879 | 100% |  |
| 900 |  | Realizar Levantamento de Campo - UTR - ETA Central - Governador Valadares/MG | 2d | 2019-02-01 A | 2019-02-04 A | 899 | 100% |  |
| 901 |  | Elaborar arranjo para obtenção de Dados de Entrada Licenciamento e Fundiário - UTR - ETA Central - Governador Valadares/MG | 30d | 2018-10-24 A | 2018-12-04 A |  | 100% |  |
| 902 |  | Elaborar Projeto Conceitual - UTR - ETA Central - Governador Valadares/MG | 49d | 2019-07-18 A | 2019-09-25 A | 900FS+110d | 100% |  |
| 903 |  | Elaborar Projeto Básico - UTR - ETA Central - Governador Valadares/MG | 115d | 2020-01-09 | 2020-06-26 | 902FS+70d |  | 0d |
| 904 |  | Aprovar Projeto Básico - UTR - ETA Central - Governador Valadares/MG | 22d | 2020-06-29 | 2020-07-28 | 903 |  | 0d |
| 905 |  | Emitir RT/PQ para Suprimentos - UTR - ETA Central - Governador Valadares/MG | 12d | 2020-12-14 | 2020-12-31 | 903, 906FF |  | 0d |
| 906 |  | Elaborar Projeto Executivo - UTR - ETA Central - Governador Valadares/MG | 107d | 2020-07-29 | 2020-12-31 | 900, 901, 903, 904 |  | 0d |
| 907 |  | Elaboração do Projeto Executivo - UTR - ETA Central - Governador Valadares/MG | 0d | 2020-12-31 | 2020-12-31 | 906 |  | 100d |
| 908 | 6.5.2.2 | **Licenciamento** | 199d | 2020-06-29 | 2021-04-15 |  |  | 30d |
| 909 |  | Obter DAIA para UTR - ETA Central - Governador Valadares/MG | 199d | 2020-06-29 | 2021-04-15 | 902, 903 |  | 30d |
| 910 |  | Conclusão do Licenciamento Ambiental da Localidade - Governador Valadares/MG | 0d | 2021-04-15 | 2021-04-15 | 909 |  | 30d |

| ID | WBS | Task | Duration | Start | Finish | Predecessors | Complete | Total float |
| --- | --- | --- | --- | --- | --- | --- | --- | --- |
| 911 | 6.5.2.3 | **Suprimentos** | 422d | 2019-09-16 A | 2021-05-28 |  | 25% | 0d |
| 912 | 6.5.2.3.1 | **Central** | 422d | 2019-09-16 A | 2021-05-28 |  | 25% | 0d |
| 913 |  | Realizar análise da RT/PQ pela Infra - Captação Principal e UTR - Governador Valadares/MG | 22d | 2021-01-04 | 2021-02-02 | 902FS-22d, 905 |  | 0d |
| 914 |  | Processo contratação CGC (ETA Central - Captação Principal e UTR/ Vila Isa UTR) - Governador Valadares/MG | 78d | 2021-02-03 | 2021-05-28 | 913 |  | 0d |
| 915 |  | Aprovar aditivo do contrato guarda-chuva - Melhorias ETA Central - Governador Valadares/MG | 34d | 2019-09-16 A | 2019-10-31 A | 894 | 100% |  |
| 916 |  | Conclusão da Contratação de Suprimentos - ETA Central - Governador Valadares/MG | 0d | 2021-05-28 | 2021-05-28 | 914, 915 |  | 0d |
| 917 | 6.5.2.4 | **Infraestrutura** | 932d | 2020-02-20 | 2023-11-22 |  |  | 0d |
| 918 | 6.5.2.4.1 | **Obras** | 684d | 2020-02-20 | 2022-11-22 |  |  | 248d |
| 919 | 6.5.2.4.1.1 | **ETA Central** | 684d | 2020-02-20 | 2022-11-22 |  |  | 248d |
| 920 |  | Execução Captação Principal - ETA Central - Governador Valadares/MG | 200d | 2021-05-31 | 2022-03-17 | 891, 914 |  | 170d |
| 921 |  | Executar Melhorias ETA - ETA Central - Governador Valadares/MG | 83d | 2020-02-20 | 2020-06-24 | 897, 915FS+74d |  | 601d |
| 922 |  | Executar UTR - ETA Central - Governador Valadares/MG | 370d | 2021-05-31 | 2022-11-22 | 909FF, 916, 907, 910 |  | 0d |
| 923 |  | Assinatura de Termo de Entrega das Obras de Melhoria do Sistema de Abastecimento de Água ETA Central - Governador Valadares/MG | 0d | 2022-11-22 | 2022-11-22 | 920, 921, 922 |  | 248d |
| 924 | 6.5.2.4.2 | **Operação** | 248d | 2022-11-22 | 2023-11-22 |  |  | 0d |
| 925 | 6.5.2.4.2.1 | **ETA Central** | 248d | 2022-11-22 | 2023-11-22 |  |  | 0d |
| 926 |  | Realizar Treinamento Operacional do Sistema - Governador Valadares/MG | 5d | 2022-11-23 | 2022-11-29 | 920, 921, 922 |  | 229d |
| 927 |  | Realizar Testes e Pré-operação - Governador Valadares/MG | 14d | 2022-11-30 | 2022-12-20 | 926 |  | 229d |
| 928 |  | Realizar Acompanhamento da Funcionalidade do Sistema - ETA Central - Governador Valadares/MG (sede) | 365ed | 2022-11-22 | 2023-11-22 | 930SS |  | 0d |
| 929 | 6.5.2.4.2.1.4 | **Operação Assistida** | 62d | 2022-11-22 | 2023-02-20 |  |  | 0d |
| 930 |  | Realizar Operação Assistida - Governador Valadares/MG | 90ed | 2022-11-22 | 2023-02-20 | 920, 921, 922 |  | 0d |
| 931 | 6.5.3 | **ETA Santa Rita** | 1066d | 2017-08-16 A | 2021-11-06 |  | 35% | 507d |
| 932 | 6.5.3.1 | **Engenharia** | 411d | 2018-03-05 A | 2019-10-11 A |  | 100% |  |
| 933 | 6.5.3.1.1 | **Estudos de Concepção do Sistema** | 11d | 2018-03-08 A | 2018-03-23 A |  | 100% |  |
| 934 |  | Declaração de Escopo e Premissas de Projeto (DEPP) concluída - Governador Valadares/MG | 0d | 2018-03-23 A | 2018-03-23 A | 25, 26 | 100% |  |
| 935 |  | Aprovação das DEPPs pela Operadora e Prefeitura - Governador Valadares/MG | 0d | 2018-03-08 A | 2018-03-08 A | 25, 26 | 100% |  |
| 936 | 6.5.3.1.2 | **Engenharia Básica e Detalhada** | 411d | 2018-03-05 A | 2019-10-11 A |  | 100% |  |
| 937 | 6.5.3.1.2.1 | **Engenharia Nova ETA / Captação Principal / Alternativa / UTR - ETA Santa Rita** | 304d | 2018-03-05 A | 2019-05-13 A |  | 100% |  |
| 938 |  | Levantar Dados de Entrada (levantamento de campo, topografia, sondagem) - Captação Principal / Alternativa / Nova ETA / UTR - ETA Santa Rita - Governador Valadares/MG | 110d | 2018-03-05 A | 2018-08-03 A | 26 | 100% |  |
| 939 |  | Elaborar arranjo para obtenção de Dados de Entrada Licenciamento e Fundiário - Captação Principal / Alternativa / Nova ETA / UTR - ETA Santa Rita - Governador Valadares/MG | 117d | 2018-03-05 A | 2018-08-14 A | 938FF+7d | 100% |  |
| 940 |  | Emitir RT/PQ para Suprimentos - Captação Principal / Alternativa / Nova ETA / UTR - ETA Santa Rita - Governador Valadares/MG | 10d | 2019-04-29 A | 2019-05-13 A | 941FF | 100% |  |
| 941 |  | Elaborar Projeto Executivo - Captação Principal / Alternativa / Nova ETA / UTR - ETA Santa Rita - Governador Valadares/MG | 267d | 2018-04-25 A | 2019-05-13 A | 939FS-80d | 100% |  |
| 942 |  | Elaboração do Projeto Executivo - Captação Principal / Alternativa / Nova ETA / UTR - ETA Santa Rita - Governador Valadares/MG | 0d | 2019-05-13 A | 2019-05-13 A | 940, 941 | 100% |  |
| 943 | 6.5.3.1.2.2 | **Engenharia Melhorias ETA existente - ETA Santa Rita** | 226d | 2018-11-19 A | 2019-10-11 A |  | 100% |  |
| 944 |  | Aprovar Plano de Trabalho e abrir OSE - Melhorias na ETA - ETA Santa Rita - Governador Valadares/MG | 43d | 2018-11-19 A | 2019-01-17 A | 26 | 100% |  |
| 945 |  | Realizar Levantamento de Campo - Melhorias na ETA - ETA Santa Rita - Governador Valadares/MG | 4d | 2019-01-18 A | 2019-01-23 A | 944 | 100% |  |
| 946 |  | Elaborar arranjo para obtenção de Dados de Entrada Licenciamento e Fundiário - Melhorias na ETA - ETA Santa Rita - Governador Valadares/MG | 108d | 2019-01-28 A | 2019-07-05 A | 945FS+2d | 100% |  |
| 947 |  | Emitir RT/PQ para Suprimentos - Melhorias na ETA - ETA Santa Rita - Governador Valadares/MG | 5d | 2019-06-24 A | 2019-06-28 A | 948FF | 100% |  |
| 948 |  | Elaborar Projeto Executivo - Melhorias na ETA - ETA Santa Rita - Governador Valadares/MG | 57d | 2019-04-04 A | 2019-06-27 A | 944, 946FS-30d | 100% |  |
| 949 |  | Elaboração do Projeto Executivo - Melhorias na ETA - ETA Santa Rita - Governador Valadares/MG | 0d | 2019-06-28 A | 2019-06-28 A | 947, 948 | 100% |  |
| 950 |  | Aprovar Projeto Executivo - Melhorias na ETA existente - ETA Santa Rita - Governador Valadares/MG | 19d | 2019-09-17 A | 2019-10-11 A | 949FS+55d | 100% |  |
| 951 |  | Aprovação do Projeto Executivo - Melhorias na ETA - ETA Santa Rita - Governador Valadares/MG | 0d | 2019-10-11 A | 2019-10-11 A | 950 | 100% |  |
| 952 | 6.5.3.2 | **Fundiária** | 184d | 2019-01-15 A | 2019-10-09 A |  | 100% |  |
| 953 |  | Obter Termo de Autorização para Vistoria Cautelar - UTR - ETA Santa Rita - Governador Valadares/MG | 142d | 2019-01-15 A | 2019-08-09 A | 934FS+211d | 100% |  |
| 954 |  | Conclusão da Regularização Fundiária para as obras de Melhoria do Sistema de Abastecimento da Localidade - Governador Valadares/MG | 0d | 2019-10-09 A | 2019-10-09 A | 953 | 100% |  |
| 955 | 6.5.3.3 | **Licenciamento** | 494d | 2017-08-16 A | 2019-07-19 A |  | 100% |  |
| 956 |  | Emissão Autorização Ambiental de Funcionamento - ETA Santa Rita - Governador Valadares/MG | 0d | 2017-08-16 A | 2017-08-16 A | 24FS+366d | 100% |  |
| 957 |  | Obter DAIA para UTR - ETA Santa Rita - Governador Valadares/MG | 36d | 2019-05-30 A | 2019-07-19 A | 942FS+12d | 100% |  |
| 958 |  | Conclusão do Licenciamento Ambiental da Localidade - Governador Valadares/MG | 0d | 2019-07-19 A | 2019-07-19 A | 956, 957 | 100% |  |
| 959 | 6.5.3.4 | **Suprimentos** | 122d | 2019-05-14 A | 2019-11-01 |  | 38% | 507d |
| 960 | 6.5.3.4.1 | **Santa Rita** | 122d | 2019-05-14 A | 2019-11-01 |  | 38% | 507d |
| 961 |  | Realizar análise da RT/PQ pela Infra - Nova ETA - ETA Santa Rita - Governador Valadares/MG | 22d | 2019-05-14 A | 2019-06-12 A | 940 | 100% |  |
| 962 |  | Processo contratação Nova ETA (Captações, nova ETA e UTR) - ETA Santa Rita - Governador Valadares/MG | 100d | 2019-06-13 A | 2019-11-01 | 961 | 25% | 507d |
| 963 |  | Conclusão da Contratação de Suprimentos - ETA Santa Rita - Governador Valadares/MG | 0d | 2019-11-01 | 2019-11-01 | 962 |  | 507d |
| 964 | 6.5.3.5 | **Infraestrutura** | 498d | 2019-11-04 | 2021-11-06 |  |  | 507d |
| 965 | 6.5.3.5.1 | **Obras** | 250d | 2019-11-04 | 2020-11-06 |  |  | 507d |
| 966 | 6.5.3.5.1.1 | **ETA Santa Rita** | 250d | 2019-11-04 | 2020-11-06 |  |  | 507d |
| 967 |  | Executar Melhorias na ETA existente - ETA Santa Rita - Governador Valadares/MG | 60d | 2019-11-04 | 2020-01-31 | 942, 951, 953, 956, 962 |  | 697d |
| 968 |  | Executar Nova ETA/Captação Principal/UTR - ETA Santa Rita - Governador Valadares/MG | 250d | 2019-11-04 | 2020-11-06 | 942, 957, 962, 954, 963, 958 |  | 507d |
| 969 |  | Assinatura de Termo de Entrega das Obras de Melhoria do Sistema de Abastecimento de Água ETA Santa Rita - Governador Valadares/MG | 0d | 2020-11-06 | 2020-11-06 | 967, 968 |  | 755d |
| 970 |  | Assinatura de Termo de Entrega das Obras de Melhoria do Sistema de Abastecimento de Água - Governador Valadares/MG | 0d | 2020-11-06 | 2020-11-06 | 969 |  | 755d |
| 971 | 6.5.3.5.2 | **Operação** | 248d | 2020-11-06 | 2021-11-06 |  |  | 507d |
| 972 | 6.5.3.5.2.1 | **ETA Santa Rita** | 248d | 2020-11-06 | 2021-11-06 |  |  | 507d |
| 973 |  | Realizar Treinamento Operacional do Sistema - Governador Valadares/MG | 5d | 2020-11-09 | 2020-11-13 | 967, 968 |  | 736d |
| 974 |  | Realizar Testes e Pré-operação - Governador Valadares/MG | 14d | 2020-11-16 | 2020-12-03 | 973 |  | 736d |
| 975 |  | Realizar Acompanhamento da Funcionalidade do Sistema - ETA Santa Rita - Governador Valadares/MG (sede) | 365ed | 2020-11-06 | 2021-11-06 | 977SS |  | 2238d |
| 976 | 6.5.3.5.2.1.4 | **Operação Assistida** | 61d | 2020-11-06 | 2021-02-04 |  |  | 507d |
| 977 |  | Realizar Operação Assistida - Governador Valadares/MG | 90ed | 2020-11-06 | 2021-02-04 | 967, 968 |  | 2238d |
| 978 | 6.5.4 | **ETA Vila Isa** | 1287d | 2018-03-08 A | 2023-04-28 |  | 13% | 141d |
| 979 | 6.5.4.1 | **Engenharia** | 688d | 2018-03-08 A | 2020-11-27 |  | 44% | 740d |
| 980 | 6.5.4.1.1 | **Estudos de Concepção do Sistema** | 11d | 2018-03-08 A | 2018-03-23 A |  | 100% |  |

| ID | WBS | Task | Duration | Start | Finish | Predecessors | Complete | Total float |
| --- | --- | --- | --- | --- | --- | --- | --- | --- |
| 981 |  | Declaração de Escopo e Premissas de Projeto (DEPP) concluída - Governador Valadares/MG | 0d | 2018-03-23 A | 2018-03-23 A | 25, 26 | 100% |  |
| 982 |  | Aprovação das DEPPs pela Operadora e Prefeitura - Governador Valadares/MG | 0d | 2018-03-08 A | 2018-03-08 A | 25, 26 | 100% |  |
| 983 | 6.5.4.1.2 | **Engenharia Básica e Detalhada** | 506d | 2018-11-19 A | 2020-11-27 |  | 44% | 740d |
| 984 | 6.5.4.1.2.1 | **Engenharia Melhorias na ETA e Captação Principal - ETA Vila Isa** | 239d | 2018-11-19 A | 2019-10-30 A |  | 100% |  |
| 985 |  | Aprovar Plano de Trabalho /abertura OSE - Melhorias na ETA e Captação Principal - ETA Vila Isa - Governador Valadares/MG | 4d | 2018-11-19 A | 2018-11-22 A | 981 | 100% |  |
| 986 |  | Realizar Levantamento de Campo - Melhorias na ETA e Captação Principal - ETA Vila Isa - Governador Valadares/MG | 1d | 2018-12-13 A | 2018-12-13 A | 985 | 100% |  |
| 987 |  | Elaborar arranjo para obtenção de Dados de Entrada Licenciamento e Fundiário - Melhorias na ETA - ETA Vila Isa - Governador Valadares/MG | 13d | 2019-10-14 A | 2019-10-30 A | 991FF+30d | 100% |  |
| 988 |  | Emitir RT/PQ para Suprimentos - Captação Principal - ETA Vila Isa - Governador Valadares/MG | 5d | 2019-04-15 A | 2019-04-23 A | 989FF | 100% |  |
| 989 |  | Elaborar Projeto Executivo - Captação Principal - ETA Vila Isa - Governador Valadares/MG | 28d | 2019-03-13 A | 2019-04-23 A |  | 100% |  |
| 990 |  | Elaboração do Projeto Executivo - Captação Principal - ETA Vila Isa - Governador Valadares/MG | 0d | 2019-04-23 A | 2019-04-23 A | 988, 989 | 100% |  |
| 991 |  | Aprovar Projeto Executivo - Melhorias na ETA - ETA Vila Isa - Governador Valadares/MG | 124d | 2019-04-04 A | 2019-10-01 A | 986, 990 | 100% |  |
| 992 |  | Elaboração do Projeto Executivo - Melhorias na ETA - ETA Vila Isa - Governador Valadares/MG | 0d | 2019-10-01 A | 2019-10-01 A | 991, 987FS-22d | 100% |  |
| 993 | 6.5.4.1.2.2 | **Engenharia Captação Alternativa (Derivação da Adutora de GV) - ETA Vila Isa** | 197d | 2019-03-01 A | 2019-12-16 |  | 60% | 976d |
| 994 |  | Aprovar Plano de Trabalho e abrir OSE - Captação Alternativa - ETA Vila Isa - Governador Valadares/MG | 60d | 2019-03-01 A | 2019-05-31 A | 981FS+343ed | 100% |  |
| 995 |  | Definir ponto de entrega da tubulação - Captação Alternativa - ETA Vila Isa - Governador Valadares/MG | 1d | 2019-10-02 A | 2019-10-02 A | 991 | 100% |  |
| 996 |  | Emitir RT/PQ para Suprimentos - Captação Alternativa - ETA Vila Isa - Governador Valadares/MG | 10d | 2019-12-02 | 2019-12-16 | 997FF |  | 976d |
| 997 |  | Elaborar Projeto Executivo - Captação Alternativa - ETA Vila Isa - Governador Valadares/MG | 51d | 2019-10-03 A | 2019-12-16 | 994, 995 | 25% | 976d |
| 998 |  | Elaboração do Projeto Executivo - Captação Alternativa - ETA Vila Isa - Governador Valadares/MG | 0d | 2019-12-16 | 2019-12-16 | 996, 997 |  | 976d |
| 999 | 6.5.4.1.2.3 | **Engenharia UTR - ETA Vila Isa** | 262d | 2019-11-07 | 2020-11-27 |  |  | 142d |
| 1000 |  | Aprovar Plano de Trabalho e abrir OSE - UTR - ETA Vila Isa - Governador Valadares/MG | 12d | 2019-11-07 | 2019-11-25 | 981FS+415d |  | 142d |
| 1001 |  | Realizar Levantamento de Campo - UTR - ETA Vila Isa - Governador Valadares/MG | 1d | 2019-11-26 | 2019-11-26 | 1000 |  | 142d |
| 1002 |  | Elaborar projeto conceitual - UTR - ETA Vila Isa - Governador Valadares/MG | 94d | 2019-11-27 | 2020-04-16 | 1001 |  | 142d |
| 1003 |  | Elaborar Projeto Básico - UTR - ETA Vila Isa - Governador Valadares/MG | 65d | 2020-04-17 | 2020-07-21 | 1002 |  | 142d |
| 1004 |  | Aprovar Projeto Básico - UTR - ETA Vila Isa - Governador Valadares/MG | 22d | 2020-07-22 | 2020-08-20 | 1003 |  | 142d |
| 1005 |  | Emitir RT/PQ para Suprimentos - UTR - ETA Vila Isa - Governador Valadares/MG | 7d | 2020-11-19 | 2020-11-27 | 1006FF |  | 142d |
| 1006 |  | Elaborar Projeto Executivo - UTR - ETA Vila Isa - Governador Valadares/MG | 68d | 2020-08-21 | 2020-11-27 | 1003, 1004 |  | 142d |
| 1007 |  | Elaboração do Projeto Executivo - UTR - ETA Vila Isa - Governador Valadares/MG | 0d | 2020-11-27 | 2020-11-27 | 1006 |  | 242d |
| 1008 | 6.5.4.2 | **Fundiária** | 193d | 2019-01-02 A | 2019-10-09 A |  | 100% |  |
| 1009 |  | Obter Termo de Autorização para Vistoria Cautelar - UTR - ETA Vila Isa - Governador Valadares/MG | 74d | 2019-01-02 A | 2019-04-22 A | 981FS+202d | 100% |  |
| 1010 |  | Conclusão da Regularização Fundiária para as obras de Melhoria do Sistema de Abastecimento da Localidade - Governador Valadares/MG | 0d | 2019-10-09 A | 2019-10-09 A | 1009 | 100% |  |
| 1011 | 6.5.4.3 | **Licenciamento** | 199d | 2020-04-17 | 2021-02-02 |  |  | 198d |
| 1012 |  | Obter DAIA para UTR - ETA Vila Isa - Governador Valadares/MG | 199d | 2020-04-17 | 2021-02-02 | 1002 |  | 198d |
| 1013 |  | Conclusão do Licenciamento Ambiental da Localidade - Governador Valadares/MG | 0d | 2021-02-02 | 2021-02-02 | 1012 |  | 198d |
| 1014 | 6.5.4.4 | **Suprimentos** | 100d | 2020-11-30 | 2021-04-28 |  |  | 142d |
| 1015 | 6.5.4.4.1 | **Vila Isa** | 100d | 2020-11-30 | 2021-04-28 |  |  | 142d |
| 1016 |  | Realizar análise da RT/PQ pela Infra - UTR - ETA Vila Isa - Governador Valadares/MG | 22d | 2020-11-30 | 2020-12-31 | 1002FS-22d, 1005 |  | 142d |
| 1017 |  | Processo contratação CGC (ETA Central - Captação Principal e UTR/ Vila Isa UTR) - Governador Valadares/MG | 78d | 2021-01-04 | 2021-04-28 | 1016 |  | 142d |
| 1018 |  | Conclusão da Contratação de Suprimentos - ETA Vila Isa - Governador Valadares/MG | 0d | 2021-04-28 | 2021-04-28 | 1017 |  | 640d |
| 1019 |  | Conclusão da Contratação de Suprimentos das obras de Melhoria do Sistema de Abastecimento de Água - Governador Valadares/MG | 0d | 2021-04-28 | 2021-04-28 | 1018 |  | 640d |
| 1020 | 6.5.4.5 | **Infraestrutura** | 1061d | 2019-01-21 A | 2023-04-28 |  | 2% | 141d |
| 1021 | 6.5.4.5.1 | **Obras** | 812d | 2019-01-21 A | 2022-04-28 |  | 10% | 390d |
| 1022 | 6.5.4.5.1.1 | **ETA Vila Isa** | 812d | 2019-01-21 A | 2022-04-28 |  | 10% | 390d |
| 1023 |  | Executar Melhorias na captação Principal - ETA Vila Isa - Governador Valadares/MG | 41d | 2019-01-21 A | 2019-03-21 A | 989FS-62d | 100% |  |
| 1024 |  | Executar Melhorias ETA - ETA Vila Isa - Governador Valadares/MG | 127d | 2019-12-04 | 2020-06-12 | 992FS+44d |  | 609d |
| 1025 |  | Executar UTR - ETA Vila Isa - Governador Valadares/MG | 250d | 2021-04-29 | 2022-04-28 | 1006, 1007, 1009, 1012FF, 1017, 1013, 1010 |  | 142d |
| 1026 |  | Assinatura de Termo de Entrega das Obras de Melhoria do Sistema de Abastecimento de Água ETA Vila Isa - Governador Valadares/MG | 0d | 2022-04-28 | 2022-04-28 | 1023, 1024, 1025, 1019, 998 |  | 390d |
| 1027 |  | Assinatura de Termo de Entrega das Obras de Melhoria do Sistema de Abastecimento de Água - Governador Valadares/MG | 0d | 2022-04-28 | 2022-04-28 | 1026 |  | 390d |
| 1028 | 6.5.4.5.2 | **Operação** | 249d | 2022-04-28 | 2023-04-28 |  |  | 141d |
| 1029 | 6.5.4.5.2.1 | **ETA Vila Isa** | 249d | 2022-04-28 | 2023-04-28 |  |  | 141d |
| 1030 |  | Realizar Treinamento Operacional do Sistema - Governador Valadares/MG | 5d | 2022-04-29 | 2022-05-05 | 1024, 1025 |  | 371d |
| 1031 |  | Realizar Testes e Pré-operação - Governador Valadares/MG | 14d | 2022-05-06 | 2022-05-25 | 1030 |  | 371d |
| 1032 |  | Realizar Acompanhamento da Funcionalidade do Sistema - ETA Vila Isa - Governador Valadares/MG (sede) | 365ed | 2022-04-28 | 2023-04-28 | 1034SS |  | 624d |
| 1033 | 6.5.4.5.2.1.4 | **Operação Assistida** | 63d | 2022-04-28 | 2022-07-27 |  |  | 141d |
| 1034 |  | Realizar Operação Assistida - Governador Valadares/MG | 90ed | 2022-04-28 | 2022-07-27 | 1024, 1025 |  | 624d |
| 1035 | 6.5.5 | **Captação Principal e Melhorias na ETA Recanto dos Sonhos** | 1167d | 2018-03-08 A | 2022-11-01 |  | 22% | 261d |
| 1036 | 6.5.5.1 | **Engenharia** | 677d | 2018-03-08 A | 2020-11-12 |  | 52% | 673d |
| 1037 | 6.5.5.1.1 | **Estudos de Concepção do Sistema** | 11d | 2018-03-08 A | 2018-03-23 A |  | 100% |  |
| 1038 |  | Declaração de Escopo e Premissas de Projeto (DEPP) concluída - Governador Valadares/MG | 0d | 2018-03-23 A | 2018-03-23 A | 25, 26 | 100% |  |
| 1039 |  | Aprovação das DEPPs pela Operadora e Prefeitura - Governador Valadares/MG | 0d | 2018-03-08 A | 2018-03-08 A | 25, 26 | 100% |  |
| 1040 | 6.5.5.1.2 | **Engenharia Básica e Detalhada** | 522d | 2018-10-11 A | 2020-11-12 |  | 52% | 673d |
| 1041 | 6.5.5.1.2.1 | **Engenharia Melhorias ETA - ETA Recanto dos Sonhos** | 278d | 2018-10-11 A | 2019-11-18 |  | 91% | 917d |
| 1042 |  | Aprovar Plano de Trabalho e abrir OSE - Melhorias na ETA - ETA Recanto dos Sonhos - Governador Valadares/MG | 15d | 2018-11-05 A | 2018-11-23 A | 1038 | 100% |  |
| 1043 |  | Realizar Levantamento de Campo - Melhorias na ETA - ETA Recanto dos Sonhos - Governador Valadares/MG | 1d | 2018-12-13 A | 2018-12-13 A | 1042 | 100% |  |
| 1044 |  | Realizar Sondagem - Melhorias na ETA - ETA Recanto dos Sonhos - Governador Valadares/MG | 22d | 2019-01-18 A | 2019-02-18 A | 1042 | 100% |  |
| 1045 |  | Executar Topografia - Melhorias na ETA - ETA Recanto dos Sonhos - Governador Valadares/MG | 72d | 2018-10-11 A | 2019-01-21 A | 1042 | 100% |  |
| 1046 |  | Emitir RT/PQ para Suprimentos - Melhorias na ETA - ETA Recanto dos Sonhos - Governador Valadares/MG | 10d | 2019-05-17 A | 2019-05-30 A | 1047FF | 100% |  |
| 1047 |  | Elaborar Projeto Executivo - Melhorias na ETA - ETA Recanto dos Sonhos - Governador Valadares/MG | 113d | 2018-12-14 A | 2019-05-30 A | 1043FF, 1044FF, 1045FF+30d | 100% |  |
| 1048 |  | Elaboração do Projeto Executivo - Melhorias na ETA - ETA Recanto dos Sonhos - Governador Valadares/MG | 0d | 2019-05-30 A | 2019-05-30 A | 1046, 1047 | 100% |  |
| 1049 |  | Elaborar Projeto Executivo (Acréscimo do Macromedidor na SE) - Melhorias na ETA - ETA Recanto dos Sonhos - Governador Valadares/MG | 31d | 2019-10-04 A | 2019-11-18 | 1048FS+88d | 25% | 917d |
| 1050 |  | Acréscimo no escopo do Projeto Executivo (Macromedidor) - Melhorias na ETA - ETA Recanto dos Sonhos - Governador Valadares/MG | 0d | 2019-11-18 | 2019-11-18 | 1049 |  | 917d |

| ID | WBS | Task | Duration | Start | Finish | Predecessors | Complete | Total float |
| --- | --- | --- | --- | --- | --- | --- | --- | --- |
| 1051 | 6.5.5.1.2.2 | **Engenharia UTR - ETA Recanto dos Sonhos** | 214d | 2020-01-06 | 2020-11-12 |  |  | 262d |
| 1052 |  | Aprovar Plano de Trabalho /abertura OSE - UTR - ETA Recanto dos Sonhos - Governador Valadares/MG | 10d | 2020-01-06 | 2020-01-17 | 1038FS+452d |  | 262d |
| 1053 |  | Realizar Sondagem - UTR - ETA Recanto dos Sonhos - Governador Valadares/MG | 14d | 2020-03-25 | 2020-04-14 | 1052FS+44d |  | 262d |
| 1054 |  | Elaborar Projeto Básico - UTR - ETA Recanto dos Sonhos - Governador Valadares/MG | 67d | 2020-04-15 | 2020-07-21 | 1053 |  | 262d |
| 1055 |  | Aprovar Projeto Básico - UTR - ETA Recanto dos Sonhos - Governador Valadares/MG | 22d | 2020-07-22 | 2020-08-20 | 1054 |  | 262d |
| 1056 |  | Emitir RT/PQ para Suprimentos - UTR - ETA Recanto dos Sonhos - Governador Valadares/MG | 10d | 2020-08-21 | 2020-09-03 | 1054FS+22d, 1055 |  | 262d |
| 1057 |  | Elaborar Projeto Executivo - UTR - ETA Recanto dos Sonhos - Governador Valadares/MG | 79d | 2020-07-22 | 2020-11-12 | 1053, 1054 |  | 303d |
| 1058 |  | Elaboração do Projeto Executivo - UTR - ETA Recanto dos Sonhos - Governador Valadares/MG | 0d | 2020-11-12 | 2020-11-12 | 1057 |  | 303d |
| 1059 | 6.5.5.2 | **Fundiária** | 395d | 2018-03-23 A | 2019-10-09 A |  | 100% |  |
| 1060 |  | Obter Termos de Autorização de Superficiário - Captação Alternativa - rio Suaçuí Grande (ETA Recanto dos Sonhos) - Governador Valadares/MG | 115d | 2018-03-23 A | 2018-08-30 A | 1038 | 100% |  |
| 1061 |  | Captação Alternativa - rio Suaçuí Grande (ETA Recanto dos Sonhos) - Desimpedimentos de área - Governador Valadares/MG | 115d | 2018-03-23 A | 2018-08-30 A | 1060 | 100% |  |
| 1062 |  | Conclusão da Regularização Fundiária para as obras de Melhoria do Sistema de Abastecimento da Localidade - Governador Valadares/MG | 0d | 2019-10-09 A | 2019-10-09 A | 1060, 1061 | 100% |  |
| 1063 | 6.5.5.3 | **Licenciamento** | 199d | 2020-07-22 | 2021-05-11 |  |  | 383d |
| 1064 |  | Obter DAIA para UTR - ETA Recanto dos Sonhos - Governador Valadares/MG | 199d | 2020-07-22 | 2021-05-11 | 1054 |  | 383d |
| 1065 |  | Conclusão do Licenciamento Ambiental da Localidade - Governador Valadares/MG | 0d | 2021-05-11 | 2021-05-11 | 1064 |  | 383d |
| 1066 | 6.5.5.4 | **Suprimentos** | 88d | 2020-09-04 | 2021-01-13 |  |  | 262d |
| 1067 | 6.5.5.4.1 | **Recanto dos Sonhos** | 88d | 2020-09-04 | 2021-01-13 |  |  | 262d |
| 1068 |  | Processo contratação MAS 1 (Captação, ETA e UTR) - Governador Valadares/MG | 88d | 2020-09-04 | 2021-01-13 | 1046, 1056, 1062 |  | 262d |
| 1069 |  | Conclusão da Contratação de Suprimentos - ETA Recanto dos Sonhos - Governador Valadares/MG | 0d | 2021-01-13 | 2021-01-13 | 1068 |  | 262d |
| 1070 |  | Conclusão da Contratação de Suprimentos das obras de Melhoria do Sistema de Abastecimento de Água - Governador Valadares/MG | 0d | 2021-01-13 | 2021-01-13 | 1069 |  | 262d |
| 1071 | 6.5.5.5 | **Infraestrutura** | 921d | 2019-02-18 A | 2022-11-01 |  | 7% | 261d |
| 1072 | 6.5.5.5.1 | **Obras** | 672d | 2019-02-18 A | 2021-11-01 |  | 32% | 510d |
| 1073 | 6.5.5.5.1.1 | **ETA Recanto dos Sonhos** | 672d | 2019-02-18 A | 2021-11-01 |  | 32% | 510d |
| 1074 |  | Executar Captação Principal - ETA Recanto dos Sonhos - Governador Valadares/MG | 20d | 2019-02-18 A | 2019-03-20 A |  | 100% |  |
| 1075 | 6.5.5.5.1.1.2 | **Melhorias na ETA Recanto do Sonhos** | 234d | 2019-04-05 A | 2020-03-16 |  | 59% | 917d |
| 1076 |  | Executar Obras de Urbanização da ETA Recanto dos Sonhos - Governador Valadares/MG | 111d | 2019-04-05 A | 2019-09-13 A | 1047FS-37d | 100% |  |
| 1077 |  | Executar Obras de Melhorias na ETA (Macromedidor) - ETA Recanto dos Sonhos - Governador Valadares/MG | 78d | 2019-11-19 | 2020-03-16 | 1050 |  | 917d |
| 1078 |  | Conclusão das Obras de Melhoria na ETA Recanto dos Sonhos - Governador Valadares/MG | 0d | 2020-03-16 | 2020-03-16 | 1076, 1077 |  | 917d |
| 1079 |  | Executar UTR - ETA Recanto dos Sonhos - Governador Valadares/MG | 200d | 2021-01-14 | 2021-11-01 | 1057, 1064FF, 1069, 1058, 1070, 1065FF |  | 262d |
| 1080 |  | Assinatura de Termo de Entrega das Obras de Melhoria do Sistema de Abastecimento de Água ETA Reacanto dos Sonhos - Governador Valadares/MG | 0d | 2021-11-01 | 2021-11-01 | 1074, 1078, 1079 |  | 510d |
| 1081 |  | Assinatura de Termo de Entrega das Obras de Melhoria do Sistema de Abastecimento de Água - Governador Valadares/MG | 0d | 2021-11-01 | 2021-11-01 | 1080 |  | 510d |
| 1082 | 6.5.5.5.2 | **Operação** | 249d | 2021-11-01 | 2022-11-01 |  |  | 261d |
| 1083 | 6.5.5.5.2.1 | **ETA Recanto dos Sonhos** | 249d | 2021-11-01 | 2022-11-01 |  |  | 261d |
| 1084 |  | Realizar Treinamento Operacional do Sistema - Governador Valadares/MG | 5d | 2021-11-03 | 2021-11-09 | 1074, 1079 |  | 491d |
| 1085 |  | Realizar Testes e Pré-operação - Governador Valadares/MG | 14d | 2021-11-10 | 2021-11-30 | 1084 |  | 491d |
| 1086 |  | Realizar Acompanhamento da Funcionalidade do Sistema - Captação Principal e Melhorias na ETA Recanto dos Sonhos - Governador Valadares/MG (sede) | 365ed | 2021-11-01 | 2022-11-01 | 1088SS |  | 1158d |
| 1087 | 6.5.5.5.2.1.4 | **Operação Assistida** | 61d | 2021-11-01 | 2022-01-30 |  |  | 262d |
| 1088 |  | Realizar Operação Assistida - Governador Valadares/MG | 90ed | 2021-11-01 | 2022-01-30 | 1074, 1079 |  | 1158d |
| 1089 | 6.6 | **São Vítor (distrito Governador Valadares/MG)** | 1149d | 2018-01-10 A | 2022-08-05 |  | 23% | 320d |
| 1090 | 6.6.1 | **Captação Principal e Melhorias na ETA** | 719d | 2018-03-23 A | 2021-01-30 |  | 39% | 698d |
| 1091 | 6.6.1.1 | **Estudos de Concepção do Sistema** | 336d | 2018-03-23 A | 2019-07-17 A |  | 100% |  |
| 1092 |  | Declaração de Escopo e Premissas de Projeto (DEPP) concluída - São Vítor/MG | 0d | 2018-03-23 A | 2018-03-23 A | 25, 26 | 100% |  |
| 1093 |  | Aprovação das DEPPs pela Operadora e Prefeitura - São Vítor/MG | 10d | 2019-02-19 A | 2019-03-07 A | 1103 | 100% |  |
| 1094 |  | Executar Coleta e Análise do Lodo da ETA - São Vítor/MG | 9d | 2019-05-21 A | 2019-05-31 A | 1093FS+49d | 100% |  |
| 1095 | 6.6.1.1.4 | **Captações Subterrâneas - Serviços em Poços Tubulares (Captação Alternativa)** | 280d | 2018-06-11 A | 2019-07-17 A |  | 100% |  |
| 1096 |  | Realizar Perfilagem 1 (parcial) - Captação Alternativa - São Vítor/MG | 2d | 2018-06-11 A | 2018-06-12 A | 1092 | 100% |  |
| 1097 |  | Realizar Recuperação 1 (parcial) - Captação Alternativa - São Vítor/MG | 7d | 2018-06-13 A | 2018-06-21 A | 1096 | 100% |  |
| 1098 |  | Realizar Perfuração (reabertura de poço existente) - Captação Alternativa - São Vítor/MG | 2d | 2019-01-15 A | 2019-01-16 A | 1097FS+147d | 100% |  |
| 1099 |  | Realizar Recuperação - Captação Alternativa - São Vítor/MG | 2d | 2019-01-16 A | 2019-01-17 A | 1098SS+1d | 100% |  |
| 1100 |  | Realizar Perfilagem 2 - Captação Alternativa - São Vítor/MG | 1d | 2019-01-18 A | 2019-01-18 A | 1099 | 100% |  |
| 1101 |  | Elaborar Relatório Técnico - Captação Alternativa - São Vítor/MG | 23d | 2019-01-21 A | 2019-02-20 A | 1096, 1097, 1098, 1099, 1100 | 100% |  |
| 1102 |  | Realizar Instrumentação - Captação Alternativa - São Vítor/MG | 2d | 2019-07-16 A | 2019-07-17 A | 1101FS+96d | 100% |  |
| 1103 |  | Realizar Laudo de Serviços de Coleta, Análise de Água - Captação Alternativa - São Vítor/MG | 22d | 2019-01-18 A | 2019-02-18 A | 1099 | 100% |  |
| 1104 |  | Conclusão dos Serviços em poço tubular - Captação Alternativa - São Vítor/MG | 0d | 2019-02-18 A | 2019-02-18 A | 1103, 1102 | 100% |  |
| 1105 | 6.6.1.2 | **Engenharia Básica e Detalhada** | 281d | 2018-10-08 A | 2019-11-18 |  | 99% | 898d |
| 1106 | 6.6.1.2.1 | **Engenharia Captação Principal (Melhorias) - SE 32262** | 162d | 2018-10-08 A | 2019-05-30 A |  | 100% |  |
| 1107 |  | Aprovar Plano de Trabalho e abrir OSE - Captação Principal - Rio Doce - São Vítor/MG | 6d | 2018-11-19 A | 2018-11-26 A | 1092 | 100% |  |
| 1108 |  | Realizar Levantamento de Campo - Captação Principal - Rio Doce - São Vítor/MG | 1d | 2018-12-14 A | 2018-12-14 A | 1092, 1107FF | 100% |  |
| 1109 |  | Executar Topografia - Captação Principal - Rio Doce - São Vítor/MG | 75d | 2018-10-08 A | 2019-01-21 A | 1092 | 100% |  |
| 1110 |  | Emitir RT/PQ para Suprimentos - Captação Principal - Rio Doce - São Vítor/MG | 8d | 2019-05-21 A | 2019-05-30 A | 1111FF | 100% |  |
| 1111 |  | Elaborar Projeto Executivo - Captação Principal - Rio Doce - São Vítor/MG | 113d | 2018-12-14 A | 2019-05-30 A | 1108, 1109FS-60d | 100% |  |
| 1112 |  | Elaboração do Projeto Executivo - Captação Principal - Rio Doce - São Vítor/MG | 0d | 2019-05-30 A | 2019-05-30 A | 1111, 1104, 1094 | 100% |  |
| 1113 | 6.6.1.2.2 | **Engenharia Melhorias ETA - SE 32262** | 281d | 2018-10-08 A | 2019-11-18 |  | 99% | 898d |
| 1114 |  | Aprovar Plano de Trabalho e abrir OSE - Melhorias na ETA - São Vítor/MG | 6d | 2018-11-19 A | 2018-11-26 A | 1092 | 100% |  |
| 1115 |  | Realizar Levantamento de Campo - Melhorias na ETA - São Vítor/MG | 1d | 2018-12-14 A | 2018-12-14 A | 1092, 1114FF | 100% |  |
| 1116 |  | Executar Topografia - Melhorias na ETA - São Vítor/MG | 75d | 2018-10-08 A | 2019-01-21 A | 1092 | 100% |  |
| 1117 |  | Emitir RT/PQ para Suprimentos - Melhorias na ETA - São Vítor/MG | 10d | 2019-05-17 A | 2019-05-30 A | 1118FF | 100% |  |
| 1118 |  | Elaborar Projeto Executivo - Melhorias na ETA - São Vítor/MG | 112d | 2018-12-17 A | 2019-05-30 A | 1103FF, 1115, 1116 | 100% |  |
| 1119 |  | Elaboração do Projeto Executivo - Melhorias na ETA - São Vítor/MG | 0d | 2019-05-30 A | 2019-05-30 A | 1118 | 100% |  |
| 1120 |  | Elaborar Projeto Executivo (Acréscimo do Macromedidor na SE) - Melhorias na ETA - São Vítor/MG | 53d | 2019-09-04 A | 2019-11-18 | 1119FS+66d | 97% | 898d |

| ID | WBS | Task | Duration | Start | Finish | Predecessors | Complete | Total float |
| --- | --- | --- | --- | --- | --- | --- | --- | --- |
| 1121 |  | Acréscimo no escopo do Projeto Executivo (Macromedidor) - Melhorias na ETA - São Vítor/MG | 0d | 2019-11-18 | 2019-11-18 | 1120 |  | 898d |
| 1122 | 6.6.1.3 | **Fundiária** | 143d | 2018-06-06 A | 2018-12-21 A |  | 100% |  |
| 1123 |  | Obter Termo de Autorização de Superficiário - ETA/Captação Alternativa - São Vítor/MG | 143d | 2018-06-06 A | 2018-12-21 A | 1092FS+53d | 100% |  |
| 1124 |  | Conclusão da Regularização Fundiária para as obras de Melhoria do Sistema de Abastecimento da Localidade - São Vítor/MG | 0d | 2018-12-21 A | 2018-12-21 A | 1123 | 100% |  |
| 1125 | 6.6.1.4 | **Suprimentos** | 8d | 2019-06-03 A | 2019-06-12 A |  | 100% |  |
| 1126 | 6.6.1.4.1 | **Captação Principal e Melhorias na ETA (contrato guarda-chuva existente - Infraestrutura)** | 8d | 2019-06-03 A | 2019-06-12 A |  | 100% |  |
| 1127 |  | Incluir PQ no CGC existente - São Vítor/MG | 8d | 2019-06-03 A | 2019-06-12 A | 1110FS+1d, 1111, 1117, 1118 | 100% |  |
| 1128 |  | Conclusão da Contratação de Suprimentos - São Vítor/MG | 0d | 2019-06-12 A | 2019-06-12 A | 1127 | 100% |  |
| 1129 | 6.6.1.5 | **Infraestrutura** | 422d | 2019-05-23 A | 2021-01-30 |  | 15% | 698d |
| 1130 | 6.6.1.5.1 | **Obras** | 203d | 2019-05-23 A | 2020-03-16 |  | 71% | 898d |
| 1131 |  | Executar Melhorias na Captação Principal - São Vítor/MG | 126d | 2019-05-23 A | 2019-11-19 | 1111FS-15d, 1128FS-15d, 1112 | 90% | 746d |
| 1132 | 6.6.1.5.1.2 | **Melhorias na ETA** | 203d | 2019-05-23 A | 2020-03-16 |  | 62% | 898d |
| 1133 |  | Executar Melhorias na ETA - São Vítor/MG | 175d | 2019-05-23 A | 2020-01-31 | 1118FS-15d, 1128FS-15d, 1124 | 90% | 697d |
| 1134 |  | Executar Melhorias na ETA (Acréscimo do Macromedidor) - São Vítor/MG | 78d | 2019-11-19 | 2020-03-16 | 1120, 1121 |  | 898d |
| 1135 |  | Conclusão das Obras de Melhorias na ETA - São Vítor/MG | 0d | 2020-03-16 | 2020-03-16 | 1134 |  | 898d |
| 1136 | 6.6.1.5.2 | **Operação** | 247d | 2020-01-31 | 2021-01-30 |  |  | 697d |
| 1137 |  | Realizar Treinamento Operacional do Sistema - São Vítor/MG | 5d | 2020-03-17 | 2020-03-23 | 1131, 1133, 1135 |  | 898d |
| 1138 |  | Realizar Testes e Pré-operação - São Vítor/MG | 14d | 2020-03-24 | 2020-04-13 | 1137 |  | 898d |
| 1139 |  | Realizar Acompanhamento da Funcionalidade do Sistema - Captação Principal e Melhorias na ETA - São Vítor (distrito Governador Valadares/MG) | 365ed | 2020-01-31 | 2021-01-30 | 1141SS |  | 3078d |
| 1140 | 6.6.1.5.2.4 | **Operação Assistida** | 59d | 2020-01-31 | 2020-04-30 |  |  | 697d |
| 1141 |  | Realizar Operação Assistida - São Vítor/MG | 90ed | 2020-01-31 | 2020-04-30 | 1131, 1133 |  | 3078d |
| 1142 | 6.6.2 | **Captação Alternativa** | 798d | 2018-01-10 A | 2021-03-12 |  | 26% | 671d |
| 1143 | 6.6.2.1 | **Estudos de Concepção do Sistema** | 336d | 2018-03-23 A | 2019-07-17 A |  | 100% |  |
| 1144 |  | Declaração de Escopo e Premissas de Projeto (DEPP) concluída - São Vítor/MG | 0d | 2018-03-23 A | 2018-03-23 A | 25, 26 | 100% |  |
| 1145 | 6.6.2.1.2 | **Captações Subterrâneas - Serviços em Poços Tubulares (Captação Alternativa)** | 280d | 2018-06-11 A | 2019-07-17 A |  | 100% |  |
| 1146 |  | Realizar Perfilagem 1 (parcial) - Captação Alternativa - São Vítor/MG | 2d | 2018-06-11 A | 2018-06-12 A | 1144 | 100% |  |
| 1147 |  | Realizar Recuperação 1 (parcial) - Captação Alternativa - São Vítor/MG | 7d | 2018-06-13 A | 2018-06-21 A | 1146 | 100% |  |
| 1148 |  | Realizar Perfuração (reabertura de poço existente) - Captação Alternativa - São Vítor/MG | 2d | 2019-01-15 A | 2019-01-16 A | 1147FS+147d | 100% |  |
| 1149 |  | Realizar Recuperação - Captação Alternativa - São Vítor/MG | 2d | 2019-01-16 A | 2019-01-17 A | 1148SS+1d | 100% |  |
| 1150 |  | Realizar Perfilagem 2 - Captação Alternativa - São Vítor/MG | 1d | 2019-01-18 A | 2019-01-18 A | 1149 | 100% |  |
| 1151 |  | Elaborar Relatório Técnico - Captação Alternativa - São Vítor/MG | 23d | 2019-01-21 A | 2019-02-20 A | 1146, 1147, 1148, 1149, 1150 | 100% |  |
| 1152 |  | Realizar Instrumentação - Captação Alternativa - São Vítor/MG | 2d | 2019-07-16 A | 2019-07-17 A | 1151FS+96d | 100% |  |
| 1153 |  | Realizar Laudo de Serviços de Coleta, Análise de Água - Captação Alternativa - São Vítor/MG | 22d | 2019-01-18 A | 2019-02-18 A | 1149 | 100% |  |
| 1154 |  | Conclusão dos Serviços em poço tubular - Captação Alternativa - São Vítor/MG | 0d | 2019-02-18 A | 2019-02-18 A | 1153 | 100% |  |
| 1155 |  | Conclusão dos Estudos de Concepção das Melhorias do Sistema de Abastecimento de Água - São Vítor/MG | 0d | 2019-02-18 A | 2019-02-18 A | 1154 | 100% |  |
| 1156 | 6.6.2.2 | **Engenharia Básica e Detalhada** | 480d | 2018-01-10 A | 2019-11-26 |  | 99% | 671d |
| 1157 | 6.6.2.2.1 | **Engenharia Captação Alternativa (Poço São Vítor) - SE 32012** | 480d | 2018-01-10 A | 2019-11-26 |  | 99% | 671d |
| 1158 |  | Dados de Entrada (levantamento de campo, topografia, sondagem) - Captação Alternativa - Poço São Vítor - São Vítor/MG | 15d | 2018-01-10 A | 2018-01-30 A | 26 | 100% |  |
| 1159 |  | Elaborar arranjo para obtenção de Dados de Entrada Licenciamento e Fundiário - Captação Alternativa - Poço São Vítor - São Vítor/MG | 44d | 2018-01-31 A | 2018-04-02 A | 1158 | 100% |  |
| 1160 |  | Elaborar Projeto Executivo (Adequação da Infraestrutura do Poço) - Captação Alternativa - Poço São Vítor - São Vítor/MG | 152d | 2018-04-03 A | 2018-10-31 A | 1159 | 100% |  |
| 1161 |  | Elaboração do Projeto Executivo (Adequação da Infraestrutura do Poço) - Captação Alternativa - Poço São Vítor - São Vítor/MG | 0d | 2018-10-31 A | 2018-10-31 A | 1160 | 100% |  |
| 1162 |  | Elaborar e Aprovar Projeto Executivo para incluir o STA do poço - Captação Alternativa - Poço São Vítor - São Vítor/MG | 90d | 2019-07-22 A | 2019-11-26 | 1153FS+102d | 97% | 671d |
| 1163 |  | Elaboração do Projeto Executivo - Captação Alternativa - Poço São Vítor - São Vítor/MG | 0d | 2019-11-26 | 2019-11-26 | 1162, 1161 |  | 671d |
| 1164 | 6.6.2.3 | **Fundiária** | 143d | 2018-06-06 A | 2018-12-21 A |  | 100% |  |
| 1165 |  | Obter Termo de Autorização de Superficiário - ETA/Captação Alternativa - São Vítor/MG | 143d | 2018-06-06 A | 2018-12-21 A | 1144FS+53d | 100% |  |
| 1166 |  | Conclusão da Regularização Fundiária para as obras de Melhoria do Sistema de Abastecimento da Localidade - São Vítor/MG | 0d | 2018-12-21 A | 2018-12-21 A | 1165 | 100% |  |
| 1167 | 6.6.2.4 | **Licenciamento** | 176d | 2019-06-12 A | 2020-02-21 |  | 25% | 930d |
| 1168 |  | Obter Outorga/DAIA para Captação Alternativa (Poço São Vítor) - São Vítor/MG | 176d | 2019-06-12 A | 2020-02-21 | 1151FS+73d, 1159, 1165 | 25% | 930d |
| 1169 |  | Conclusão do Licenciamento Ambiental da Localidade - São Vítor/MG | 0d | 2020-02-21 | 2020-02-21 | 1168 |  | 930d |
| 1170 | 6.6.2.5 | **Infraestrutura** | 318d | 2019-11-27 | 2021-03-12 |  |  | 671d |
| 1171 | 6.6.2.5.1 | **Obras** | 70d | 2019-11-27 | 2020-03-12 |  |  | 671d |
| 1172 |  | Executar Captação Alternativa (Poço São Vítor) - Interligação do poço a ETA e STA - São Vítor/MG | 70d | 2019-11-27 | 2020-03-12 | 1152, 1160, 1163, 1165 |  | 671d |
| 1173 |  | Assinatura de Termo de Entrega das Obras de Melhoria do Sistema de Abastecimento de Água - São Vítor/MG | 0d | 2020-03-12 | 2020-03-12 | 1172, 1169 |  | 919d |
| 1174 | 6.6.2.5.2 | **Operação** | 248d | 2020-03-12 | 2021-03-12 |  |  | 671d |
| 1175 |  | Realizar Treinamento Operacional do Sistema - São Vítor/MG | 5d | 2020-03-13 | 2020-03-19 | 1172 |  | 900d |
| 1176 |  | Realizar Testes e Pré-operação - São Vítor/MG | 14d | 2020-03-20 | 2020-04-08 | 1175 |  | 900d |
| 1177 |  | Realizar Acompanhamento da Funcionalidade do Sistema - Captação Alternativa - São Vítor (distrito Governador Valadares/MG) | 365ed | 2020-03-12 | 2021-03-12 | 1179SS |  | 2955d |
| 1178 | 6.6.2.5.2.4 | **Operação Assistida** | 61d | 2020-03-12 | 2020-06-10 |  |  | 671d |
| 1179 |  | Realizar Operação Assistida - São Vítor/MG | 90ed | 2020-03-12 | 2020-06-10 | 1172 |  | 2955d |
| 1180 | 6.6.3 | **UTR** | 665d | 2019-12-03 | 2022-08-05 |  |  | 320d |
| 1181 | 6.6.3.1 | **Engenharia Básica e Detalhada** | 186d | 2019-12-03 | 2020-09-02 |  |  | 322d |
| 1182 | 6.6.3.1.1 | **Engenharia UTR** | 186d | 2019-12-03 | 2020-09-02 |  |  | 322d |
| 1183 |  | Aprovar Plano de Trabalho e Abrir SE - UTR - São Vítor/MG | 19d | 2019-12-03 | 2020-01-02 | 1144FS+432d |  | 322d |
| 1184 |  | Realizar Levantamento de Campo - UTR - São Vítor/MG | 10d | 2019-12-18 | 2020-01-03 | 1183FF+1d |  | 332d |
| 1185 |  | Realizar Sondagem - UTR - São Vítor/MG | 10d | 2019-12-18 | 2020-01-03 | 1183FF+1d |  | 322d |
| 1186 |  | Elaborar Projeto Básico - UTR - São Vítor/MG | 65d | 2020-01-20 | 2020-04-24 | 1185FS+10d, 1184 |  | 322d |
| 1187 |  | Aprovar Projeto Básico - UTR - São Vítor/MG | 22d | 2020-04-27 | 2020-05-27 | 1186 |  | 351d |
| 1188 |  | Emitir RT/PQ para Suprimentos - UTR - São Vítor/MG | 10d | 2020-04-27 | 2020-05-11 | 1186 |  | 322d |
| 1189 |  | Elaborar Projeto Executivo - UTR - São Vítor/MG | 69d | 2020-05-28 | 2020-09-02 | 1185, 1186, 1187, 1188FF |  | 351d |
| 1190 |  | Elaboração do Projeto Executivo - UTR - São Vítor/MG | 0d | 2020-09-02 | 2020-09-02 | 1189 |  | 351d |

| ID | WBS | Task | Duration | Start | Finish | Predecessors | Complete | Total float |
| --- | --- | --- | --- | --- | --- | --- | --- | --- |
| 1191 | 6.6.3.2 | **Licenciamento** | 199d | 2020-04-27 | 2021-02-09 |  |  | 563d |
| 1192 |  | Obter DAIA para UTR - São Vítor/MG | 199d | 2020-04-27 | 2021-02-09 | 1186 |  | 563d |
| 1193 |  | Conclusão do Licenciamento Ambiental da Localidade - São Vítor/MG | 0d | 2021-02-09 | 2021-02-09 | 1192 |  | 691d |
| 1194 | 6.6.3.3 | **Suprimentos** | 110d | 2020-05-12 | 2020-10-15 |  |  | 322d |
| 1195 | 6.6.3.3.1 | **Contratação MAS 2 (UTR's)** | 110d | 2020-05-12 | 2020-10-15 |  |  | 322d |
| 1196 |  | Analisar a RT/PQ emitida pela Engenharia (Infra) - UTR - São Vítor/MG | 22d | 2020-05-12 | 2020-06-10 | 1188 |  | 322d |
| 1197 |  | Abrir a RC - São Vítor/MG | 8d | 2020-06-12 | 2020-06-23 | 1196 |  | 322d |
| 1198 |  | Aprovar a RC (liberação) - São Vítor/MG | 8d | 2020-06-24 | 2020-07-03 | 1197 |  | 322d |
| 1199 |  | Prospectar fornecedores e receber proposta técnicas - São Vítor/MG | 30d | 2020-07-06 | 2020-08-14 | 1198 |  | 322d |
| 1200 |  | Aprovar proposta técnica - São Vítor/MG | 12d | 2020-08-17 | 2020-09-01 | 1199 |  | 322d |
| 1201 |  | Realizar negociação e aprovar o pedido - São Vítor/MG | 30d | 2020-09-02 | 2020-10-15 | 1200 |  | 322d |
| 1202 |  | Conclusão da Contratação de Suprimentos - São Vítor/MG | 0d | 2020-10-15 | 2020-10-15 | 1201 |  | 770d |
| 1203 |  | Conclusão da Contratação de Suprimentos das obras de Melhoria do Sistema de Abastecimento de Água - São Vítor/MG | 0d | 2020-10-15 | 2020-10-15 | 1202 |  | 770d |
| 1204 | 6.6.3.4 | **Infraestrutura** | 450d | 2020-10-16 | 2022-08-05 |  |  | 320d |
| 1205 | 6.6.3.4.1 | **Obras** | 200d | 2020-10-16 | 2021-08-05 |  |  | 322d |
| 1206 |  | Executar UTR - São Vítor/MG | 200d | 2020-10-16 | 2021-08-05 | 1189, 1201, 1192FF-120d, 1190 |  | 322d |
| 1207 |  | Assinatura de Termo de Entrega das Obras de Melhoria do Sistema de Abastecimento de Água - São Vítor/MG | 0d | 2021-08-05 | 2021-08-05 | 1206, 1193, 1203 |  | 570d |
| 1208 | 6.6.3.4.2 | **Operação** | 250d | 2021-08-05 | 2022-08-05 |  |  | 320d |
| 1209 |  | Realizar Treinamento Operacional do Sistema - São Vítor/MG | 5d | 2021-08-06 | 2021-08-12 | 1206 |  | 551d |
| 1210 |  | Realizar Testes e Pré-operação - São Vítor/MG | 14d | 2021-08-13 | 2021-09-01 | 1209 |  | 551d |
| 1211 |  | Realizar Acompanhamento da Funcionalidade do Sistema - UTR - São Vítor (distrito Governador Valadares/MG) | 365ed | 2021-08-05 | 2022-08-05 | 1213SS |  | 1422d |
| 1212 | 6.6.3.4.2.4 | **Operação Assistida** | 61d | 2021-08-05 | 2021-11-03 |  |  | 322d |
| 1213 |  | Realizar Operação Assistida - São Vítor/MG | 90ed | 2021-08-05 | 2021-11-03 | 1206 |  | 1422d |
| 1214 | 6.7 | **Galileia/MG (sede)** | 888d | 2017-06-01 A | 2020-11-28 |  | 60% | 740d |
| 1215 | 6.7.1 | **Captação Principal, Alternativa, Melhorias em ETA e UTR** | 888d | 2017-06-01 A | 2020-11-28 |  | 60% | 740d |
| 1216 | 6.7.1.1 | **Engenharia** | 534d | 2017-06-01 A | 2019-06-28 A |  | 100% |  |
| 1217 | 6.7.1.1.1 | **Estudos de Concepção do Sistema** | 366d | 2017-11-18 A | 2019-04-23 A |  | 100% |  |
| 1218 |  | Declaração de Escopo e Premissas de Projeto (DEPP) concluída - Galiléia/MG | 0d | 2017-11-18 A | 2017-11-18 A | 26 | 100% |  |
| 1219 |  | Aprovação das DEPPs pela Operadora e Prefeitura - Galiléia/MG | 0d | 2018-03-02 A | 2018-03-02 A | 26SS | 100% |  |
| 1220 | 6.7.1.1.1.3 | **Serviços em Poços Tubulares** | 228d | 2018-05-31 A | 2019-04-23 A |  | 100% |  |
| 1221 |  | Realizar Perfilagem (Poços 1, 2, 3 e 4) - Galiléia/MG | 11d | 2018-05-31 A | 2018-06-14 A | 1218FS+49d | 100% |  |
| 1222 |  | Realizar Recuperação (Poços 1, 2, 3 e 4) - Galiléia/MG | 22d | 2018-08-01 A | 2018-08-30 A | 1221FS+34d | 100% |  |
| 1223 |  | Realizar Instrumentação (Poços 1, 2, 3 e 4) - Galiléia/MG | 4d | 2018-12-17 A | 2018-12-20 A | 1222FS+76d | 100% |  |
| 1224 |  | Elaborar Relatório Técnico (Poços 1, 2, 3 e 4) - Galiléia/MG | 10d | 2019-01-08 A | 2019-01-21 A | 1221, 1222FS+92d | 100% |  |
| 1225 |  | Realizar Laudo dos Serviços de Coleta e Análise de Água - Galiléia/MG | 15d | 2018-10-17 A | 2018-11-06 A | 1222FS+35d | 100% |  |
| 1226 |  | Realizar Teste de Interferência entre poços - Galiléia/MG | 30d | 2019-03-11 A | 2019-04-23 A | 1222FS+190ed | 100% |  |
| 1227 |  | Conclusão dos Serviços em poço tubular - Galiléia/MG | 0d | 2019-04-23 A | 2019-04-23 A | 1226 | 100% |  |
| 1228 |  | Conclusão dos Estudos de Concepção das Melhorias do Sistema de Abastecimento de Água - Galileia/MG | 0d | 2019-04-23 A | 2019-04-23 A | 1219, 1227 | 100% |  |
| 1229 | 6.7.1.1.2 | **Engenharia Básica e Detalhada** | 534d | 2017-06-01 A | 2019-06-28 A |  | 100% |  |
| 1230 | 6.7.1.1.2.1 | **Engenharia Captação Principal (Captação, Adução e Elevatória)** | 284d | 2017-06-01 A | 2018-07-03 A |  | 100% |  |
| 1231 |  | Levantar Dados de Entrada (levantamento de campo, topografia e sondagem) - Captação Principal - Galiléia/MG | 16d | 2017-06-01 A | 2017-06-22 A | 26 | 100% |  |
| 1232 |  | Elaborar arranjo para obtenção de Dados de Entrada Licenciamento e Fundiário - Captação Principal - Galiléia/MG | 44d | 2017-07-03 A | 2017-08-31 A | 1231SS+22d | 100% |  |
| 1233 |  | Emitir RT/PQ para Suprimentos - Captação Principal - Galiléia/MG | 22d | 2017-08-09 A | 2017-09-07 A | 1232SS+27d | 100% |  |
| 1234 |  | Elaborar Projeto Executivo - Captação Principal - Galiléia/MG | 218d | 2017-09-01 A | 2018-07-03 A | 1232 | 100% |  |
| 1235 |  | Elaboração do Projeto Executivo - Captação Principal - Galiléia/MG | 0d | 2018-07-03 A | 2018-07-03 A | 1234 | 100% |  |
| 1236 | 6.7.1.1.2.2 | **Engenharia Captação Alternativa (Poços 1, 2, 3 e 4)** | 240d | 2018-01-10 A | 2018-12-11 A |  | 100% |  |
| 1237 |  | Aprovar Plano de Trabalho e abrir OSE - Captação Alternativa - Poços 1, 2, 3 e 4 - Galiléia/MG | 16d | 2018-01-10 A | 2018-01-31 A | 26 | 100% |  |
| 1238 |  | Levantar Dados de Entrada (levantamento de campo, topografia e sondagem) - Captação Alternativa - Poços 1, 2, 3 e 4 - Galiléia/MG | 16d | 2018-01-10 A | 2018-01-31 A | 26, 1237SS | 100% |  |
| 1239 |  | Elaborar Projeto Executivo - Captação Alternativa - Poços 1, 2, 3 e 4 - Galiléia/MG | 224d | 2018-02-01 A | 2018-12-11 A | 1224, 1227, 1238 | 100% |  |
| 1240 |  | Elaboração do Projeto Executivo - Captação Alternativa - Poços 1, 2, 3 e 4 - Galiléia/MG | 0d | 2018-12-11 A | 2018-12-11 A | 1239 | 100% |  |
| 1241 | 6.7.1.1.2.3 | **Engenharia Melhorias ETA** | 132d | 2018-11-19 A | 2019-05-30 A |  | 100% |  |
| 1242 |  | Aprovar Plano de Trabalho e abrir OSE - Melhorias na ETA - Galiléia/MG | 22d | 2018-11-19 A | 2018-12-18 A | 1218 | 100% |  |
| 1243 |  | Dados de Entrada (levantamento de campo, topografia e informações da Caixa de Coleta) - Melhorias na ETA - Galiléia/MG | 57d | 2018-11-26 A | 2019-02-13 A | 1242SS+5d | 100% |  |
| 1244 |  | Elaborar Projeto Executivo - Melhorias na ETA - Galiléia/MG | 70d | 2019-02-14 A | 2019-05-30 A | 1225, 1243 | 100% |  |
| 1245 |  | Elaboração do Projeto Executivo - Melhorias na ETA - Galiléia/MG | 0d | 2019-05-30 A | 2019-05-30 A | 1244 | 100% |  |
| 1246 | 6.7.1.1.2.4 | **Engenharia nova ETA e UTR** | 287d | 2017-11-03 A | 2018-12-10 A |  | 100% |  |
| 1247 |  | Elaborar arranjo para obtenção de Dados de Entrada Licenciamento e Fundiário - Nova ETA/UTR - Galiléia/MG | 44d | 2017-11-03 A | 2018-01-03 A | 26 | 100% |  |
| 1248 |  | Elaborar Projeto Executivo - Nova ETA/UTR - Galiléia/MG | 277d | 2017-11-17 A | 2018-12-10 A | 1247SS+10d | 100% |  |
| 1249 |  | Elaboração do Projeto Executivo - Nova ETA/UTR - Galiléia/MG | 0d | 2018-12-10 A | 2018-12-10 A | 1248 | 100% |  |
| 1250 | 6.7.1.1.2.5 | **Validação dos Projetos** | 20d | 2019-05-31 A | 2019-06-28 A |  | 100% |  |
| 1251 |  | Validar Projetos com Prefeitura e Operadora - Galiléia/MG | 20d | 2019-05-31 A | 2019-06-28 A | 1234, 1239, 1244, 1248 | 100% |  |
| 1252 |  | Validação com Prefeitura e Operadora dos Projetos de Melhoria do Sistema de Abastecimento de Água - Galiléia/MG | 0d | 2019-06-28 A | 2019-06-28 A | 1235, 1240, 1245, 1249, 1251 | 100% |  |
| 1253 |  | Conclusão e Validação da Engenharia - Galileia/MG | 0d | 2019-06-28 A | 2019-06-28 A | 1228, 1252 | 100% |  |
| 1254 | 6.7.1.2 | **Licenciamento** | 519d | 2017-09-18 A | 2019-09-25 A |  | 100% |  |
| 1255 |  | Nova ETA Galiléia (DAIA / LAS Cadastro) - Captação Principal - Galiléia/MG | 0d | 2018-07-13 A | 2018-07-13 A | 1218FS+82d | 100% |  |
| 1256 |  | Obter Outorga para Captação Alternativa (Poços 3 e 4) - Galiléia/MG | 224d | 2017-09-18 A | 2018-07-26 A | 26FS-45d | 100% |  |
| 1257 |  | Obter Outorga para Captação Alternativa (Poços 1 e 2) - Galiléia/MG | 279d | 2017-11-20 A | 2018-12-13 A | 26, 1226FF | 100% |  |
| 1258 |  | Obtenção de Outorgas para Captação Alternativa - Galiléia/MG | 0d | 2018-12-13 A | 2018-12-13 A | 1255, 1256, 1257 | 100% |  |
| 1259 |  | Indeferimento das Outorgas para Captação Alternativa (Poço 1 e 2) - Galiléia/MG | 0d | 2019-07-23 A | 2019-07-23 A | 1258FS+150d | 100% |  |
| 1260 |  | Reabrir processo de Outorga para Captação Alternativa (Poços 1 e 2) - Galiléia/MG | 30d | 2019-08-14 A | 2019-09-25 A | 1259FS+15d | 100% |  |

| ID | WBS | Task | Duration | Start | Finish | Predecessors | Complete | Total float | Constraint |
| --- | --- | --- | --- | --- | --- | --- | --- | --- | --- |
| 1261 |  | Conclusão do Licenciamento Ambiental para as Melhorias no Sistema de Abastecimento - Galiléia/MG | 0d | 2019-09-25 A | 2019-09-25 A | 1260 | 100% |  |  |
| 1262 | 6.7.1.3 | **Suprimentos** | 195d | 2018-09-04 A | 2019-06-12 A |  | 100% |  |  |
| 1263 | 6.7.1.3.1 | **Melhorias na ETA (contrato guarda-chuva existente - Infraestrutura)** | 8d | 2019-06-03 A | 2019-06-12 A |  | 100% |  |  |
| 1264 |  | Incluir PQ no CGC existente - Galiléia/MG | 8d | 2019-06-03 A | 2019-06-12 A | 1244FS+1d, 1251SS+1d | 100% |  |  |
| 1265 |  | Conclusão da Contratação de Suprimentos - Galileia/MG | 0d | 2019-06-12 A | 2019-06-12 A | 1264 | 100% |  |  |
| 1266 |  | Processo contratação MAS 1 (Contratação Eletromecânica) - Galiléia/MG | 165d | 2018-09-04 A | 2019-04-30 A | 1233FS+257d | 100% |  |  |
| 1267 |  | Conclusão da Contratação de Suprimentos das obras de Melhoria do Sistema de Abastecimento de Água - Galileia/MG | 0d | 2019-06-12 A | 2019-06-12 A | 1265, 1266 | 100% |  |  |
| 1268 | 6.7.1.4 | **Infraestrutura** | 681d | 2018-03-19 A | 2020-11-28 |  | 15% | 740d |  |
| 1269 | 6.7.1.4.1 | **Obras** | 435d | 2018-03-19 A | 2019-11-29 |  | 93% | 986d |  |
| 1270 | 6.7.1.4.1.1 | **Nova ETA/UTR/Melhorias na ETA e na Captação Principal** | 392d | 2018-03-19 A | 2019-09-30 A |  | 100% |  |  |
| 1271 |  | Executar Melhorias de ETA - Adutora e Reservatório - Galiléia/MG | 158d | 2018-03-19 A | 2018-10-24 A | 1244, 1265 | 100% |  |  |
| 1272 |  | Executar Captação Principal, Adução, Nova ETA / UTR, Elevatória - Galiléia/MG | 61d | 2019-07-05 A | 2019-09-30 A | 1234, 1248, 1255, 1265FS+15d, 1266 | 100% |  |  |
| 1273 |  | Conclusão das Obras de Melhorias de ETA - Captação Principal, Adução, Nova ETA / UTR, Elevatória - Galiléia/MG | 0d | 2019-09-30 A | 2019-09-30 A | 1272 | 100% |  |  |
| 1274 | 6.7.1.4.1.2 | **Captação Alternativa** | 15d | 2019-09-10 A | 2019-09-30 A |  | 100% |  |  |
| 1275 |  | Executar Captação Alternativa (Interligação dos poços 1, 2, 3 e 4) - Galiléia/MG | 15d | 2019-09-10 A | 2019-09-30 A | 1223, 1239, 1256, 1257, 1272FF | 100% |  |  |
| 1276 |  | Conclusão das obras de Captação Alternativa - Poços 01, 02, 03 e 04 - Galiléia/MG | 0d | 2019-09-30 A | 2019-09-30 A | 1275 | 100% |  |  |
| 1277 |  | Realizar ajustes no escopo do projeto para atender solicitações do MP - Galiléia/MG | 43d | 2019-10-01 A | 2019-11-29 | 1273, 1276 | 53% | 738d |  |
| 1278 |  | Assinatura de Termo de Entrega das Obras de Melhoria do Sistema de Abastecimento de Água - Galiléia/MG | 0d | 2019-11-29 | 2019-11-29 | 1272, 1275, 1271, 1261, 1277 |  | 986d |  |
| 1279 | 6.7.1.4.2 | **Operação** | 246d | 2019-11-29 | 2020-11-28 |  |  | 738d |  |
| 1280 |  | Realizar Treinamento Operacional do Sistema - Galiléia/MG | 5d | 2019-12-02 | 2019-12-06 | 1272, 1275, 1271, 1277 |  | 967d |  |
| 1281 |  | Realizar Testes e Pré-operação - Galiléia/MG | 14d | 2019-12-09 | 2019-12-31 | 1280 |  | 967d |  |
| 1282 |  | Realizar Acompanhamento da Funcionalidade do Sistema - Captação Principal, Alternativa, Melhorias em ETA e UTR - Galileia/MG (sede) | 365ed | 2019-11-29 | 2020-11-28 | 1284SS |  | 3267d |  |
| 1283 | 6.7.1.4.2.4 | **Operação Assistida** | 57d | 2019-11-29 | 2020-02-27 |  |  | 738d |  |
| 1284 |  | Realizar Operação Assistida - Galiléia/MG | 90ed | 2019-11-29 | 2020-02-27 | 1272, 1275, 1271, 1277 |  | 3267d |  |
| 1285 | 6.8 | **Tumiritinga/MG (sede)** | 1243d | 2018-01-31 A | 2023-01-14 |  | 8% | 211d |  |
| 1286 | 6.8.1 | **Captação Principal e Melhorias em ETA** | 1127d | 2018-03-23 A | 2022-09-20 |  | 18% | 290d |  |
| 1287 | 6.8.1.1 | **Estudos de Concepção do Sistema** | 0d | 2018-03-23 A | 2018-03-23 A |  | 100% |  |  |
| 1288 |  | Declaração de Escopo e Premissas de Projeto (DEPP) concluída - Tumiritinga/MG | 0d | 2018-03-23 A | 2018-03-23 A | 25, 26 | 100% |  |  |
| 1289 |  | Aprovação das DEPPs pela Operadora e Prefeitura - Tumiritinga/MG | 0d | 2018-03-23 A | 2018-03-23 A | 1288 | 100% |  |  |
| 1290 | 6.8.1.2 | **Engenharia Básica e Detalhada** | 175d | 2018-10-29 A | 2019-07-10 A |  | 100% |  |  |
| 1291 | 6.8.1.2.1 | **Engenharia Captação Principal - SE 32248** | 175d | 2018-10-29 A | 2019-07-10 A |  | 100% |  |  |
| 1292 |  | Aprovação Plano de Trabalho /abertura OSE - Captação Principal - Tumiritinga/MG | 23d | 2018-10-29 A | 2018-11-28 A | 1288 | 100% |  |  |
| 1293 |  | Realizar Levantamento de Campo - Captação Principal - Tumiritinga/MG | 1d | 2019-01-22 A | 2019-01-22 A | 1292SS | 100% |  |  |
| 1294 |  | Executar Topografia - Captação Principal - Tumiritinga/MG | 55d | 2018-10-29 A | 2019-01-14 A | 1292 | 100% |  |  |
| 1295 |  | Emitir RT/PQ para Suprimentos - Captação Principal - Tumiritinga/MG | 10d | 2019-06-27 A | 2019-07-10 A | 1296FF | 100% |  |  |
| 1296 |  | Elaborar Projeto Executivo - Captação Principal - Tumiritinga/MG | 87d | 2019-03-01 A | 2019-07-10 A | 1293, 1294 | 100% |  |  |
| 1297 |  | Elaboração do Projeto Executivo - Captação Principal - Tumiritinga/MG | 0d | 2019-07-10 A | 2019-07-10 A | 1296 | 100% |  |  |
| 1298 | 6.8.1.2.2 | **Engenharia Melhorias na ETA - SE 32248** | 175d | 2018-10-29 A | 2019-07-10 A |  | 100% |  |  |
| 1299 |  | Aprovar Plano de Trabalho e abrir OSE - Melhorias na ETA - Tumiritinga/MG | 23d | 2018-10-29 A | 2018-11-28 A | 1288 | 100% |  |  |
| 1300 |  | Realizar Levantamento de Campo - Melhorias na ETA - Tumiritinga/MG | 1d | 2019-01-22 A | 2019-01-22 A | 1299 | 100% |  |  |
| 1301 |  | Executar Topografia - Melhorias na ETA - Tumiritinga/MG | 55d | 2018-10-29 A | 2019-01-14 A | 1299 | 100% |  |  |
| 1302 |  | Emitir RT/PQ para Suprimentos - Melhorias na ETA - Tumiritinga/MG | 10d | 2019-06-26 A | 2019-07-10 A | 1303FF | 100% |  |  |
| 1303 |  | Elaborar Projeto Executivo - Melhorias na ETA - Tumiritinga/MG | 87d | 2019-03-01 A | 2019-07-10 A | 1300, 1301 | 100% |  |  |
| 1304 |  | Elaboração do Projeto Executivo - Melhorias na ETA - Tumiritinga/MG | 0d | 2019-07-10 A | 2019-07-10 A | 1303 | 100% |  |  |
| 1305 | 6.8.1.3 | **Infraestrutura** | 369d | 2021-03-31 | 2022-09-20 |  |  | 290d |  |
| 1306 | 6.8.1.3.1 | **Obras** | 120d | 2021-03-31 | 2021-09-20 |  |  | 291d |  |
| 1307 |  | Captação Principal e Melhorias na ETA (contrato guarda-chuva existente - Infraestrutura) - Tumiritinga/MG | 0d | 2021-03-31 | 2021-03-31 | 1295, 1296, 1302, 1303 |  | 291d | start no earlier than 2021-03-31 |
| 1308 |  | Executar obras de Melhorias na Captação Principal - Tumiritinga/MG | 120d | 2021-03-31 | 2021-09-20 | 1296, 1307, 1309SS |  | 291d |  |
| 1309 |  | Executar Melhorias na ETA - Tumiritinga/MG | 120d | 2021-03-31 | 2021-09-20 | 1303, 1307 |  | 291d |  |
| 1310 |  | Assinatura de Termo de Entrega das Obras de Melhoria do Sistema de Abastecimento de Água - Tumiritinga - Tumiritinga/MG | 0d | 2021-09-20 | 2021-09-20 | 1308, 1309 |  | 539d |  |
| 1311 | 6.8.1.3.2 | **Operação** | 249d | 2021-09-20 | 2022-09-20 |  |  | 290d |  |
| 1312 |  | Realizar Treinamento Operacional do Sistema - Tumiritinga/MG | 5d | 2021-09-21 | 2021-09-27 | 1308, 1309 |  | 520d |  |
| 1313 |  | Realizar Testes e Pré-operação - Tumiritinga/MG | 14d | 2021-09-28 | 2021-10-18 | 1312 |  | 520d |  |
| 1314 |  | Realizar Acompanhamento da Funcionalidade do Sistema - Captação Principal e Melhorias em ETA - Tumiritinga/MG (sede) | 365ed | 2021-09-20 | 2022-09-20 | 1316SS |  | 1284d |  |
| 1315 | 6.8.1.3.2.4 | **Operação Assistida** | 61d | 2021-09-20 | 2021-12-19 |  |  | 291d |  |
| 1316 |  | Realizar Operação Assistida - Tumiritinga/MG | 90ed | 2021-09-20 | 2021-12-19 | 1308, 1309 |  | 1284d |  |
| 1317 | 6.8.2 | **Captação Alternativa** | 1109d | 2018-01-31 A | 2022-07-01 |  | 5% | 345d |  |
| 1318 | 6.8.2.1 | **Estudos de Concepção do Sistema** | 317d | 2018-03-14 A | 2019-06-10 A |  | 100% |  |  |
| 1319 |  | Declaração de Escopo e Premissas de Projeto (DEPP) concluída - Tumiritinga/MG | 0d | 2018-03-23 A | 2018-03-23 A | 25, 26 | 100% |  |  |
| 1320 |  | Aprovação das DEPPs pela Operadora e Prefeitura - Tumiritinga/MG | 0d | 2018-03-14 A | 2018-03-14 A | 25, 26 | 100% |  |  |
| 1321 | 6.8.2.1.3 | **Captações Subterrâneas - Serviços em Poços Tubulares (Poço 4)** | 228d | 2018-07-17 A | 2019-06-10 A |  | 100% |  |  |
| 1322 |  | Realizar Perfilagem - Captação Alternativa - Poço 4 - Tumiritinga/MG | 2d | 2018-07-17 A | 2018-07-18 A | 1319 | 100% |  |  |
| 1323 |  | Realizar Recuperação - Captação Alternativa - Poço 4 - Tumiritinga/MG | 3d | 2018-09-28 A | 2018-10-02 A | 1322FS+51d | 100% |  |  |
| 1324 |  | Elaborar Relatório Técnico - Captação Alternativa - Poço 4 - Tumiritinga/MG | 47d | 2018-10-03 A | 2018-12-06 A | 1322, 1323 | 100% |  |  |
| 1325 |  | Realizar Instrumentação - Captação Alternativa - Poço 4 - Tumiritinga/MG | 3d | 2019-04-26 A | 2019-04-30 A | 1324FS+94d | 100% |  |  |
| 1326 |  | Realizar Laudo de Serviços de Coleta e Análise de Água - Captação Alternativa - Poço 4 - Tumiritinga/MG | 26d | 2019-05-06 A | 2019-06-10 A | 1323FS+215ed | 100% |  |  |
| 1327 |  | Conclusão dos Serviços em poço tubular - Captação Alternativa - Poço 4 - Tumiritinga/MG | 0d | 2019-06-10 A | 2019-06-10 A | 1326 | 100% |  |  |
| 1328 |  | Conclusão dos Estudos de Concepção das Melhorias do Sistema de Abastecimento de Água - Tumiritinga/MG | 0d | 2019-06-10 A | 2019-06-10 A | 1327 | 100% |  |  |
| 1329 | 6.8.2.2 | **Engenharia Básica e Detalhada** | 372d | 2019-02-27 A | 2020-08-27 |  | 12% | 803d |  |
| 1330 | 6.8.2.2.1 | **Engenharia Captação Alternativa (Poço 4) - SE 32154** | 372d | 2019-02-27 A | 2020-08-27 |  | 12% | 803d |  |

| ID | WBS | Task | Duration | Start | Finish | Predecessors | Complete | Total float |
| --- | --- | --- | --- | --- | --- | --- | --- | --- |
| 1331 |  | Aprovar Plano de Trabalho - Captação Alternativa - Poço 4 - Tumiritinga/MG | 10d | 2019-02-27 A | 2019-03-15 A | 1319, 1326FS-63d | 100% |  |
| 1332 |  | Realizar Levantamento de Campo - Captação Alternativa - Poço 4 - Tumiritinga/MG | 1d | 2019-07-23 A | 2019-07-23 A | 1326FS+29d, 1331FS+52d | 100% |  |
| 1333 |  | Realizar Sondagem - Captação Alternativa - Poço 4 - Tumiritinga/MG | 12d | 2019-10-25 A | 2019-11-11 | 1332FS+66d | 25% | 347d |
| 1334 |  | Realizar levantamento topográfico complementar (interferência de PVs e undergrounds) - Captação Alternativa - Poço 4 - Tumiritinga/MG | 12d | 2019-07-24 A | 2019-08-08 A | 1332 | 100% |  |
| 1335 |  | Elaborar arranjo conceitual para obtenção de Dados de Entrada Licenciamento e Fundiário - Captação Alternativa - Poço 4 - Tumiritinga/MG | 38d | 2020-02-06 | 2020-04-02 | 1333FS+57d |  | 347d |
| 1336 |  | Elaborar Projeto Básico - Captação Alternativa - Poço 4 - Tumiritinga/MG | 50d | 2020-02-06 | 2020-04-22 | 1335SS |  | 347d |
| 1337 |  | Aprovar Projeto Básico - Captação Alternativa - Poço 4 - Tumiritinga/MG | 22d | 2020-04-23 | 2020-05-25 | 1336 |  | 347d |
| 1338 |  | Emitir RT/PQ para Suprimentos - Captação Alternativa - Poço 4 - Tumiritinga/MG | 10d | 2020-08-14 | 2020-08-27 | 1339FF |  | 347d |
| 1339 |  | Elaborar Projeto Executivo - Captação Alternativa - Poço 4 - Tumiritinga/MG | 67d | 2020-05-26 | 2020-08-27 | 1324, 1333FF, 1334, 1335, 1336, 1337 |  | 347d |
| 1340 |  | Elaboração do Projeto Executivo - Captação Alternativa - Poço 4 - Tumiritinga/MG | 0d | 2020-08-27 | 2020-08-27 | 1339 |  | 803d |
| 1341 | 6.8.2.3 | **Fundiária** | 616d | 2018-01-31 A | 2020-07-09 |  | 2% | 838d |
| 1342 |  | Obter Termos de Autorização de Superficiário - Captação Alternativa - Poço 4 - Tumiritinga/MG | 1d | 2018-01-31 A | 2018-01-31 A | 26FS+52d | 100% |  |
| 1343 |  | Obter Termos de Autorização de Superficiário - Captação Alternativa - Adutora (ligando água do Poço 4 à ETA) - Tumiritinga/MG | 5d | 2020-04-03 | 2020-04-09 | 1335 |  | 470d |
| 1344 |  | Captação Alternativa - Adutora (ligando água do Poço 4 à ETA) - Desimpedimento da Área e Negociação de Servidão - Tumiritinga/MG | 44d | 2020-05-08 | 2020-07-09 | 1343SS+22d |  | 470d |
| 1345 |  | Conclusão da Regularização Fundiária para as obras de Melhoria do Sistema de Abastecimento da Localidade - Tumiritinga/MG | 0d | 2020-07-09 | 2020-07-09 | 1342, 1343, 1344 |  | 838d |
| 1346 | 6.8.2.4 | **Licenciamento** | 176d | 2020-04-13 | 2020-12-22 |  |  | 475d |
| 1347 |  | Obter Outorga para Captação Alternativa (Poço 4) - Tumiritinga/MG | 176d | 2020-04-13 | 2020-12-22 | 1324, 1335, 1342, 1343 |  | 475d |
| 1348 |  | Conclusão do Licenciamento Ambiental da Localidade - Tumiritinga/MG | 0d | 2020-12-22 | 2020-12-22 | 1347 |  | 723d |
| 1349 | 6.8.2.5 | **Suprimentos** | 88d | 2020-08-28 | 2021-01-06 |  |  | 347d |
| 1350 |  | Contratação MAS 1 (STA Poços Tubulares) - Tumiritinga/MG | 88d | 2020-08-28 | 2021-01-06 | 1338 |  | 347d |
| 1351 |  | Conclusão da Contratação de Suprimentos das obras de Melhoria do Sistema de Abastecimento de Água - Tumiritinga/MG | 0d | 2021-01-06 | 2021-01-06 | 1350 |  | 715d |
| 1352 | 6.8.2.6 | **Infraestrutura** | 370d | 2021-01-07 | 2022-07-01 |  |  | 345d |
| 1353 | 6.8.2.6.1 | **Obras** | 120d | 2021-01-07 | 2021-07-01 |  |  | 347d |
| 1354 |  | Executar Captação Alternativa (Interligação do Poço 4) - Tumiritinga/MG | 120d | 2021-01-07 | 2021-07-01 | 1325, 1339, 1342, 1343, 1344, 1347FF, 1350 |  | 347d |
| 1355 |  | Assinatura de Termo de Entrega das Obras de Melhoria do Sistema de Abastecimento de Água - Tumiritinga - Tumiritinga/MG | 0d | 2021-07-01 | 2021-07-01 | 1354, 1340, 1345, 1348, 1351 |  | 595d |
| 1356 | 6.8.2.6.2 | **Operação** | 250d | 2021-07-01 | 2022-07-01 |  |  | 345d |
| 1357 |  | Realizar Treinamento Operacional do Sistema - Tumiritinga/MG | 5d | 2021-07-02 | 2021-07-08 | 1354 |  | 576d |
| 1358 |  | Realizar Testes e Pré-operação - Tumiritinga/MG | 14d | 2021-07-09 | 2021-07-28 | 1357 |  | 576d |
| 1359 |  | Realizar Acompanhamento da Funcionalidade do Sistema - Captação Alternativa - Tumiritinga/MG (sede) | 365ed | 2021-07-01 | 2022-07-01 | 1361SS |  | 1527d |
| 1360 | 6.8.2.6.2.4 | **Operação Assistida** | 63d | 2021-07-01 | 2021-09-29 |  |  | 346d |
| 1361 |  | Realizar Operação Assistida - Tumiritinga/MG | 90ed | 2021-07-01 | 2021-09-29 | 1354 |  | 1527d |
| 1362 | 6.8.3 | **UTR** | 679d | 2020-04-27 | 2023-01-14 |  |  | 211d |
| 1363 | 6.8.3.1 | **Engenharia Básica e Detalhada** | 212d | 2020-04-27 | 2021-03-03 |  |  | 211d |
| 1364 | 6.8.3.1.1 | **Engenharia UTR** | 212d | 2020-04-27 | 2021-03-03 |  |  | 211d |
| 1365 |  | Elaborar arranjo para obtenção de Dados de Entrada Licenciamento e Fundiário - UTR - Tumiritinga/MG | 38d | 2020-04-27 | 2020-06-19 | 1319FS+527d |  | 211d |
| 1366 |  | Elaborar Projeto Básico - UTR - Tumiritinga/MG | 65d | 2020-08-03 | 2020-11-04 | 1365FS+30d |  | 211d |
| 1367 |  | Aprovar Projeto Básico - UTR - Tumiritinga/MG | 22d | 2020-11-05 | 2020-12-04 | 1366 |  | 230d |
| 1368 |  | Emitir RT/PQ para Suprimentos - UTR - Tumiritinga/MG | 10d | 2020-11-05 | 2020-11-18 | 1366 |  | 211d |
| 1369 |  | Elaborar Projeto Executivo - UTR - Tumiritinga/MG | 57d | 2020-12-07 | 2021-03-03 | 1365, 1366, 1367 |  | 230d |
| 1370 |  | Elaboração do Projeto Executivo - UTR - Tumiritinga/MG | 0d | 2021-03-03 | 2021-03-03 | 1369 |  | 230d |
| 1371 | 6.8.3.2 | **Suprimentos** | 88d | 2020-11-19 | 2021-03-30 |  |  | 211d |
| 1372 |  | Contratação MAS 2 (UTR's) - Tumiritinga/MG | 88d | 2020-11-19 | 2021-03-30 | 1368 |  | 211d |
| 1373 |  | Conclusão da Contratação de Suprimentos das obras de Melhoria do Sistema de Abastecimento de Água - Tumiritinga/MG | 0d | 2021-03-30 | 2021-03-30 | 1372 |  | 659d |
| 1374 | 6.8.3.3 | **Infraestrutura** | 448d | 2021-03-31 | 2023-01-14 |  |  | 211d |
| 1375 | 6.8.3.3.1 | **Obras** | 200d | 2021-03-31 | 2022-01-14 |  |  | 211d |
| 1376 |  | Executar UTR - Tumiritinga/MG | 200d | 2021-03-31 | 2022-01-14 | 1369, 1372, 1370 |  | 211d |
| 1377 |  | Assinatura de Termo de Entrega das Obras de Melhoria do Sistema de Abastecimento de Água - Tumiritinga - Tumiritinga/MG | 0d | 2022-01-14 | 2022-01-14 | 1376, 1373 |  | 459d |
| 1378 | 6.8.3.3.2 | **Operação** | 248d | 2022-01-14 | 2023-01-14 |  |  | 211d |
| 1379 |  | Realizar Treinamento Operacional do Sistema - Tumiritinga/MG | 5d | 2022-01-17 | 2022-01-21 | 1376 |  | 440d |
| 1380 |  | Realizar Testes e Pré-operação - Tumiritinga/MG | 14d | 2022-01-24 | 2022-02-10 | 1379 |  | 440d |
| 1381 |  | Realizar Acompanhamento da Funcionalidade do Sistema - UTR - Tumiritinga/MG (sede) | 365ed | 2022-01-14 | 2023-01-14 | 1383SS |  | 936d |
| 1382 | 6.8.3.3.2.4 | **Operação Assistida** | 61d | 2022-01-14 | 2022-04-14 |  |  | 211d |
| 1383 |  | Realizar Operação Assistida - Tumiritinga/MG | 90ed | 2022-01-14 | 2022-04-14 | 1376 |  | 936d |
| 1384 | 6.9 | **São Tomé do Rio Doce (distrito Tumiritinga/MG)** | 1156d | 2017-12-12 A | 2022-07-19 |  | 39% | 333d |
| 1385 | 6.9.1 | **Captação Principal / Nova ETA / UTR** | 1156d | 2017-12-12 A | 2022-07-19 |  | 22% | 333d |
| 1386 | 6.9.1.1 | **Estudos de Concepção do Sistema** | 72d | 2017-12-12 A | 2018-03-23 A |  | 100% |  |
| 1387 |  | Declaração de Escopo e Premissas de Projeto (DEPP) concluída - São Tomé do Rio Doce/MG | 0d | 2018-03-23 A | 2018-03-23 A | 25, 26 | 100% |  |
| 1388 |  | Aprovação das DEPPs pela Operadora e Prefeitura - São Tomé do Rio Doce/MG | 0d | 2017-12-12 A | 2017-12-12 A | 25, 26FS+17d | 100% |  |
| 1389 | 6.9.1.2 | **Engenharia Básica e Detalhada** | 376d | 2018-10-29 A | 2020-05-04 |  | 38% | 885d |
| 1390 | 6.9.1.2.1 | **Engenharia Captação Principal / Nova ETA / UTR - SE 32156** | 376d | 2018-10-29 A | 2020-05-04 |  | 38% | 885d |
| 1391 |  | Aprovar plano de Trabalho - Captação Principal / Nova ETA / UTR - São Tomé do Rio Doce/MG | 8d | 2019-03-11 A | 2019-03-20 A | 1387FS+353ed | 100% |  |
| 1392 |  | Realizar Levantamento de Campo - Captação Principal / Nova ETA / UTR - São Tomé do Rio Doce/MG | 4d | 2019-05-24 A | 2019-05-31 A | 1387, 1391FF+52d | 100% |  |
| 1393 |  | Realizar Sondagem - Captação Principal / Nova ETA / UTR - São Tomé do Rio Doce/MG | 21d | 2019-11-26 | 2019-12-27 | 1391, 1404FS-30d |  | 345d |
| 1394 |  | Executar Topografia - Captação Principal / Nova ETA / UTR - São Tomé do Rio Doce/MG | 55d | 2018-10-29 A | 2019-01-14 A | 1387 | 100% |  |
| 1395 |  | Elaborar arranjo para obtenção de Dados de Entrada Licenciamento e Fundiário - Captação Principal / Nova ETA / UTR - São Tomé do Rio Doce/MG | 21d | 2019-07-12 A | 2019-08-09 A | 1392, 1394 | 100% |  |
| 1396 |  | Elaborar Projeto Básico - Captação Principal / Nova ETA / UTR - São Tomé do Rio Doce/MG | 55d | 2019-10-22 A | 2020-01-13 | 1393FF, 1395 | 11% | 335d |
| 1397 |  | Aprovar Projeto Básico - Captação Principal / Nova ETA / UTR - São Tomé do Rio Doce/MG | 22d | 2020-01-14 | 2020-02-12 | 1396 |  | 349d |
| 1398 |  | Emitir RT/PQ para Suprimentos - Captação Principal / Nova ETA / UTR - São Tomé do Rio Doce/MG | 12d | 2020-04-15 | 2020-05-04 | 1396, 1399FF |  | 349d |
| 1399 |  | Elaborar Projeto Executivo - Captação Principal / Nova ETA / UTR - São Tomé do Rio Doce/MG | 52d | 2020-02-13 | 2020-05-04 | 1393FF, 1395, 1396, 1397 |  | 349d |
| 1400 |  | Elaboração do Projeto Executivo - Captação Principal / Nova ETA / UTR - São Tomé do Rio Doce/MG | 0d | 2020-05-04 | 2020-05-04 | 1399 |  | 885d |

| ID | WBS | Task | Duration | Start | Finish | Predecessors | Complete | Total float |
| --- | --- | --- | --- | --- | --- | --- | --- | --- |
| 1401 | 6.9.1.3 | **Fundiária** | 291d | 2018-11-12 A | 2020-01-10 |  | 61% | 345d |
| 1402 |  | Captação Principal - Adutora rio Doce - Desimpedimento de área - São Tomé do Rio Doce/MG | 291d | 2018-11-12 A | 2020-01-10 | 1387FS+166d | 61% | 345d |
| 1403 |  | Nova ETA / UTR - Desimpedimento de área - São Tomé do Rio Doce/MG | 291d | 2018-11-12 A | 2020-01-10 | 1387FS+166d | 61% | 345d |
| 1404 |  | Conclusão da Regularização Fundiária para as obras de Melhoria do Sistema de Abastecimento da Localidade - São Tomé do Rio Doce/MG | 0d | 2020-01-10 | 2020-01-10 | 1402, 1403 |  | 345d |
| 1405 | 6.9.1.4 | **Licenciamento** | 444d | 2018-12-14 A | 2020-09-25 |  | 46% | 783d |
| 1406 |  | Outorga/DAIA para Captação Principal (rio Doce) - São Tomé do Rio Doce/MG | 176d | 2020-01-14 | 2020-09-25 | 1395, 1396 |  | 335d |
| 1407 |  | Obter DAIA Nova ETA - São Tomé do Rio Doce/MG | 240d | 2018-12-14 A | 2019-11-28 |  | 80% | 539d |
| 1408 |  | Conclusão do Licenciamento Ambiental da Localidade - São Tomé do Rio Doce/MG | 0d | 2020-09-25 | 2020-09-25 | 1406, 1407 |  | 783d |
| 1409 | 6.9.1.5 | **Suprimentos** | 88d | 2020-05-05 | 2020-09-04 |  |  | 349d |
| 1410 |  | Contratação MAS 1 (Captação Principal e Construções novas ETA's/UTR's) - São Tomé do Rio Doce/MG | 88d | 2020-05-05 | 2020-09-04 | 1398 |  | 349d |
| 1411 |  | Conclusão da Contratação de Suprimentos das obras de Melhoria do Sistema de Abastecimento de Água - São Tomé do Rio Doce/MG | 0d | 2020-09-04 | 2020-09-04 | 1410 |  | 797d |
| 1412 | 6.9.1.6 | **Infraestrutura** | 450d | 2020-09-28 | 2022-07-19 |  |  | 333d |
| 1413 | 6.9.1.6.1 | **Obras** | 200d | 2020-09-28 | 2021-07-19 |  |  | 335d |
| 1414 |  | Executar Captação Principal / Nova ETA / UTR - São Tomé do Rio Doce/MG | 200d | 2020-09-28 | 2021-07-19 | 1399, 1402, 1403, 1406, 1407, 1410 |  | 335d |
| 1415 | 6.9.1.6.2 | **Operação** | 250d | 2021-07-19 | 2022-07-19 |  |  | 333d |
| 1416 |  | Realizar Treinamento Operacional do Sistema - São Tomé do Rio Doce/MG | 5d | 2021-07-20 | 2021-07-26 | 1414 |  | 564d |
| 1417 |  | Realizar Testes e Pré-operação - São Tomé do Rio Doce/MG | 14d | 2021-07-27 | 2021-08-13 | 1416 |  | 564d |
| 1418 |  | Realizar Acompanhamento da Funcionalidade do Sistema - Captação Principal / Nova ETA / UTR - São Tomé do Rio Doce (distrito Tumiritinga/MG) | 365ed | 2021-07-19 | 2022-07-19 | 1420SS |  | 1473d |
| 1419 | 6.9.1.6.2.4 | **Operação Assistida** | 62d | 2021-07-19 | 2021-10-17 |  |  | 335d |
| 1420 |  | Realizar Operação Assistida - São Tomé do Rio Doce/MG | 90ed | 2021-07-19 | 2021-10-17 | 1414 |  | 1473d |
| 1421 | 6.9.2 | **Captação Alternativa** | 706d | 2017-12-12 A | 2020-09-25 |  | 80% | 783d |
| 1422 | 6.9.2.1 | **Estudos de Concepção do Sistema - Etapa 1** | 404d | 2017-12-12 A | 2019-07-11 A |  | 100% |  |
| 1423 |  | Declaração de Escopo e Premissas de Projeto (DEPP) concluída - São Tomé do Rio Doce/MG | 0d | 2018-03-23 A | 2018-03-23 A | 25, 26 | 100% |  |
| 1424 |  | Aprovação das DEPPs pela Operadora e Prefeitura - São Tomé do Rio Doce/MG | 0d | 2017-12-12 A | 2017-12-12 A | 25, 26FS+17d | 100% |  |
| 1425 | 6.9.2.1.3 | **Estudos de Concepção do Sistema - Etapa 2** | 52d | 2019-04-29 A | 2019-07-11 A |  | 100% |  |
| 1426 | 6.9.2.1.3.1 | **Captações Subterrâneas - Serviços em Poços Tubulares** | 52d | 2019-04-29 A | 2019-07-11 A |  | 100% |  |
| 1427 |  | Realizar Perfilagem - São Tomé do Rio Doce/MG | 2d | 2019-04-29 A | 2019-04-30 A | 1423FS+400ed | 100% |  |
| 1428 |  | Realizar Recuperação - São Tomé do Rio Doce/MG | 7d | 2019-05-02 A | 2019-05-10 A | 1427 | 100% |  |
| 1429 |  | Elaborar Relatório Técnico - São Tomé do Rio Doce/MG | 43d | 2019-05-13 A | 2019-07-11 A | 1428 | 100% |  |
| 1430 |  | Conclusão dos Serviços em poço tubular - São Tomé do Rio Doce/MG | 0d | 2019-07-11 A | 2019-07-11 A | 1429 | 100% |  |
| 1431 |  | Conclusão dos Estudos de Concepção das Melhorias do Sistema de Abastecimento de Água - São Tomé do Rio Doce/MG | 0d | 2019-07-11 A | 2019-07-11 A | 1430 | 100% |  |
| 1432 | 6.9.2.2 | **Engenharia Básica e Detalhada** | 189d | 2018-01-30 A | 2018-10-19 A |  | 100% |  |
| 1433 | 6.9.2.2.1 | **Engenharia Captação Alternativa (Poço 1)** | 189d | 2018-01-30 A | 2018-10-19 A |  | 100% |  |
| 1434 |  | Aprovação Plano de Trabalho /abertura OSE - Captação Alternativa - Poço 1 - São Tomé do Rio Doce/MG | 152d | 2018-01-30 A | 2018-08-29 A | 26 | 100% |  |
| 1435 |  | Dados de Entrada (levantamento de campo, topografia e sondagem) - Captação Alternativa - Poço 1 - São Tomé do Rio Doce/MG | 152d | 2018-01-30 A | 2018-08-29 A | 26, 1434FF | 100% |  |
| 1436 |  | Elaborar Projeto Executivo - Captação Alternativa - Poço 1 - São Tomé do Rio Doce/MG | 103d | 2018-05-30 A | 2018-10-19 A | 1435SS+86d | 100% |  |
| 1437 |  | Elaboração do Projeto Executivo - Captação Alternativa - Poço 1 - São Tomé do Rio Doce/MG | 0d | 2018-10-19 A | 2018-10-19 A | 1436 | 100% |  |
| 1438 | 6.9.2.3 | **Fundiária** | 291d | 2018-11-12 A | 2020-01-10 |  | 61% | 960d |
| 1439 |  | Captação Alternativa - Poço 1 - Desimpedimento de área - São Tomé do Rio Doce/MG | 291d | 2018-11-12 A | 2020-01-10 | 1423FS+166d | 61% | 900d |
| 1440 |  | Conclusão da Regularização Fundiária para as obras de Melhoria do Sistema de Abastecimento da Localidade - São Tomé do Rio Doce/MG | 0d | 2020-01-10 | 2020-01-10 | 1439 |  | 960d |
| 1441 | 6.9.2.4 | **Licenciamento** | 286d | 2018-11-19 A | 2020-01-10 |  | 76% | 960d |
| 1442 | 6.9.2.4.1 | **Outorga/DAIA para Captação Alternativa (Poço 1) - São Tomé do Rio Doce/MG** | 286d | 2018-11-19 A | 2020-01-10 |  | 76% | 960d |
| 1443 |  | Acompanhar processo junto ao orgão - Outorga/DAIA para Captação Alternativa (Poço 1) - São Tomé do Rio Doce/MG | 163d | 2018-11-19 A | 2019-07-15 A | 1430FS-161d | 100% |  |
| 1444 |  | Indeferimento da Outorga para Captação Alternativa - São Tomé do Rio Doce | 0d | 2019-07-15 A | 2019-07-15 A | 1443 | 100% |  |
| 1445 |  | Protocolar defesa junto ao orgão - São Tomé do Rio Doce | 1d | 2019-07-16 A | 2019-07-16 A | 1444 | 100% |  |
| 1446 |  | Protocolar estudo complementar no orgão ambiental - São Tomé do Rio Doce/MG | 32d | 2019-07-17 A | 2019-08-30 A | 1445 | 100% |  |
| 1447 |  | Acompanhar processo junto ao orgão - São Tomé do Rio Doce/MG | 90d | 2019-09-02 A | 2020-01-10 | 1446 | 23% | 960d |
| 1448 |  | Obtenção da Outorga para captação - Poço 1 - São Tomé do Rio Doce/MG | 0d | 2020-01-10 | 2020-01-10 | 1447 |  | 960d |
| 1449 | 6.9.2.5 | **Suprimentos** | 33d | 2018-11-08 A | 2018-12-24 A |  | 100% |  |
| 1450 |  | Captação Alternativa (contrato guarda-chuva existente - Infraestrutura) - São Tomé do Rio Doce/MG | 33d | 2018-11-08 A | 2018-12-24 A | 1436 | 100% |  |
| 1451 |  | Conclusão da Contratação de Suprimentos das obras de Melhoria do Sistema de Abastecimento de Água - São Tomé do Rio Doce/MG | 0d | 2018-12-24 A | 2018-12-24 A | 1450 | 100% |  |
| 1452 | 6.9.2.6 | **Infraestrutura** | 683d | 2018-01-15 A | 2020-09-25 |  | 48% | 783d |
| 1453 | 6.9.2.6.1 | **Obras** | 683d | 2018-01-15 A | 2020-09-25 |  | 48% | 783d |
| 1454 | 6.9.2.6.1.1 | **Captação Alternativa** | 566d | 2018-01-15 A | 2020-04-08 |  | 48% | 900d |
| 1455 |  | Executar da Captação Alternativa - Poço 1 - São Tomé do Rio Doce/MG | 56d | 2018-01-15 A | 2018-04-02 A | 1437FS-200d | 100% |  |
| 1456 |  | Executar obras de urbanização do Poço - Poço 1 - Captação Alternativa - São Tomé do Rio Doce/MG | 60d | 2020-01-13 | 2020-04-08 | 1448FF, 1439 |  | 900d |
| 1457 |  | Assinatura de Termo de Entrega das Obras de Melhoria do Sistema de Abastecimento de Água - São Tomé do Rio Doce/MG | 0d | 2020-09-25 | 2020-09-25 | 1455, 1456, 1400, 1408, 1411, 1440, 1451 |  | 783d |
| 1458 | 7 | **Território Baixo Rio Doce (MG/ES)** | 1630d | 2017-01-26 A | 2023-07-14 |  | 16% | 88d |
| 1459 | 7.1 | **Resplendor/MG (sede)** | 1470d | 2017-01-26 A | 2022-11-22 |  | 24% | 248d |
| 1460 | 7.1.1 | **Captação Alternativa** | 993d | 2017-01-26 A | 2020-12-19 |  | 49% | 725d |
| 1461 | 7.1.1.1 | **Estudos de Concepção do Sistema** | 301d | 2017-01-26 A | 2018-03-23 A |  | 100% |  |
| 1462 |  | Declaração de Escopo e Premissas de Projeto (DEPP) concluída - Resplendor/MG | 0d | 2018-03-23 A | 2018-03-23 A | 25, 26 | 100% |  |
| 1463 |  | Aprovação das DEPPs pela Operadora e Prefeitura - Resplendor/MG | 0d | 2018-03-14 A | 2018-03-14 A | 25, 26 | 100% |  |
| 1464 | 7.1.1.1.3 | **Captações Subterrâneas - Serviços em Poço Tubular Existente** | 82d | 2017-01-26 A | 2017-05-19 A |  | 100% |  |
| 1465 |  | Realizar Perfilagem e Recuperação - Poço C1 - Resplendor/MG | 7d | 2017-01-26 A | 2017-02-03 A | 24 | 100% |  |
| 1466 |  | Elaborar Relatório Técnico - Poço C1 - Resplendor/MG | 21d | 2017-02-06 A | 2017-03-06 A | 1465 | 100% |  |
| 1467 |  | Realizar Laudo dos Serviços de Coleta e Análise de Água - Poço C1 - Resplendor/MG | 79d | 2017-01-31 A | 2017-05-19 A | 1465SS+3d | 100% |  |
| 1468 |  | Conclusão dos Serviços em poço tubular - Poço C1 - Resplendor/MG | 0d | 2017-05-19 A | 2017-05-19 A | 1467 | 100% |  |
| 1469 | 7.1.1.2 | **Engenharia Básica e Detalhada** | 357d | 2017-10-23 A | 2019-03-11 A |  | 100% |  |
| 1470 | 7.1.1.2.1 | **Engenharia Captação Alternativa (Poço C2)** | 202d | 2017-10-23 A | 2018-07-31 A |  | 100% |  |

| ID | WBS | Task | Duration | Start | Finish | Predecessors | Complete | Total float |
| --- | --- | --- | --- | --- | --- | --- | --- | --- |
| 1471 |  | Aprovar Plano de Trabalho e abrir OSE - Captação Alternativa - Poço C2 - Resplendor/MG | 11d | 2018-03-23 A | 2018-04-06 A | 1462 | 100% |  |
| 1472 |  | Realizar Levantamento de Campo - Captação Alternativa - Poço C2 - Resplendor/MG | 6d | 2018-04-09 A | 2018-04-16 A | 1471 | 100% |  |
| 1473 |  | Elaborar arranjo para obtenção de Dados de Entrada Licenciamento e Fundiário - Captação Alternativa - Poço C2 - Resplendor/MG | 30d | 2018-04-17 A | 2018-05-28 A | 1472 | 100% |  |
| 1474 |  | Emitir RT/PQ para Suprimentos - Captação Alternativa - Poço C2 - Resplendor/MG | 10d | 2018-06-26 A | 2018-07-09 A | 1475FF | 100% |  |
| 1475 |  | Elaborar Projeto Executivo As Built do Poço Existente - Captação Alternativa - Poço C2 - Resplendor/MG | 202d | 2017-10-23 A | 2018-07-31 A | 1472, 1473FF | 100% |  |
| 1476 |  | Elaboração do Projeto Executivo - Captação Alternativa - Poço C2 - Resplendor/MG | 0d | 2018-07-31 A | 2018-07-31 A | 1475, 1474 | 100% |  |
| 1477 | 7.1.1.2.2 | **Engenharia Captação Alternativa (Poço C1)** | 260d | 2018-03-07 A | 2019-03-11 A |  | 100% |  |
| 1478 |  | Aprovar Plano de Trabalho e abrir OSE (Poço C1) - Captação Alternativa - Poço C1 - Resplendor/MG | 22d | 2018-03-07 A | 2018-04-05 A | 26 | 100% |  |
| 1479 |  | Realizar Levantamento de Campo - Captação Alternativa - Poço C1 - Resplendor/MG | 5d | 2018-04-13 A | 2018-04-19 A | 1478 | 100% |  |
| 1480 |  | Realizar Sondagem - Captação Alternativa - Poço C1 - Resplendor/MG | 40d | 2018-05-18 A | 2018-07-12 A | 1478 | 100% |  |
| 1481 |  | Executar Topografia - Captação Alternativa - Poço C1 - Resplendor/MG | 40d | 2018-05-18 A | 2018-07-12 A | 1478 | 100% |  |
| 1482 |  | Elaborar arranjo para obtenção de Dados de Entrada Licenciamento e Fundiário (Poço C1) - Captação Alternativa - Poço C1 - Resplendor/MG | 10d | 2018-05-07 A | 2018-05-18 A | 1479, 1480, 1481 | 100% |  |
| 1483 |  | Emitir RT/PQ para Suprimentos - Captação Alternativa - Poço C1 - Resplendor/MG | 71d | 2018-11-27 A | 2019-03-11 A | 1484FF | 100% |  |
| 1484 |  | Elaborar Projeto Executivo (Poço C1) - Captação Alternativa - Poço C1 - Resplendor/MG | 215d | 2018-05-09 A | 2019-03-11 A | 1466, 1482 | 100% |  |
| 1485 |  | Elaboração do Projeto Executivo - Captação Alternativa - Poço C1 - Resplendor/MG | 0d | 2019-03-11 A | 2019-03-11 A | 1484, 1483 | 100% |  |
| 1486 | 7.1.1.3 | **Licenciamento** | 386d | 2017-12-12 A | 2019-06-13 A |  | 100% |  |
| 1487 |  | Captação Alternativa - Dispensa de Licença - Poços C01, C02 e C03 (Aut. Municipal para obras) - Resplendor/MG | 1d | 2017-12-12 A | 2017-12-12 A | 26FS+16d | 100% |  |
| 1488 |  | Outorga para Captação Alternativa (Poço C01) - Resplendor/MG | 185d | 2018-09-19 A | 2019-06-13 A | 1466, 1482 | 100% |  |
| 1489 |  | Conclusão do Licenciamento Ambiental da Localidade - Resplendor/MG | 0d | 2019-06-13 A | 2019-06-13 A | 1487, 1488 | 100% |  |
| 1490 | 7.1.1.4 | **Infraestrutura** | 687d | 2018-03-30 A | 2020-12-19 |  | 23% | 725d |
| 1491 | 7.1.1.4.1 | **Obras** | 440d | 2018-03-30 A | 2019-12-20 |  | 95% | 972d |
| 1492 | 7.1.1.4.1.1 | **Captação Alternativa** | 440d | 2018-03-30 A | 2019-12-20 |  | 95% | 972d |
| 1493 |  | Executar Captação Alternativa (Poço C1 e C2) - Resplendor/MG | 440d | 2018-03-30 A | 2019-12-20 | 1484, 1487 | 95% | 724d |
| 1494 |  | Conclusão das Obras de Captação Alternativa (Poço C1 e C2) - Resplendor/MG | 0d | 2019-12-20 | 2019-12-20 | 1493 |  | 972d |
| 1495 |  | Assinatura de Termo de Entrega das Obras de Melhoria do Sistema de Abastecimento de Água - Resplendor/MG | 0d | 2019-12-20 | 2019-12-20 | 1493, 1494, 1489, 1485, 1476, 1468 |  | 972d |
| 1496 | 7.1.1.4.2 | **Operação** | 247d | 2019-12-20 | 2020-12-19 |  |  | 724d |
| 1497 |  | Realizar Treinamento Operacional do Sistema - Resplendor/MG | 5d | 2019-12-23 | 2019-12-31 | 1493 |  | 953d |
| 1498 |  | Realizar Testes e Pré-operação - Resplendor/MG | 14d | 2020-01-02 | 2020-01-21 | 1497 |  | 953d |
| 1499 |  | Realizar Acompanhamento da Funcionalidade do Sistema - Captação Alternativa - Resplendor/MG (sede) | 365ed | 2019-12-20 | 2020-12-19 | 1501SS |  | 3204d |
| 1500 | 7.1.1.4.2.4 | **Operação Assistida** | 58d | 2019-12-20 | 2020-03-19 |  |  | 724d |
| 1501 |  | Realizar Operação Assistida - Resplendor/MG | 90ed | 2019-12-20 | 2020-03-19 | 1493 |  | 3204d |
| 1502 | 7.1.2 | **Melhorias de ETA e na Captação Principal** | 810d | 2018-03-14 A | 2021-06-05 |  | 15% | 614d |
| 1503 | 7.1.2.1 | **Engenharia** | 433d | 2018-03-14 A | 2019-11-22 |  | 87% | 623d |
| 1504 | 7.1.2.1.1 | **Estudos de Concepção do Sistema** | 7d | 2018-03-14 A | 2018-03-23 A |  | 100% |  |
| 1505 |  | Declaração de Escopo e Premissas de Projeto (DEPP) concluída - Resplendor/MG | 0d | 2018-03-23 A | 2018-03-23 A | 25, 26 | 100% |  |
| 1506 |  | Aprovação das DEPPs pela Operadora e Prefeitura - Resplendor/MG | 0d | 2018-03-14 A | 2018-03-14 A | 25, 26 | 100% |  |
| 1507 | 7.1.2.1.2 | **Engenharia Básica e Detalhada** | 386d | 2018-05-18 A | 2019-11-22 |  | 87% | 623d |
| 1508 | 7.1.2.1.2.1 | **Engenharia Melhorias ETA - SE 32247** | 386d | 2018-05-18 A | 2019-11-22 |  | 87% | 623d |
| 1509 |  | Aprovar Plano de Trabalho e abrir OSE - Melhorias na ETA - Resplendor/MG | 10d | 2018-10-29 A | 2018-11-09 A | 1505 | 100% |  |
| 1510 |  | Realizar Levantamento de Campo - Melhorias na ETA - Resplendor/MG | 2d | 2019-01-22 A | 2019-01-23 A | 1509FS+51d | 100% |  |
| 1511 |  | Realizar Sondagem - Melhorias na ETA - Resplendor/MG | 40d | 2018-05-18 A | 2018-07-12 A | 1509 | 100% |  |
| 1512 |  | Emitir RT/PQ para Suprimentos - Melhorias na ETA - Resplendor/MG | 10d | 2019-11-08 | 2019-11-22 | 1513FF |  | 613d |
| 1513 |  | Elaborar Projeto Executivo - Melhorias na ETA - Resplendor/MG | 202d | 2019-02-01 A | 2019-11-22 | 1510, 1511 | 88% | 613d |
| 1514 |  | Elaboração do Projeto Executivo - Melhorias na ETA - Resplendor/MG | 0d | 2019-11-22 | 2019-11-22 | 1513 |  | 623d |
| 1515 | 7.1.2.2 | **Suprimentos** | 93d | 2019-11-25 | 2020-04-13 |  |  | 898d |
| 1516 |  | Verificar se obra está incluída no CGC existente - Processo contratação Captações e ETA - Resplendor/MG | 5d | 2019-11-25 | 2019-11-29 | 1512, 1513 |  | 898d |
| 1517 |  | Processo de contratação - Melhorias na ETA - Resplendor/MG | 88d | 2019-12-02 | 2020-04-13 | 1516 |  | 898d |
| 1518 |  | Conclusão da Contratação de Suprimentos das obras de Melhoria do Sistema de Abastecimento de Água - Resplendor/MG | 0d | 2020-04-13 | 2020-04-13 | 1517 |  | 898d |
| 1519 | 7.1.2.3 | **Infraestrutura** | 614d | 2018-12-13 A | 2021-06-05 |  | 5% | 614d |
| 1520 | 7.1.2.3.1 | **Obras** | 367d | 2018-12-13 A | 2020-06-05 |  | 30% | 861d |
| 1521 |  | Executar Captação Principal - Balsa de Captação do Rio Doce - Resplendor/MG | 60d | 2019-10-28 A | 2020-01-24 | 1505 | 25% | 950d |
| 1522 | 7.1.2.3.1.2 | **Melhorias na ETA** | 367d | 2018-12-13 A | 2020-06-05 |  | 31% | 613d |
| 1523 |  | Executar Melhorias na ETA (Serviço de adequação da elevatória) - Resplendor/MG | 59d | 2018-12-13 A | 2019-03-11 A | 1505FS+189d | 100% |  |
| 1524 |  | Executar Melhorias de ETA - Resplendor/MG | 130d | 2019-11-25 | 2020-06-05 | 1512, 1514FS-10d |  | 613d |
| 1525 |  | Conclusão das Obras de Melhorias em ETA - Resplendor/MG | 0d | 2020-06-05 | 2020-06-05 | 1523, 1524 |  | 613d |
| 1526 |  | Assinatura de Termo de Entrega das Obras de Melhoria do Sistema de Abastecimento de Água - Resplendor/MG | 0d | 2020-06-05 | 2020-06-05 | 1521, 1523, 1524, 1525, 1518 |  | 861d |
| 1527 | 7.1.2.3.2 | **Operação** | 247d | 2020-06-05 | 2021-06-05 |  |  | 613d |
| 1528 |  | Realizar Treinamento Operacional do Sistema - Resplendor/MG | 5d | 2020-06-08 | 2020-06-15 | 1523, 1524, 1525 |  | 842d |
| 1529 |  | Realizar Testes e Pré-operação - Resplendor/MG | 14d | 2020-06-16 | 2020-07-03 | 1528 |  | 842d |
| 1530 |  | Realizar Acompanhamento da Funcionalidade do Sistema - Melhorias de ETA e na Captação Principal - Resplendor/MG (sede) | 365ed | 2020-06-05 | 2021-06-05 | 1532SS |  | 2700d |
| 1531 | 7.1.2.3.2.4 | **Operação Assistida** | 63d | 2020-06-05 | 2020-09-03 |  |  | 612d |
| 1532 |  | Realizar Operação Assistida - Resplendor/MG | 90ed | 2020-06-05 | 2020-09-03 | 1523, 1525 |  | 2700d |
| 1533 | 7.1.3 | **UTR** | 1388d | 2017-05-19 A | 2022-11-22 |  |  | 248d |
| 1534 | 7.1.3.1 | **Estudos de Concepção do Sistema** | 523d | 2017-05-19 A | 2019-05-31 A |  | 100% |  |
| 1535 |  | Declaração de Escopo e Premissas de Projeto (DEPP) concluída - Resplendor/MG | 0d | 2018-03-23 A | 2018-03-23 A | 25, 26 | 100% |  |
| 1536 |  | Aprovação das DEPPs pela Operadora e Prefeitura - Resplendor/MG | 0d | 2018-03-14 A | 2018-03-14 A | 25, 26 | 100% |  |
| 1537 | 7.1.3.1.3 | **Coleta e Análise do Lodo de ETA** | 7d | 2019-05-23 A | 2019-05-31 A |  | 100% |  |
| 1538 |  | Executar Coleta e Análise do Lodo de ETA - Resplendor/MG | 7d | 2019-05-23 A | 2019-05-31 A | 1536FS+304d | 100% |  |
| 1539 |  | Conclusão das Coletas e Análises de Lodo de ETA - Resplendor/MG | 0d | 2019-05-31 A | 2019-05-31 A | 1538 | 100% |  |
| 1540 |  | Conclusão dos Estudos de Concepção das Melhorias do Sistema de Abastecimento de Água - Resplendor/MG | 0d | 2017-05-19 A | 2017-05-19 A |  | 100% |  |

| ID | WBS | Task | Duration | Start | Finish | Predecessors | Complete | Total float |
| --- | --- | --- | --- | --- | --- | --- | --- | --- |
| 1541 | 7.1.3.2 | **Engenharia Básica e Detalhada** | 259d | 2019-11-14 | 2020-12-01 |  |  | 249d |
| 1542 | 7.1.3.2.1 | **Engenharia UTR** | 259d | 2019-11-14 | 2020-12-01 |  |  | 249d |
| 1543 |  | Aprovar Plano de Trabalho e abrir OSE - UTR - Resplendor/MG | 18d | 2019-11-14 | 2019-12-10 | 1535FS+420d, 1539 |  | 249d |
| 1544 |  | Realizar Levantamento de Campo - UTR - Resplendor/MG | 14d | 2020-01-16 | 2020-02-04 | 1543FS+22d |  | 249d |
| 1545 |  | Realizar Sondagem - UTR - Resplendor/MG | 14d | 2020-01-16 | 2020-02-04 | 1543FS+22d |  | 249d |
| 1546 |  | Elaborar Projeto Conceitual - UTR - Resplendor/MG | 67d | 2020-01-06 | 2020-04-13 | 1544FS-22d, 1545FS-22d |  | 249d |
| 1547 |  | Elaborar Projeto Básico - UTR - Resplendor/MG | 70d | 2020-04-14 | 2020-07-23 | 1546 |  | 249d |
| 1548 |  | Aprovar Projeto Básico - UTR - Resplendor/MG | 22d | 2020-07-24 | 2020-08-24 | 1547 |  | 738d |
| 1549 |  | Emitir RT/PQ para Suprimentos - UTR - Resplendor/MG | 43d | 2020-07-24 | 2020-09-23 | 1547 |  | 249d |
| 1550 |  | Elaborar Projeto Executivo - UTR - Resplendor/MG | 68d | 2020-08-25 | 2020-12-01 | 1547, 1548 |  | 738d |
| 1551 |  | Elaboração do Projeto Executivo - UTR - Resplendor/MG | 0d | 2020-12-01 | 2020-12-01 | 1550 |  | 738d |
| 1552 | 7.1.3.3 | **Licenciamento** | 176d | 2020-04-14 | 2020-12-23 |  |  | 274d |
| 1553 |  | DAIA para execução da obra - UTR - Resplendor/MG | 176d | 2020-04-14 | 2020-12-23 | 1546 |  | 274d |
| 1554 |  | Conclusão do Licenciamento Ambiental da Localidade - Resplendor/MG | 0d | 2020-12-23 | 2020-12-23 | 1553 |  | 722d |
| 1555 | 7.1.3.4 | **Suprimentos** | 88d | 2020-09-24 | 2021-02-01 |  |  | 249d |
| 1556 |  | Processo contratação (UTR) - Resplendor/MG | 88d | 2020-09-24 | 2021-02-01 | 1549 |  | 249d |
| 1557 |  | Conclusão da Contratação de Suprimentos das obras de Melhoria do Sistema de Abastecimento de Água - Resplendor/MG | 0d | 2021-02-01 | 2021-02-01 | 1556 |  | 697d |
| 1558 | 7.1.3.5 | **Infraestrutura** | 449d | 2021-02-02 | 2022-11-22 |  |  | 248d |
| 1559 | 7.1.3.5.1 | **Obras** | 200d | 2021-02-02 | 2021-11-22 |  |  | 249d |
| 1560 |  | Executar UTR - Resplendor/MG | 200d | 2021-02-02 | 2021-11-22 | 1553, 1556, 1549 |  | 249d |
| 1561 |  | Assinatura de Termo de Entrega das Obras de Melhoria do Sistema de Abastecimento de Água - Resplendor/MG | 0d | 2021-11-22 | 2021-11-22 | 1560, 1551, 1554, 1557 |  | 497d |
| 1562 | 7.1.3.5.2 | **Operação** | 249d | 2021-11-22 | 2022-11-22 |  |  | 248d |
| 1563 |  | Realizar Treinamento Operacional do Sistema - Resplendor/MG | 5d | 2021-11-23 | 2021-11-29 | 1560 |  | 478d |
| 1564 |  | Realizar Testes e Pré-operação - Resplendor/MG | 14d | 2021-11-30 | 2021-12-17 | 1563 |  | 478d |
| 1565 |  | Realizar Acompanhamento da Funcionalidade do Sistema - UTR - Resplendor/MG (sede) | 365ed | 2021-11-22 | 2022-11-22 | 1567SS |  | 1095d |
| 1566 | 7.1.3.5.2.4 | **Operação Assistida** | 63d | 2021-11-22 | 2022-02-20 |  |  | 248d |
| 1567 |  | Realizar Operação Assistida - Resplendor/MG | 90ed | 2021-11-22 | 2022-02-20 | 1560 |  | 1095d |
| 1568 | 7.2 | **Itueta/MG (sede)** | 1284d | 2018-03-23 A | 2023-05-11 |  | 3% | 133d |
| 1569 | 7.2.1 | **Captação Alternativa (Rio Manhuaçu) / Nova ETA e UTR** | 1284d | 2018-03-23 A | 2023-05-11 |  | 3% | 133d |
| 1570 | 7.2.1.1 | **Estudos de Concepção do Sistema - Etapa 1** | 0d | 2018-03-23 A | 2018-03-23 A |  | 100% |  |
| 1571 |  | Declaração de Escopo e Premissas de Projeto (DEPP) concluída - Itueta/MG | 0d | 2018-03-23 A | 2018-03-23 A | 25, 26 | 100% |  |
| 1572 |  | Aprovação das DEPPs pela Operadora e Prefeitura - Itueta/MG | 0d | 2018-03-23 A | 2018-03-23 A | 1571 | 100% |  |
| 1573 | 7.2.1.2 | **Estudos de Concepção do Sistema - Etapa 2** | 157d | 2019-03-08 A | 2019-10-21 A |  | 100% |  |
| 1574 |  | Início das atividades da nova definição para a captação principal - Itueta/MG | 0d | 2019-10-21 A | 2019-10-21 A | 1572FS+410d | 100% |  |
| 1575 | 7.2.1.2.2 | **Captações Superficiais - Rio Manhuaçu** | 20d | 2019-03-08 A | 2019-04-04 A |  | 100% |  |
| 1576 |  | Realizar Laudo dos Serviços de Coleta e Análise de Água (Dados do PMQQS) - Itueta/MG | 20d | 2019-03-08 A | 2019-04-04 A | 1571FS+350ed | 100% |  |
| 1577 |  | Conclusão do Estudo da Captação Superficial - Itueta/MG | 0d | 2019-04-04 A | 2019-04-04 A | 1576 | 100% |  |
| 1578 |  | Conclusão dos Estudos de Concepção das Melhorias do Sistema de Abastecimento de Água - Itueta/MG | 0d | 2019-04-04 A | 2019-04-04 A | 1577 | 100% |  |
| 1579 | 7.2.1.3 | **Engenharia Básica e Detalhada** | 317d | 2019-08-23 A | 2020-11-30 |  | 15% | 739d |
| 1580 | 7.2.1.3.1 | **Engenharia Captação Alternativa (Rio Manhuaçu) / Nova ETA e UTR** | 297d | 2019-08-23 A | 2020-10-30 |  | 16% | 739d |
| 1581 |  | Aprovar Plano de Trabalho e abrir OSE - Captação Alternativa, ETA e UTR, Nova ETA e UTR - Itueta/MG | 25d | 2019-10-22 A | 2019-11-26 | 1574 | 25% | 133d |
| 1582 |  | Realizar Sondagem - Captação Alternativa, ETA e UTR -Itueta/MG | 30d | 2020-02-04 | 2020-03-19 | 1581FS+45d |  | 201d |
| 1583 |  | Executar Topografia - Captação Alternativa, ETA e UTR - Itueta/MG | 47d | 2019-08-23 A | 2019-10-28 A | 1581FS-40d | 100% |  |
| 1584 |  | Elaborar arranjo para obtenção de Dados de Entrada Licenciamento e Fundiário - Captação Alternativa, ETA e UTR -Itueta/MG | 58d | 2019-11-27 | 2020-02-20 | 1581 |  | 133d |
| 1585 |  | Elaborar Projeto Básico - Captação Alternativa, ETA e UTR - Itueta/MG | 85d | 2020-02-21 | 2020-06-29 | 1582FF, 1583FF, 1584SS+58d |  | 133d |
| 1586 |  | Aprovar Projeto Básico - Captação Alternativa, ETA e UTR - Itueta/MG | 22d | 2020-06-30 | 2020-07-29 | 1585 |  | 133d |
| 1587 |  | Emitir RT/PQ para Suprimentos - Captação Alternativa, ETA e UTR - Itueta/MG | 10d | 2020-10-02 | 2020-10-16 | 1588FF-10d |  | 133d |
| 1588 |  | Elaborar Projeto Executivo - Captação Alternativa, ETA e UTR - Itueta/MG | 65d | 2020-07-30 | 2020-10-30 | 1585, 1586 |  | 133d |
| 1589 |  | Elaboração do Projeto Executivo- Captação Alternativa, ETA e UTR -Itueta/MG | 0d | 2020-10-30 | 2020-10-30 | 1588 |  | 739d |
| 1590 | 7.2.1.3.2 | **Validação dos Projetos** | 20d | 2020-11-03 | 2020-11-30 |  |  | 739d |
| 1591 |  | Validar Projetos com Prefeitura e Operadora - Itueta/MG | 20d | 2020-11-03 | 2020-11-30 | 1589 |  | 739d |
| 1592 |  | Validação com Prefeitura e Operadora dos Projetos de Melhoria do Sistema de Abastecimento de Água - Itueta/MG | 0d | 2020-11-30 | 2020-11-30 | 1591 |  | 739d |
| 1593 | 7.2.1.4 | **Fundiária** | 367d | 2019-05-16 A | 2020-11-03 |  | 11% | 758d |
| 1594 | 7.2.1.4.1 | **Captação Alternativa - Rio Manhuaçu - Desimpedimento da Área e Negociação de Servidão** | 367d | 2019-05-16 A | 2020-11-03 |  | 20% | 223d |
| 1595 |  | [Traçado antigo] Realizar Levantamento da documentação da propriedade - Termo de Autorização e Cadastro de superficiários - Itueta/MG | 22d | 2019-05-16 A | 2019-06-14 A | 1571 | 100% |  |
| 1596 |  | [Traçado antigo] Obter assinatura do Contrato de servidão pelo proprietário - Itueta/MG | 20d | 2019-06-17 A | 2019-07-15 A | 1595 | 100% |  |
| 1597 |  | Definição de novo traçado para Adutora do rio Manhuaçu - Itueta/MG | 0d | 2019-10-21 A | 2019-10-21 A | 1596, 1574 | 100% |  |
| 1598 |  | Realizar Negociação da Servidão - Adutora Rio Manhuaçu - Captação Alternativa - Itueta/MG | 173d | 2020-02-21 | 2020-11-03 | 1597, 1584 |  | 223d |
| 1599 |  | Regularização da Servidão - Captação Alternativa - Itueta/MG | 0d | 2020-11-03 | 2020-11-03 | 1598 |  | 223d |
| 1600 |  | Nova ETA / UTR - Desimpedimento de áreas - Itueta/MG | 173d | 2020-02-21 | 2020-11-03 | 1584 |  | 310d |
| 1601 |  | Conclusão da Regularização Fundiária para as obras de Melhoria do Sistema de Abastecimento da Localidade - Itueta/MG | 0d | 2020-11-03 | 2020-11-03 | 1599, 1600 |  | 758d |
| 1602 | 7.2.1.5 | **Licenciamento** | 203d | 2020-02-21 | 2020-12-15 |  |  | 227d |
| 1603 |  | Captação Alternativa - Outorga para Captação no rio Manhuaçu - Itueta/MG | 203d | 2020-02-21 | 2020-12-15 | 1584 |  | 480d |
| 1604 |  | Captação Alternativa - DAIA para Construção de Adutora rio Manhuaçu - Itueta/MG | 203d | 2020-02-21 | 2020-12-15 | 1584 |  | 227d |
| 1605 |  | Verificar necessidade de Licença/Autorização - Nova ETA / UTR - Itueta/MG | 203d | 2020-02-21 | 2020-12-15 | 1584 |  | 280d |
| 1606 |  | Conclusão do Licenciamento Ambiental da Localidade - Itueta/MG | 0d | 2020-12-15 | 2020-12-15 | 1603, 1605 |  | 728d |
| 1607 | 7.2.1.6 | **Suprimentos** | 98d | 2020-10-19 | 2021-03-12 |  |  | 133d |
| 1608 |  | Realizar análise da RT/PQ pela Infra - Adutora, Nova ETA e UTR - Itueta/MG | 10d | 2020-10-19 | 2020-10-30 | 1587 |  | 133d |
| 1609 |  | Realizar Processo contratação - Adutora, Nova ETA e UTR - Itueta/MG | 88d | 2020-11-03 | 2021-03-12 | 1608 |  | 133d |
| 1610 |  | Conclusão da Contratação de Suprimentos - Adutora, Nova ETA e UTR - Itueta/MG | 0d | 2021-03-12 | 2021-03-12 | 1609 |  | 133d |

| ID | WBS | Task | Duration | Start | Finish | Predecessors | Complete | Total float |
| --- | --- | --- | --- | --- | --- | --- | --- | --- |
| 1611 | 7.2.1.7 | **Infraestrutura** | 538d | 2021-03-15 | 2023-05-11 |  |  | 133d |
| 1612 | 7.2.1.7.1 | **Obras** | 538d | 2021-03-15 | 2023-05-11 |  |  | 133d |
| 1613 |  | Executar Captação Principal (Pequenas Melhorias Captação rio Doce) - Itueta/MG | 66d | 2021-03-15 | 2021-06-17 | 1599FS-3d, 1610 |  | 357d |
| 1614 |  | Executar Captação Alternativa (Rio Manhuaçu) - Itueta/MG | 290d | 2021-03-15 | 2022-05-11 | 1599FS-3d, 1603FF, 1610, 1604FS-37d |  | 133d |
| 1615 |  | Executar Nova ETA - Itueta/MG | 137d | 2021-03-15 | 2021-09-27 | 1600, 1605, 1610 |  | 286d |
| 1616 |  | Executar UTR - Itueta/MG | 200d | 2021-03-15 | 2021-12-29 | 1600, 1605, 1610 |  | 223d |
| 1617 |  | Assinatura de Termo de Entrega das Obras de Melhoria do Sistema de Abastecimento de Água - Itueta/MG | 0d | 2022-05-11 | 2022-05-11 | 1613, 1614, 1615, 1616, 1592, 1601, 1606 |  | 381d |
| 1618 |  | Realizar Acompanhamento da Funcionalidade do Sistema - Captação Alternativa (Rio Manhuaçu) / Nova ETA e UTR - Itueta/MG (sede) | 365ed | 2022-05-11 | 2023-05-11 | 1623SS |  | 585d |
| 1619 | 7.2.1.7.2 | **Operação** | 63d | 2022-05-11 | 2022-08-09 |  |  | 133d |
| 1620 |  | Realizar Treinamento Operacional do Sistema - Itueta/MG | 5d | 2022-05-12 | 2022-05-18 | 1613, 1614, 1615, 1616 |  | 362d |
| 1621 |  | Realizar Testes e Pré-operação - Itueta/MG | 14d | 2022-05-19 | 2022-06-07 | 1620 |  | 362d |
| 1622 | 7.2.1.7.2.3 | **Operação Assistida** | 63d | 2022-05-11 | 2022-08-09 |  |  | 132d |
| 1623 |  | Realizar Operação Assistida - Itueta/MG | 90ed | 2022-05-11 | 2022-08-09 | 1613, 1614, 1615, 1616 |  | 585d |
| 1624 | 7.3 | **Santo Antônio do Rio Doce (distrito Aimorés/MG)** | 1329d | 2018-03-23 A | 2023-07-14 |  | 6% | 88d |
| 1625 | 7.3.1 | **Captação Principal, UTR na ETA de Aimorés** | 1329d | 2018-03-23 A | 2023-07-14 |  | 6% | 88d |
| 1626 | 7.3.1.1 | **Estudos de Concepção do Sistema** | 384d | 2018-03-23 A | 2019-09-24 A |  | 100% |  |
| 1627 |  | Declaração de Escopo e Premissas de Projeto (DEPP) concluída - Santo Antônio do Rio Doce/MG | 0d | 2018-03-23 A | 2018-03-23 A | 25, 26 | 100% |  |
| 1628 |  | Revisar Definições - Santo Antônio do Rio Doce/MG | 55d | 2019-01-28 A | 2019-04-17 A | 1627FS+220d | 100% |  |
| 1629 |  | Aprovação da Revisão da Definição pela Operadora e Prefeitura - Santo Antônio do Rio Doce/MG | 7d | 2019-04-22 A | 2019-04-30 A | 1628 | 100% |  |
| 1630 |  | Aprovação pelo CIF da solução da Prefeitura de Aimorés/MG - Deliberação nº 325/2019 - Santo Antônio do Rio Doce/MG | 0d | 2019-09-24 A | 2019-09-24 A | 1629FS+102d | 100% |  |
| 1631 | 7.3.1.2 | **Engenharia Básica e Detalhada** | 417d | 2019-05-02 A | 2020-12-31 |  | 21% | 718d |
| 1632 | 7.3.1.2.1 | **Engenharia Projeto Município Aimorés (Captação principal)** | 329d | 2019-05-02 A | 2020-08-24 |  | 39% | 786d |
| 1633 |  | Analisar o Projeto Básico da Prefeitura - Captação Principal - Santo Antônio do Rio Doce/MG | 126d | 2019-05-02 A | 2019-10-28 A | 1629 | 100% |  |
| 1634 |  | Aprovar Plano de Trabalho e abrir OSE - Captação Principal - Santo Antônio do Rio Doce/MG | 19d | 2019-10-29 A | 2019-11-25 | 1633 | 25% | 195d |
| 1635 |  | Realizar Levantamento de Campo/Sondagem - Captação Principal - Santo Antônio do Rio Doce/MG | 30d | 2019-11-26 | 2020-01-10 | 1634 |  | 195d |
| 1636 |  | Elaborar Projeto Básico - Captação Principal - Santo Antônio do Rio Doce/MG | 80d | 2020-01-13 | 2020-05-11 | 1635 |  | 195d |
| 1637 |  | Aprovar Projeto Básico - Captação Principal - Santo Antônio do Rio Doce/MG | 22d | 2020-05-12 | 2020-06-10 | 1636 |  | 195d |
| 1638 |  | Emitir RT/PQ para Suprimentos - Captação Principal - Santo Antônio do Rio Doce/MG | 10d | 2020-07-07 | 2020-07-20 | 1639FF-25d |  | 195d |
| 1639 |  | Elaborar Projeto Executivo - Captação Principal - Santo Antônio do Rio Doce/MG | 52d | 2020-06-12 | 2020-08-24 | 1633, 1634, 1636, 1637 |  | 195d |
| 1640 |  | Elaboração do Projeto Executivo - Captação Principal - Santo Antônio do Rio Doce/MG | 0d | 2020-08-24 | 2020-08-24 | 1639 |  | 786d |
| 1641 | 7.3.1.2.2 | **Engenharia UTR na ETA de Aimorés/MG** | 249d | 2019-11-29 | 2020-12-01 |  |  | 88d |
| 1642 |  | Aprovar Plano de Trabalho e abrir OSE - UTR - Santo Antônio do Rio Doce/MG | 8d | 2019-11-29 | 2019-12-10 | 1633FS+22d |  | 88d |
| 1643 |  | Elaborar arranjo para obtenção de Dados de Entrada Licenciamento e Fundiário - UTR - Santo Antônio do Rio Doce/MG | 69d | 2020-01-16 | 2020-04-28 | 1642FS+22d |  | 88d |
| 1644 |  | Elaborar Projeto Básico - UTR - Santo Antônio do Rio Doce/MG | 70d | 2020-04-14 | 2020-07-23 | 1643FS-10d |  | 88d |
| 1645 |  | Aprovar Projeto Básico - UTR - Santo Antônio do Rio Doce/MG | 22d | 2020-07-24 | 2020-08-24 | 1644 |  | 290d |
| 1646 |  | Emitir RT/PQ para Suprimentos - UTR - Santo Antônio do Rio Doce/MG | 15d | 2020-04-29 | 2020-05-20 | 1643 |  | 337d |
| 1647 |  | Elaborar Projeto Executivo - UTR - Santo Antônio do Rio Doce/MG | 68d | 2020-08-25 | 2020-12-01 | 1643, 1645 |  | 290d |
| 1648 |  | Elaboração do Projeto Executivo - UTR - Santo Antônio do Rio Doce/MG | 0d | 2020-12-01 | 2020-12-01 | 1647 |  | 738d |
| 1649 | 7.3.1.2.3 | **Validação dos Projetos** | 20d | 2020-12-02 | 2020-12-31 |  |  | 718d |
| 1650 |  | Validar Projetos com Prefeitura e Operadora - Santo Antônio do Rio Doce/MG | 20d | 2020-12-02 | 2020-12-31 | 1640, 1647 |  | 718d |
| 1651 |  | Validação com Prefeitura e Operadora dos Projetos de Melhoria do Sistema de Abastecimento de Água - Santo Antônio do Rio Doce/MG | 0d | 2020-12-31 | 2020-12-31 | 1644, 1648, 1650 |  | 718d |
| 1652 |  | Conclusão e Validação da Engenharia - Santo Antônio do Rio Doce/MG | 0d | 2020-12-31 | 2020-12-31 | 1651 |  | 718d |
| 1653 | 7.3.1.4 | **Fundiária** | 358d | 2019-11-20 | 2021-05-04 |  |  | 201d |
| 1654 |  | Obter Termo de Autorização de Superficiário - Captação Principal - Santo Antônio do Rio Doce/MG | 5d | 2019-11-20 | 2019-11-26 | 1629FS+25d, 1633FS+15d |  | 201d |
| 1655 |  | Captação Principal - Desimpedimento de área - Santo Antônio do Rio Doce/MG | 240d | 2020-05-18 | 2021-05-04 | 1654, 1644SS+22d |  | 88d |
| 1656 |  | Conclusão da Regularização Fundiária para as obras de Melhoria do Sistema de Abastecimento da Localidade - Santo Antônio do Rio Doce/MG | 0d | 2021-05-04 | 2021-05-04 | 1654, 1655 |  | 636d |
| 1657 | 7.3.1.5 | **Licenciamento** | 188d | 2020-04-29 | 2021-01-27 |  |  | 164d |
| 1658 |  | Obter Outorga/DAIA para Captação Principal - Santo Antônio do Rio Doce/MG | 176d | 2020-05-18 | 2021-01-27 | 1633FS+22d, 1654, 1644SS+22d |  | 152d |
| 1659 |  | Licença/Autorização ETA / UTR - Santo Antônio do Rio Doce/MG | 176d | 2020-04-29 | 2021-01-11 | 1643 |  | 264d |
| 1660 |  | Conclusão do Licenciamento Ambiental da Localidade - Santo Antônio do Rio Doce/MG | 0d | 2021-01-27 | 2021-01-27 | 1658, 1659 |  | 700d |
| 1661 | 7.3.1.6 | **Suprimentos** | 130d | 2020-05-21 | 2020-11-24 |  |  | 237d |
| 1662 |  | Processo de Contrataçao (Projeto da Prefeitura) - Santo Antônio do Rio Doce/MG | 88d | 2020-07-21 | 2020-11-24 | 1638 |  | 195d |
| 1663 |  | Processo contratação MAS 2 (UTR) - Santo Antônio do Rio Doce/MG | 88d | 2020-05-21 | 2020-09-23 | 1646 |  | 337d |
| 1664 |  | Conclusão da Contratação de Suprimentos das obras de Melhoria do Sistema de Abastecimento de Água - Santo Antônio do Rio Doce/MG | 0d | 2020-11-24 | 2020-11-24 | 1662, 1663 |  | 743d |
| 1665 | 7.3.1.7 | **Infraestrutura** | 624d | 2021-01-12 | 2023-07-14 |  |  | 88d |
| 1666 | 7.3.1.7.1 | **Obras** | 624d | 2021-01-12 | 2023-07-14 |  |  | 88d |
| 1667 |  | Executar Captação Principal (Adutora de Aimorés e expansão do Reservatório) - Santo Antônio do Rio Doce/MG | 300d | 2021-05-05 | 2022-07-14 | 1639, 1655, 1658, 1662 |  | 88d |
| 1668 |  | Executar UTR na ETA de Aimorés/MG - Santo Antônio do Rio Doce/MG | 200d | 2021-01-12 | 2021-10-28 | 1647, 1659, 1663 |  | 264d |
| 1669 |  | Assinatura de Termo de Entrega das Obras de Melhoria do Sistema de Abastecimento de Água - Santo Antônio do Rio Doce | 0d | 2022-07-14 | 2022-07-14 | 1667, 1668, 1652, 1656, 1660, 1664 |  | 336d |
| 1670 |  | Realizar Acompanhamento da Funcionalidade do Sistema - Captação Principal, UTR na ETA de Aimorés - Santo Antônio do Rio Doce (distrito Aimorés/MG) | 365ed | 2022-07-14 | 2023-07-14 | 1675SS |  | 393d |
| 1671 | 7.3.1.7.2 | **Operação** | 61d | 2022-07-14 | 2022-10-12 |  |  | 88d |
| 1672 |  | Realizar Treinamento Operacional do Sistema - Santo Antônio do Rio Doce/MG | 5d | 2022-07-15 | 2022-07-21 | 1667, 1668 |  | 317d |
| 1673 |  | Realizar Testes e Pré-operação - Santo Antônio do Rio Doce/MG | 14d | 2022-07-22 | 2022-08-10 | 1672 |  | 317d |
| 1674 | 7.3.1.7.2.3 | **Operação Assistida** | 61d | 2022-07-14 | 2022-10-12 |  |  | 88d |
| 1675 |  | Realizar Operação Assistida - Santo Antônio do Rio Doce/MG | 90ed | 2022-07-14 | 2022-10-12 | 1667, 1668 |  | 393d |
| 1676 | 7.4 | **Baixo Guandu/ES (sede)** | 1123d | 2017-09-25 A | 2022-03-10 |  | 21% | 423d |
| 1677 | 7.4.1 | **Captação Alternativa** | 915d | 2018-03-23 A | 2021-11-13 |  | 34% | 502d |
| 1678 | 7.4.1.1 | **Estudos de Concepção do Sistema** | 183d | 2018-03-23 A | 2018-12-04 A |  | 100% |  |
| 1679 |  | Declaração de Escopo e Premissas de Projeto (DEPP) concluída - Baixo Guandu/ES | 0d | 2018-03-23 A | 2018-03-23 A | 25, 26 | 100% |  |
| 1680 |  | Aprovação das DEPPs pela Operadora e Prefeitura - Baixo Guandu/ES | 0d | 2018-03-23 A | 2018-03-23 A | 1679 | 100% |  |

| ID | WBS | Task | Duration | Start | Finish | Predecessors | Complete | Total float |
| --- | --- | --- | --- | --- | --- | --- | --- | --- |
| 1681 | 7.4.1.1.3 | **Captação Superficial - rio Guandu** | 1d | 2018-12-04 A | 2018-12-04 A |  | 100% |  |
| 1682 |  | Realizar Laudo dos Serviços de Coleta e Análise de Água - Baixo Guandu/ES | 1d | 2018-12-04 A | 2018-12-04 A | 1679 | 100% |  |
| 1683 |  | Conclusão do Estudo de Concepção da Captação Superficial - Baixo Guandu/ES | 0d | 2018-12-04 A | 2018-12-04 A | 1682 | 100% |  |
| 1684 | 7.4.1.2 | **Engenharia Básica e Detalhada** | 489d | 2018-04-30 A | 2020-04-06 |  | 86% | 534d |
| 1685 | 7.4.1.2.1 | **Engenharia Captação Alternativa (Rio Guandu)** | 489d | 2018-04-30 A | 2020-04-06 |  | 86% | 534d |
| 1686 |  | Aprovação Plano de Trabalho /abertura OSE - Captação Alternativa - Rio Guandu - Baixo Guandu/ES | 29d | 2018-11-05 A | 2018-12-13 A | 1679 | 100% |  |
| 1687 |  | Levantar Dados de Entrada (levantamento de campo, topografia) - Captação Alternativa - Rio Guandu - Baixo Guandu/ES | 142d | 2018-04-30 A | 2018-11-13 A | 1679, 1686 | 100% |  |
| 1688 |  | Realizar sondagem - Captação Alternativa - Rio Guandu - Baixo Guandu/ES | 56d | 2019-03-13 A | 2019-06-03 A | 1687FS+81d | 100% |  |
| 1689 |  | Elaborar arranjo para obtenção de Dados de Entrada Licenciamento e Fundiário - Adequação Adutora - Captação Alternativa - Rio Guandu - Baixo Guandu/ES | 267d | 2018-05-01 A | 2019-05-17 A | 1679 | 100% |  |
| 1690 |  | Emitir RT/PQ para Suprimentos - Adequação Adutora - Captação Alternativa - Rio Guandu - Baixo Guandu/ES | 10d | 2019-09-17 A | 2019-09-30 A | 1691FF | 100% |  |
| 1691 |  | Elaborar Projeto Executivo - Adequação Adutora (SE 32101) - Captação Alternativa - Rio Guandu - Baixo Guandu/ES | 351d | 2018-05-15 A | 2019-09-30 A | 1688FF, 1689SS+10d | 100% |  |
| 1692 |  | Elaborar arranjo para obtenção de Dados de Entrada Licenciamento e Fundiário - Repotenciamento da Elevatória - Captação Alternativa - Rio Guandu - Baixo Guandu/ES | 55d | 2019-05-16 A | 2019-08-01 A | 1687FS+124d | 100% |  |
| 1693 |  | Emitir RT/PQ para Suprimentos - Repotenciamento da Elevatória - Captação Alternativa - Rio Guandu - Baixo Guandu/ES | 10d | 2019-09-17 A | 2019-09-30 A | 1691FF | 100% |  |
| 1694 |  | Elaborar Projeto Executivo - Repotenciamento da Elevatória (SE 32252) - Captação Alternativa - Rio Guandu - Baixo Guandu/ES | 146d | 2019-08-02 A | 2020-03-05 | 1692 | 14% | 534d |
| 1695 |  | Obter aprovação da Operadora/Prefeitura | 22d | 2020-03-06 | 2020-04-06 | 1694 |  | 534d |
| 1696 |  | Elaboração do Projeto Executivo - Captação Alternativa - Rio Guandu - Baixo Guandu/ES | 0d | 2020-04-06 | 2020-04-06 | 1691, 1692, 1695 |  | 534d |
| 1697 | 7.4.1.3 | **Fundiária** | 191d | 2019-08-16 A | 2020-05-25 |  | 10% | 870d |
| 1698 | 7.4.1.3.1 | **Captação Alternativa - Adutora Rio Guandu - Desimpedimento da Área e Negociação de Servidão** | 191d | 2019-08-16 A | 2020-05-25 |  | 10% | 502d |
| 1699 |  | Realizar Levantamento da documentação da propriedade - Cadastro dos proprietários - Baixo Guandu/ES | 75d | 2019-08-16 A | 2019-11-29 | 1689FS+62d | 25% | 502d |
| 1700 |  | Obter laudo de Avaliação - Baixo Guandu/ES | 22d | 2019-12-02 | 2020-01-06 | 1699 |  | 502d |
| 1701 |  | Obter assinatura do Contrato de servidão pelo proprietário - Baixo Guandu/ES | 44d | 2020-01-07 | 2020-03-11 | 1700 |  | 502d |
| 1702 |  | Lavrar Escritura Pública de Servidão no cartório de notas - Baixo Guandu/ES | 30d | 2020-03-12 | 2020-04-24 | 1701 |  | 502d |
| 1703 |  | Averbar a escritura pública na matrícula do imóvel - Baixo Guandu/ES | 20d | 2020-04-27 | 2020-05-25 | 1702 |  | 502d |
| 1704 |  | Regularização da Servidão do imóvel - Adutora rio Guandu - Baixo Guandu/ES | 0d | 2020-05-25 | 2020-05-25 | 1703 |  | 502d |
| 1705 |  | Conclusão da Regularização Fundiária para as obras de Melhoria do Sistema de Abastecimento - Baixo Gandu/ES | 0d | 2020-05-25 | 2020-05-25 | 1704 |  | 870d |
| 1706 | 7.4.1.4 | **Licenciamento** | 180d | 2019-08-01 A | 2020-04-23 |  | 26% | 891d |
| 1707 |  | Captação Alternativa - Outorga para captação e Autorizações - Baixo Guandu/ES | 180d | 2019-08-01 A | 2020-04-23 |  | 26% | 523d |
| 1708 |  | Conclusão do Licenciamento Ambiental da Localidade - Baixo Gandu/ES | 0d | 2020-04-23 | 2020-04-23 | 1707 |  | 891d |
| 1709 | 7.4.1.5 | **Suprimentos** | 88d | 2019-10-01 A | 2020-02-06 |  | 26% | 941d |
| 1710 |  | Realizar processo de contratação - Adequação Adutora Rio Guandu e Repotenciamento da Elevatória - Baixo Guandu/ES | 88d | 2019-10-01 A | 2020-02-06 | 1690, 1693 | 26% | 573d |
| 1711 |  | Conclusão da Contratação de Suprimentos das obras de Melhoria do Sistema de Abastecimento de Água - Baixo Gandu/ES | 0d | 2020-02-06 | 2020-02-06 | 1710 |  | 941d |
| 1712 | 7.4.1.6 | **Infraestrutura** | 368d | 2020-05-26 | 2021-11-13 |  |  | 502d |
| 1713 | 7.4.1.6.1 | **Obras** | 120d | 2020-05-26 | 2020-11-13 |  |  | 502d |
| 1714 |  | Executar Captação Alternativa (rio Guandu) - Baixo Guandu/ES | 120d | 2020-05-26 | 2020-11-13 | 1691, 1694, 1696, 1704, 1707, 1710 |  | 502d |
| 1715 |  | Assinatura de Termo de Entrega das Obras de Melhoria do Sistema de Abastecimento de Água - Baixo Guandu/ES | 0d | 2020-11-13 | 2020-11-13 | 1714, 1705, 1708, 1711 |  | 750d |
| 1716 | 7.4.1.6.2 | **Operação** | 248d | 2020-11-13 | 2021-11-13 |  |  | 502d |
| 1717 |  | Realizar Treinamento Operacional do Sistema - Baixo Guandu/ES | 5d | 2020-11-16 | 2020-11-20 | 1714 |  | 731d |
| 1718 |  | Realizar Testes e Pré-operação - Baixo Guandu/ES | 14d | 2020-11-23 | 2020-12-10 | 1717 |  | 731d |
| 1719 |  | Realizar Acompanhamento da Funcionalidade do Sistema - Captação Alternativa - Baixo Guandu/ES (sede) | 365ed | 2020-11-13 | 2021-11-13 | 1721SS |  | 2217d |
| 1720 | 7.4.1.6.2.4 | **Operação Assistida** | 61d | 2020-11-13 | 2021-02-11 |  |  | 502d |
| 1721 |  | Realizar Operação Assistida - Baixo Guandu/ES | 90ed | 2020-11-13 | 2021-02-11 | 1714 |  | 2217d |
| 1722 | 7.4.2 | **Melhorias na ETA** | 999d | 2017-09-25 A | 2021-09-08 |  | 10% | 547d |
| 1723 | 7.4.2.1 | **Estudos de Concepção do Sistema** | 312d | 2017-09-25 A | 2018-12-04 A |  | 100% |  |
| 1724 |  | Declaração de Escopo e Premissas de Projeto (DEPP) concluída - Baixo Guandu/ES | 0d | 2018-03-23 A | 2018-03-23 A | 25, 26 | 100% |  |
| 1725 |  | Aprovação das DEPPs pela Operadora e Prefeitura - Baixo Guandu/ES | 0d | 2017-09-25 A | 2017-09-25 A | 25, 26 | 100% |  |
| 1726 |  | Conclusão dos Estudos de Concepção das Melhorias do Sistema de Abastecimento de Água - Baixo Gandu/ES | 0d | 2018-12-04 A | 2018-12-04 A | 1725 | 100% |  |
| 1727 | 7.4.2.2 | **Engenharia Básica e Detalhada** | 204d | 2018-09-06 A | 2019-06-28 A |  | 100% |  |
| 1728 | 7.4.2.2.1 | **Engenharia Pequenas Melhorias na ETA existente** | 204d | 2018-09-06 A | 2019-06-28 A |  | 100% |  |
| 1729 |  | Aprovação Plano de Trabalho /abertura OSE - Melhorias na ETA - Baixo Guandu/ES | 8d | 2018-09-06 A | 2018-09-17 A | 1724 | 100% |  |
| 1730 |  | Dados de Entrada (levantamento de campo, topografia, sondagem e DR equipamento) - Melhorias na ETA - Baixo Guandu/ES | 12d | 2018-10-11 A | 2018-10-26 A | 1729 | 100% |  |
| 1731 |  | Elaborar arranjo para obtenção de Dados de Entrada Licenciamento e Fundiário - Melhorias na ETA - Baixo Guandu/ES | 33d | 2018-10-31 A | 2018-12-14 A | 1730SS+65d | 100% |  |
| 1732 |  | Emitir RT/PQ para Suprimentos - Melhorias na ETA - Baixo Guandu/ES | 10d | 2019-06-14 A | 2019-06-28 A | 1733FF | 100% |  |
| 1733 |  | Elaborar Projeto Executivo - Melhorias na ETA - Baixo Guandu/ES | 98d | 2019-02-04 A | 2019-06-28 A | 1731 | 100% |  |
| 1734 |  | Elaboração do Projeto Executivo - Melhorias na ETA - Baixo Guandu/ES | 0d | 2019-06-28 A | 2019-06-28 A | 1733 | 100% |  |
| 1735 | 7.4.2.3 | **Suprimentos** | 88d | 2019-10-01 A | 2020-02-06 |  | 26% | 941d |
| 1736 |  | Realizar processo de contratação - Adequação Adutora Rio Guandu e Repotenciamento da Elevatória - Baixo Guandu/ES | 88d | 2019-10-01 A | 2020-02-06 |  | 26% | 548d |
| 1737 |  | Conclusão da Contratação de Suprimentos das obras de Melhoria do Sistema de Abastecimento de Água - Baixo Gandu/ES | 0d | 2020-02-06 | 2020-02-06 | 1736 |  | 941d |
| 1738 | 7.4.2.4 | **Infraestrutura** | 394d | 2020-02-07 | 2021-09-08 |  |  | 547d |
| 1739 | 7.4.2.4.1 | **Obras** | 145d | 2020-02-07 | 2020-09-08 |  |  | 548d |
| 1740 |  | Executar Melhorias de ETA e Melhorias na Captação Principal - Baixo Guandu/ES | 145d | 2020-02-07 | 2020-09-08 | 1733, 1736 |  | 548d |
| 1741 |  | Assinatura de Termo de Entrega das Obras de Melhoria do Sistema de Abastecimento de Água - Baixo Guandu/ES | 0d | 2020-09-08 | 2020-09-08 | 1740, 1737 |  | 796d |
| 1742 | 7.4.2.4.2 | **Operação** | 249d | 2020-09-08 | 2021-09-08 |  |  | 547d |
| 1743 |  | Realizar Treinamento Operacional do Sistema - Baixo Guandu/ES | 5d | 2020-09-09 | 2020-09-15 | 1740 |  | 777d |
| 1744 |  | Realizar Testes e Pré-operação - Baixo Guandu/ES | 14d | 2020-09-16 | 2020-10-05 | 1743 |  | 777d |
| 1745 |  | Realizar Acompanhamento da Funcionalidade do Sistema - Melhorias na ETA - Baixo Guandu/ES (sede) | 365ed | 2020-09-08 | 2021-09-08 | 1747SS |  | 2415d |
| 1746 | 7.4.2.4.2.4 | **Operação Assistida** | 62d | 2020-09-08 | 2020-12-07 |  |  | 548d |
| 1747 |  | Realizar Operação Assistida - Baixo Guandu/ES | 90ed | 2020-09-08 | 2020-12-07 | 1740 |  | 2415d |
| 1748 | 7.4.3 | **Nova ETA e UTR** | 875d | 2018-09-06 A | 2022-03-10 |  | 11% | 423d |
| 1749 | 7.4.3.1 | **Estudos de Concepção do Sistema** | 121d | 2018-12-04 A | 2019-05-31 A |  | 100% |  |
| 1750 | 7.4.3.1.1 | **Coleta e Análise do Lodo de ETA** | 7d | 2019-05-23 A | 2019-05-31 A |  | 100% |  |

| ID | WBS | Task | Duration | Start | Finish | Predecessors | Complete | Total float |
| --- | --- | --- | --- | --- | --- | --- | --- | --- |
| 1751 |  | Executar Coleta e Análise do Lodo de ETA - Baixo Guandu/ES | 7d | 2019-05-23 A | 2019-05-31 A |  | 100% |  |
| 1752 |  | Conclusão das Coletas e Análises de Lodo de ETA - Baixo Guandu/ES | 0d | 2019-05-31 A | 2019-05-31 A | 1751 | 100% |  |
| 1753 |  | Conclusão dos Estudos de Concepção das Melhorias do Sistema de Abastecimento de Água - Baixo Gandu/ES | 0d | 2018-12-04 A | 2018-12-04 A |  | 100% |  |
| 1754 | 7.4.3.2 | **Engenharia Básica e Detalhada** | 377d | 2018-09-06 A | 2020-03-10 |  | 46% | 921d |
| 1755 | 7.4.3.2.1 | **Engenharia Nova ETA e UTR** | 377d | 2018-09-06 A | 2020-03-10 |  | 46% | 921d |
| 1756 |  | Aprovação Plano de Trabalho /abertura OSE - Nova ETA/UTR - Baixo Guandu/ES | 8d | 2018-09-06 A | 2018-09-17 A |  | 100% |  |
| 1757 |  | Dados de Entrada (levantamento de campo, topografia e DR equipamento) - Nova ETA/UTR - Baixo Guandu/ES | 65d | 2018-09-18 A | 2018-12-17 A | 1756 | 100% |  |
| 1758 |  | Realizar sondagem - Nova ETA/UTR - Baixo Guandu/ES | 15d | 2019-03-08 A | 2019-03-28 A | 1756, 1759 | 100% |  |
| 1759 |  | Elaborar arranjo para obtenção de Dados de Entrada Licenciamento e Fundiário - Nova ETA/UTR - Baixo Guandu/ES | 54d | 2018-12-18 A | 2019-03-07 A | 1757SS+65d | 100% |  |
| 1760 |  | Elaborar Projeto Básico - Nova ETA/UTR - Baixo Guandu/ES | 45d | 2019-09-12 A | 2019-11-13 | 1759FS+129d | 45% | 997d |
| 1761 |  | Emitir RT/PQ para Suprimentos - Nova ETA/UTR - Baixo Guandu/ES | 10d | 2020-02-21 | 2020-03-10 | 1764FF |  | 425d |
| 1762 |  | Elaborar Projeto Executivo - Nova ETA/UTR - Baixo Guandu/ES | 228d | 2019-03-08 A | 2020-02-04 | 1752FF, 1758FF, 1759 | 20% | 425d |
| 1763 |  | Obter aprovação da Operadora/Prefeitura | 22d | 2020-02-05 | 2020-03-10 | 1762 |  | 425d |
| 1764 |  | Elaboração do Projeto Executivo - Nova ETA/UTR - Baixo Guandu/ES | 0d | 2020-03-10 | 2020-03-10 | 1763 |  | 425d |
| 1765 | 7.4.3.3 | **Licenciamento** | 192d | 2019-09-05 A | 2020-06-16 |  | 21% | 855d |
| 1766 |  | Nova ETA - Licenças e Autorizações - Baixo Guandu/ES | 192d | 2019-09-05 A | 2020-06-16 | 1759FS+124d | 21% | 447d |
| 1767 |  | Conclusão do Licenciamento Ambiental da Localidade - Baixo Gandu/ES | 0d | 2020-06-16 | 2020-06-16 | 1766 |  | 855d |
| 1768 | 7.4.3.4 | **Suprimentos** | 88d | 2020-03-11 | 2020-07-16 |  |  | 425d |
| 1769 |  | Realizar processo contratação da obra - ETA e UTR - Baixo Guandu/ES | 88d | 2020-03-11 | 2020-07-16 | 1761 |  | 425d |
| 1770 |  | Conclusão da Contratação de Suprimentos das obras de Melhoria do Sistema de Abastecimento de Água - Baixo Gandu/ES | 0d | 2020-07-16 | 2020-07-16 | 1769 |  | 833d |
| 1771 | 7.4.3.5 | **Infraestrutura** | 410d | 2020-07-17 | 2022-03-10 |  |  | 423d |
| 1772 | 7.4.3.5.1 | **Obras** | 160d | 2020-07-17 | 2021-03-10 |  |  | 425d |
| 1773 |  | Executar Nova ETA e UTR - Baixo Guandu/ES | 160d | 2020-07-17 | 2021-03-10 | 1769, 1766, 1764 |  | 425d |
| 1774 |  | Assinatura de Termo de Entrega das Obras de Melhoria do Sistema de Abastecimento de Água - Baixo Guandu/ES | 0d | 2021-03-10 | 2021-03-10 | 1773, 1767, 1770 |  | 673d |
| 1775 | 7.4.3.5.2 | **Operação** | 250d | 2021-03-10 | 2022-03-10 |  |  | 423d |
| 1776 |  | Realizar Treinamento Operacional do Sistema - Baixo Guandu/ES | 5d | 2021-03-11 | 2021-03-17 | 1773 |  | 654d |
| 1777 |  | Realizar Testes e Pré-operação - Baixo Guandu/ES | 14d | 2021-03-18 | 2021-04-07 | 1776 |  | 654d |
| 1778 |  | Realizar Acompanhamento da Funcionalidade do Sistema - Nova ETA e UTR - Baixo Guandu/ES (sede) | 365ed | 2021-03-10 | 2022-03-10 | 1780SS |  | 1866d |
| 1779 | 7.4.3.5.2.4 | **Operação Assistida** | 61d | 2021-03-10 | 2021-06-08 |  |  | 425d |
| 1780 |  | Realizar Operação Assistida - Baixo Guandu/ES | 90ed | 2021-03-10 | 2021-06-08 | 1773 |  | 1866d |
| 1781 | 7.5 | **Mascarenhas (distrito Baixo Guandu/ES)** | 1099d | 2017-09-25 A | 2022-02-01 |  | 27% | 447d |
| 1782 | 7.5.1 | **Adutora de Água Tratada de Baixo Guandu** | 1099d | 2017-09-25 A | 2022-02-01 |  | 27% | 447d |
| 1783 | 7.5.1.1 | **Estudos de Concepção do Sistema** | 195d | 2017-09-25 A | 2018-06-22 A |  | 100% |  |
| 1784 |  | Declaração de Escopo e Premissas de Projeto (DEPP) concluída - Mascarenhas/ES | 0d | 2018-03-23 A | 2018-03-23 A | 25, 26 | 100% |  |
| 1785 |  | Aprovação das DEPPs pela Operadora e Prefeitura - Mascarenhas/ES | 0d | 2017-09-25 A | 2017-09-25 A | 25, 26 | 100% |  |
| 1786 | 7.5.1.1.3 | **Serviços em Poços Tubulares** | 24d | 2018-05-22 A | 2018-06-22 A |  | 100% |  |
| 1787 |  | Realizar Tamponamento - Mascarenhas/ES | 1d | 2018-05-22 A | 2018-05-22 A | 1784 | 100% |  |
| 1788 |  | Elaborar Relatório Técnico - Mascarenhas/ES | 23d | 2018-05-23 A | 2018-06-22 A | 1787 | 100% |  |
| 1789 |  | Conclusão dos Serviços em poço tubular - Mascarenhas/ES | 0d | 2018-06-22 A | 2018-06-22 A | 1788 | 100% |  |
| 1790 |  | Conclusão dos Estudos de Concepção das Melhorias do Sistema de Abastecimento de Água - Mascarenhas/ES | 0d | 2018-06-22 A | 2018-06-22 A | 1789 | 100% |  |
| 1791 | 7.5.1.2 | **Engenharia Básica e Detalhada** | 488d | 2018-03-22 A | 2020-02-21 |  | 84% | 930d |
| 1792 | 7.5.1.2.1 | **Engenharia Adutora Água Tratada (ETA Baixo Guandu até reservatório em Mascarenhas) - SE 32085** | 468d | 2018-03-22 A | 2020-01-24 |  | 86% | 1.87d |
| 1793 |  | Aprovação Plano de Trabalho /abertura OSE + Levantamento de campo - Adutora de Água Tratada - Mascarenhas/ES | 167d | 2018-03-22 A | 2018-11-09 A | 26 | 100% |  |
| 1794 |  | Executar Topografia - Adutora de Água Tratada - Mascarenhas/ES | 11d | 2018-11-27 A | 2018-12-11 A | 1793FS+11d | 100% |  |
| 1795 |  | Realizar sondagem - Adutora de Água Tratada - Mascarenhas/ES | 3d | 2019-11-13 | 2019-11-18 | 1793FS+253d |  | 24.87d |
| 1796 |  | Elaborar arranjo para obtenção de Dados de Entrada Licenciamento e Fundiário - Adutora de Água Tratada - Mascarenhas/ES | 264d | 2018-04-16 A | 2019-04-26 A | 1793SS | 100% |  |
| 1797 |  | Emitir RT/PQ para Suprimentos - Adutora de Água Tratada - Mascarenhas/ES | 10d | 2019-08-28 A | 2019-09-10 A | 1800FF-60d | 100% |  |
| 1798 |  | Elaborar Projeto Executivo - Adutora de Água Tratada - Mascarenhas/ES | 264d | 2018-12-03 A | 2019-12-20 | 1793, 1794FS-50d, 1795FF | 70% | 1.87d |
| 1799 |  | Obter Aprovação da Operadora e Prefeitura | 22d | 2019-12-23 | 2020-01-24 | 1798 |  | 1.87d |
| 1800 |  | Elaboração do Projeto Executivo - Adutora de Água Tratada - Mascarenhas/ES | 0d | 2020-01-24 | 2020-01-24 | 1799 |  | 1.87d |
| 1801 | 7.5.1.2.2 | **Validação dos Projetos** | 20d | 2020-01-27 | 2020-02-21 |  |  | 930d |
| 1802 |  | Validar Projetos com Prefeitura e Operadora - Mascarenhas/ES | 20d | 2020-01-27 | 2020-02-21 | 1800 |  | 930d |
| 1803 |  | Validação com Prefeitura e Operadora dos Projetos de Melhoria do Sistema de Abastecimento de Água - Mascarenhas/ES | 0d | 2020-02-21 | 2020-02-21 | 1800, 1802 |  | 930d |
| 1804 | 7.5.1.3 | **Fundiária** | 210d | 2019-08-16 A | 2020-06-22 |  | 23% | 851d |
| 1805 |  | Obter Termos de Autorização de Superficiário e Desimpedimento da Área - Adutora Água Tratada da ETA de Baixo Guandu ao reservatório em Mascarenhas/ES | 210d | 2019-08-16 A | 2020-06-22 | 1796FS+76d | 23% | 453d |
| 1806 |  | Conclusão da Regularização Fundiária para as obras de Melhoria do Sistema de Abastecimento - Mascarenhas/ES | 0d | 2020-06-22 | 2020-06-22 | 1805 |  | 851d |
| 1807 | 7.5.1.4 | **Licenciamento** | 200d | 2019-09-05 A | 2020-06-26 |  | 12% | 847d |
| 1808 |  | Licenciamento e autorização para construção - Adutora Água Tratada (da ETA de Baixo Guandu até reservatório em Mascarenhas) | 200d | 2019-09-05 A | 2020-06-26 | 1796, 1800FS-75d | 12% | 449d |
| 1809 |  | Conclusão do Licenciamento Ambiental da Localidade - Mascarenhas/ES | 0d | 2020-06-26 | 2020-06-26 | 1808 |  | 847d |
| 1810 | 7.5.1.5 | **Suprimentos** | 102d | 2019-09-10 A | 2020-02-06 |  | 29% | 941d |
| 1811 | 7.5.1.5.1 | **Processo contratação MAS 1 (Adutora)** | 102d | 2019-09-10 A | 2020-02-06 |  | 29% | 941d |
| 1812 |  | Recebimento da RT/PQ pelo Suprimentos - Mascarenhas/ES | 0d | 2019-09-10 A | 2019-09-10 A | 1797 | 100% |  |
| 1813 |  | Realizar Entendimento da Demanda - Mascarenhas/ES | 10d | 2019-09-11 A | 2019-09-24 A | 1812 | 100% |  |
| 1814 |  | Abrir a RC - Mascarenhas/ES | 8d | 2019-09-25 A | 2019-10-04 A | 1813 | 100% |  |
| 1815 |  | Aprovar a RC (liberação) - Mascarenhas/ES | 8d | 2019-10-07 A | 2019-10-16 A | 1814 | 100% |  |
| 1816 |  | Prospectar fornecedores e receber proposta técnicas - Mascarenhas/ES | 13d | 2019-10-17 A | 2019-11-04 | 1815 | 25% | 543d |
| 1817 |  | Aprovar proposta técnica - Mascarenhas/ES | 14d | 2019-11-05 | 2019-11-25 | 1816 |  | 543d |
| 1818 |  | Realizar negociação e aprovar o pedido - Mascarenhas/ES | 49d | 2019-11-26 | 2020-02-06 | 1817 |  | 543d |
| 1819 |  | Conclusão da Contratação de Suprimentos - Adutora - Mascarenhas/ES | 0d | 2020-02-06 | 2020-02-06 | 1818 |  | 941d |
| 1820 |  | Conclusão da Contratação de Suprimentos das obras de Melhoria do Sistema de Abastecimento de Água - Mascarenhas/ES | 0d | 2020-02-06 | 2020-02-06 | 1819 |  | 941d |

| ID | WBS | Task | Duration | Start | Finish | Predecessors | Complete | Total float |
| --- | --- | --- | --- | --- | --- | --- | --- | --- |
| 1821 | 7.5.1.6 | **Infraestrutura** | 400d | 2020-06-29 | 2022-02-01 |  |  | 447d |
| 1822 | 7.5.1.6.1 | **Obras** | 150d | 2020-06-29 | 2021-02-01 |  |  | 449d |
| 1823 |  | Executar Captação Principal (adutora de água tratada de 11km da ETA de B-G até reservatório Mascarenhas) | 150d | 2020-06-29 | 2021-02-01 | 1805, 1808, 1818, 1800 |  | 449d |
| 1824 |  | Assinatura de Termo de Entrega das Obras de Melhoria do Sistema de Abastecimento de Água - Mascarenhas/ES | 0d | 2021-02-01 | 2021-02-01 | 1823, 1803, 1806, 1809, 1820 |  | 697d |
| 1825 | 7.5.1.6.2 | **Operação** | 250d | 2021-02-01 | 2022-02-01 |  |  | 447d |
| 1826 |  | Realizar Treinamento Operacional do Sistema - Mascarenhas/ES | 5d | 2021-02-02 | 2021-02-08 | 1823 |  | 678d |
| 1827 |  | Realizar Testes e Pré-operação - Mascarenhas/ES | 14d | 2021-02-09 | 2021-03-03 | 1826 |  | 678d |
| 1828 |  | Realizar Acompanhamento da Funcionalidade do Sistema - Adutora de Água Tratada de Baixo Guandu - Mascarenhas (distrito Baixo Guandu/ES) | 365ed | 2021-02-01 | 2022-02-01 | 1830SS |  | 1977d |
| 1829 | 7.5.1.6.2.4 | **Operação Assistida** | 59d | 2021-02-01 | 2021-05-02 |  |  | 449d |
| 1830 |  | Realizar Operação Assistida - Mascarenhas/ES | 90ed | 2021-02-01 | 2021-05-02 | 1823 |  | 1977d |
| 1831 | 7.6 | **Colatina/ES (sede)** | 1164d | 2018-08-07 A | 2023-04-05 |  | 5% | 156d |
| 1832 | 7.6.1 | **UTR - ETA Marista** | 1164d | 2018-08-07 A | 2023-04-05 |  | 5% | 156d |
| 1833 | 7.6.1.1 | **Engenharia Básica e Detalhada** | 213d | 2019-11-04 | 2020-09-14 |  |  | 157d |
| 1834 | 7.6.1.1.1 | **Engenharia UTR (ETA Marista) - SE 32257** | 213d | 2019-11-04 | 2020-09-14 |  |  | 157d |
| 1835 |  | Aprovação Plano de Trabalho /abertura OSE - UTR - ETA Marista - Colatina/ES | 15d | 2019-11-04 | 2019-11-25 | 24FS+949d |  | 157d |
| 1836 |  | Realizar Levantamento de Campo (Sondagem, Topografia) - UTR - ETA Marista - Colatina/ES | 41d | 2019-11-26 | 2020-01-27 | 1835 |  | 196d |
| 1837 |  | Elaborar projeto Conceitual (Dados de Entrada Licenciamento e Fundiário) - UTR - ETA Marista - Colatina/ES | 80d | 2019-11-26 | 2020-03-25 | 1835, 1836FF |  | 157d |
| 1838 |  | Elaborar Projeto Básico - UTR - ETA Marista - Colatina/ES | 75d | 2020-03-26 | 2020-07-14 | 1837 |  | 157d |
| 1839 |  | Obter Aprovação do projeto Básico com Prefeitura/Operadora- UTR - ETA Marista - Colatina/ES | 22d | 2020-07-15 | 2020-08-13 | 1838 |  | 157d |
| 1840 |  | Emitir RT/PQ para Suprimentos - UTR - ETA Marista - Colatina/ES | 18d | 2020-08-14 | 2020-09-09 | 1838, 1839 |  | 157d |
| 1841 |  | Elaborar Projeto Executivo - UTR - ETA Marista - Colatina/ES | 68d | 2020-06-09 | 2020-09-14 | 1838FS-25d |  | 294d |
| 1842 |  | Elaboração do Projeto Executivo - UTR - ETA Marista - Colatina/ES | 0d | 2020-09-14 | 2020-09-14 | 1841 |  | 294d |
| 1843 | 7.6.1.2 | **Fundiária** | 705d | 2018-08-07 A | 2021-06-02 |  | 23% | 615d |
| 1844 |  | Obter Termos de Autorização de Superficiário - UTRs - Imóveis 1, 2 e 4 (Marista, Aparecida e Columbia) - Colatina/ES | 349d | 2018-08-07 A | 2019-12-23 | 24 | 34% | 473d |
| 1845 |  | Realizar Negociação da Servidão do Imóvel - UTR Marista - Colatina/ES | 180d | 2020-09-10 | 2021-06-02 | 1840 |  | 157d |
| 1846 |  | Conclusão da Regularização Fundiária para as obras de Melhoria do Sistema de Abastecimento da Localidade - Colatina/ES | 0d | 2021-06-02 | 2021-06-02 | 1844, 1845 |  | 615d |
| 1847 | 7.6.1.3 | **Suprimentos** | 88d | 2020-09-10 | 2021-01-18 |  |  | 209d |
| 1848 |  | Suprimentos - Processo contratação UTRs - Colatina/ES | 88d | 2020-09-10 | 2021-01-18 | 1840 |  | 209d |
| 1849 |  | Conclusão da Contratação de Suprimentos das obras de Melhoria do Sistema de Abastecimento de Água - Colatina/ES | 0d | 2021-01-18 | 2021-01-18 | 1848 |  | 707d |
| 1850 | 7.6.1.4 | **Infraestrutura** | 499d | 2021-04-07 | 2023-04-05 |  |  | 156d |
| 1851 | 7.6.1.4.1 | **Obras** | 250d | 2021-04-07 | 2022-04-05 |  |  | 157d |
| 1852 |  | Executar UTR (ETA Marista 250L/s) - Colatina/ES | 250d | 2021-04-07 | 2022-04-05 | 1842, 1844, 1845FS-40d, 1848 |  | 157d |
| 1853 |  | Assinatura de Termo de Entrega das Obras de Melhoria do Sistema de Abastecimento de Água - Colatina/ES | 0d | 2022-04-05 | 2022-04-05 | 1852, 1846, 1849 |  | 405d |
| 1854 | 7.6.1.4.2 | **Operação** | 249d | 2022-04-05 | 2023-04-05 |  |  | 156d |
| 1855 |  | Realizar Treinamento Operacional do Sistema - Colatina/ES | 5d | 2022-04-06 | 2022-04-12 | 1852 |  | 386d |
| 1856 |  | Realizar Testes e Pré-operação - Colatina/ES | 14d | 2022-04-13 | 2022-05-04 | 1855 |  | 386d |
| 1857 |  | Realizar Acompanhamento da Funcionalidade do Sistema - UTR - ETA Marista - Colatina/ES (sede) | 365ed | 2022-04-05 | 2023-04-05 | 1859SS |  | 693d |
| 1858 | 7.6.1.4.2.4 | **Operação Assistida** | 61d | 2022-04-05 | 2022-07-04 |  |  | 157d |
| 1859 |  | Realizar Operação Assistida - Colatina/ES | 90ed | 2022-04-05 | 2022-07-04 | 1852 |  | 693d |
| 1860 | 7.6.2 | **UTR - ETA Aparecida** | 1104d | 2018-08-07 A | 2023-01-06 |  | 5% | 216d |
| 1861 | 7.6.2.1 | **Engenharia** | 232d | 2019-11-04 | 2020-10-09 |  |  | 217d |
| 1862 | 7.6.2.1.1 | **Engenharia Básica e Detalhada** | 232d | 2019-11-04 | 2020-10-09 |  |  | 217d |
| 1863 | 7.6.2.1.1.1 | **Engenharia UTR (ETA Aparecida) - SE 32256** | 232d | 2019-11-04 | 2020-10-09 |  |  | 217d |
| 1864 |  | Aprovação Plano de Trabalho /abertura OSE - UTR - ETA Aparecida - Colatina/ES | 15d | 2019-11-04 | 2019-11-25 | 24FS+949d |  | 217d |
| 1865 |  | Realizar levantamento de Campo e Sondagem - UTR - ETA Aparecida - Colatina/ES | 41d | 2019-11-26 | 2020-01-27 | 1864 |  | 256d |
| 1866 |  | Elaborar projeto Conceitual (Dados de Entrada Licenciamento e Fundiário) - UTR - Aparecida - Colatina/ES | 80d | 2019-11-26 | 2020-03-25 | 1864, 1865FF |  | 217d |
| 1867 |  | Elaborar Projeto Básico - UTR - ETA Aparecida - Colatina/ES | 72d | 2020-03-26 | 2020-07-09 | 1866 |  | 217d |
| 1868 |  | Obter Aprovação do projeto Básico com Prefeitura/Operadora - UTR - ETA Aparecida - Colatina/ES | 22d | 2020-07-10 | 2020-08-10 | 1867 |  | 217d |
| 1869 |  | Emitir RT/PQ para Suprimentos - UTR - ETA Aparecida - Colatina/ES | 13d | 2020-08-11 | 2020-08-27 | 1868 |  | 217d |
| 1870 |  | Elaborar Projeto Executivo - UTR - ETA Aparecida - Colatina/ES | 68d | 2020-07-07 | 2020-10-09 | 1868FS-25d |  | 275d |
| 1871 |  | Elaboração do Projeto Executivo - UTR - ETA Aparecida - Colatina/ES | 0d | 2020-10-09 | 2020-10-09 | 1870 |  | 275d |
| 1872 | 7.6.2.2 | **Fundiária** | 590d | 2018-08-07 A | 2020-12-11 |  | 23% | 730d |
| 1873 |  | Obter Termos de Autorização de Superficiário - UTRs - Imóveis 1, 2 e 4 (Marista, Aparecida e Columbia) - Colatina/ES | 349d | 2018-08-07 A | 2019-12-23 |  | 34% | 473d |
| 1874 |  | Realizar Negociação da Servidão do Imóvel - UTR Aparecida - Colatina/ES | 180d | 2020-03-26 | 2020-12-11 | 1866 |  | 272d |
| 1875 |  | Conclusão da Regularização Fundiária para as obras de Melhoria do Sistema de Abastecimento da Localidade - Colatina/ES | 0d | 2020-12-11 | 2020-12-11 | 1873, 1874 |  | 730d |
| 1876 | 7.6.2.3 | **Suprimentos** | 88d | 2020-08-28 | 2021-01-06 |  |  | 217d |
| 1877 |  | Suprimentos - Processo contratação UTRs - Colatina/ES | 88d | 2020-08-28 | 2021-01-06 | 1869 |  | 217d |
| 1878 |  | Conclusão da Contratação de Suprimentos das obras de Melhoria do Sistema de Abastecimento de Água - Colatina/ES | 0d | 2021-01-06 | 2021-01-06 | 1877 |  | 715d |
| 1879 | 7.6.2.4 | **Infraestrutura** | 499d | 2021-01-07 | 2023-01-06 |  |  | 216d |
| 1880 | 7.6.2.4.1 | **Obras** | 250d | 2021-01-07 | 2022-01-06 |  |  | 217d |
| 1881 |  | Executar UTR (ETA Aparecida 250L/s) - Colatina/ES | 250d | 2021-01-07 | 2022-01-06 | 1871, 1873, 1874FS-40d, 1877 |  | 217d |
| 1882 |  | Assinatura de Termo de Entrega das Obras de Melhoria do Sistema de Abastecimento de Água - Colatina/ES | 0d | 2022-01-06 | 2022-01-06 | 1881, 1875, 1878 |  | 465d |
| 1883 | 7.6.2.4.2 | **Operação** | 249d | 2022-01-06 | 2023-01-06 |  |  | 216d |
| 1884 |  | Realizar Treinamento Operacional do Sistema - Colatina/ES | 5d | 2022-01-07 | 2022-01-13 | 1881 |  | 446d |
| 1885 |  | Realizar Testes e Pré-operação - Colatina/ES | 14d | 2022-01-14 | 2022-02-02 | 1884 |  | 446d |
| 1886 |  | Realizar Acompanhamento da Funcionalidade do Sistema - UTR - ETA Aparecida - Colatina/ES (sede) | 365ed | 2022-01-06 | 2023-01-06 | 1888SS |  | 960d |
| 1887 | 7.6.2.4.2.4 | **Operação Assistida** | 61d | 2022-01-06 | 2022-04-06 |  |  | 217d |
| 1888 |  | Realizar Operação Assistida - Colatina/ES | 90ed | 2022-01-06 | 2022-04-06 | 1881 |  | 960d |
| 1889 | 7.6.3 | **UTR - ETA Columbia** | 1002d | 2018-08-07 A | 2022-08-09 |  | 5% | 318d |
| 1890 | 7.6.3.1 | **Engenharia Básica e Detalhada** | 177d | 2020-03-02 | 2020-11-12 |  |  | 320d |

| ID | WBS | Task | Duration | Start | Finish | Predecessors | Complete | Total float |
| --- | --- | --- | --- | --- | --- | --- | --- | --- |
| 1891 | 7.6.3.1.1 | **Engenharia UTR (ETA Columbia) - SE 32258** | 177d | 2020-03-02 | 2020-11-12 |  |  | 320d |
| 1892 |  | Aprovação Plano de Trabalho /abertura OSE - UTR - ETA Columbia - Colatina/ES | 15d | 2020-03-02 | 2020-03-20 | 24FS+1026d |  | 320d |
| 1893 |  | Realizar levantamento de Campo e Sondagem - UTR - ETA Columbia - Colatina/ES | 36d | 2020-03-23 | 2020-05-14 | 1892 |  | 354d |
| 1894 |  | Elaborar Projeto Conceitual (Dados de Entrada Licenciamento e Fundiário) - UTR - ETA Columbia - Colatina/ES | 65d | 2020-03-30 | 2020-07-02 | 1892FS+5d, 1893FF |  | 320d |
| 1895 |  | Elaborar Projeto Básico - UTR - ETA Columbia - Colatina/ES | 55d | 2020-06-19 | 2020-09-03 | 1894FS-10d |  | 320d |
| 1896 |  | Obter Aprovação do projeto Básico com Prefeitura/Operadora - UTR - ETA Columbia - Colatina/ES | 22d | 2020-09-04 | 2020-10-06 | 1895 |  | 320d |
| 1897 |  | Emitir RT/PQ para Suprimentos - UTR - ETA Columbia - Colatina/ES | 10d | 2020-10-07 | 2020-10-21 | 1896 |  | 320d |
| 1898 |  | Elaborar Projeto Executivo - UTR - ETA Columbia - Colatina/ES | 51d | 2020-08-31 | 2020-11-12 | 1896FS-26d |  | 393d |
| 1899 |  | Elaboração do Projeto Executivo - UTR - ETA Columbia - Colatina/ES | 0d | 2020-11-12 | 2020-11-12 | 1898 |  | 393d |
| 1900 | 7.6.3.2 | **Fundiária** | 657d | 2018-08-07 A | 2021-03-24 |  | 23% | 663d |
| 1901 |  | Obter Termos de Autorização de Superficiário - UTRs - Imóveis 1, 2 e 4 (Marista, Aparecida e Columbia) - Colatina/ES | 349d | 2018-08-07 A | 2019-12-23 |  | 34% | 613d |
| 1902 |  | Realizar Negociação da Servidão do Imóvel - UTR Columbia - Colatina/ES | 180d | 2020-07-03 | 2021-03-24 | 1894 |  | 345d |
| 1903 |  | Conclusão da Regularização Fundiária para as obras de Melhoria do Sistema de Abastecimento da Localidade - Colatina/ES | 0d | 2021-03-24 | 2021-03-24 | 1901, 1902 |  | 663d |
| 1904 | 7.6.3.3 | **Suprimentos** | 88d | 2020-10-22 | 2021-03-03 |  |  | 320d |
| 1905 |  | Suprimentos - Processo contratação UTRs - Colatina/ES | 88d | 2020-10-22 | 2021-03-03 | 1897 |  | 320d |
| 1906 |  | Conclusão da Contratação de Suprimentos das obras de Melhoria do Sistema de Abastecimento de Água - Colatina/ES | 0d | 2021-03-03 | 2021-03-03 | 1905 |  | 678d |
| 1907 | 7.6.3.4 | **Infraestrutura** | 360d | 2021-03-04 | 2022-08-09 |  |  | 318d |
| 1908 | 7.6.3.4.1 | **Obras** | 110d | 2021-03-04 | 2021-08-09 |  |  | 320d |
| 1909 |  | Executar UTR (ETA Columbia 19L/s) - Colatina/ES | 110d | 2021-03-04 | 2021-08-09 | 1901, 1905, 1899, 1902FS-40d |  | 320d |
| 1910 |  | Assinatura de Termo de Entrega das Obras de Melhoria do Sistema de Abastecimento de Água - Colatina/ES | 0d | 2021-08-09 | 2021-08-09 | 1909, 1903, 1906 |  | 568d |
| 1911 | 7.6.3.4.2 | **Operação** | 250d | 2021-08-09 | 2022-08-09 |  |  | 318d |
| 1912 |  | Realizar Treinamento Operacional do Sistema - Colatina/ES | 5d | 2021-08-10 | 2021-08-16 | 1909 |  | 549d |
| 1913 |  | Realizar Testes e Pré-operação - Colatina/ES | 14d | 2021-08-17 | 2021-09-03 | 1912 |  | 549d |
| 1914 |  | Realizar Acompanhamento da Funcionalidade do Sistema - UTR - ETA Columbia - Colatina/ES (sede) | 365ed | 2021-08-09 | 2022-08-09 | 1916SS |  | 1410d |
| 1915 | 7.6.3.4.2.4 | **Operação Assistida** | 61d | 2021-08-09 | 2021-11-07 |  |  | 320d |
| 1916 |  | Realizar Operação Assistida - Colatina/ES | 90ed | 2021-08-09 | 2021-11-07 | 1909 |  | 1410d |
| 1917 | 7.7 | **Boninsegna (distrito Marilândia/ES)** | 1041d | 2018-02-01 A | 2022-03-26 |  | 28% | 412d |
| 1918 | 7.7.1 | **Captação Principal, Alternativa, Nova ETA e UTR** | 1041d | 2018-02-01 A | 2022-03-26 |  | 28% | 412d |
| 1919 | 7.7.1.1 | **Estudos de Concepção do Sistema** | 155d | 2018-02-01 A | 2018-09-05 A |  | 100% |  |
| 1920 |  | Declaração de Escopo e Premissas de Projeto (DEPP) concluída - Boninsegna/ES | 0d | 2018-03-23 A | 2018-03-23 A | 25, 26 | 100% |  |
| 1921 |  | Aprovação das DEPPs pela Operadora e Prefeitura - Boninsegna/ES | 0d | 2018-02-01 A | 2018-02-01 A | 25, 26 | 100% |  |
| 1922 |  | Revisão de Definições - Boninsegna/ES | 0d | 2018-09-05 A | 2018-09-05 A | 1920FS+121d | 100% |  |
| 1923 |  | Aprovação da Revisão da Definição pela Prefeitura de Marilândia - Boninsegna/ES | 0d | 2018-09-05 A | 2018-09-05 A | 1922 | 100% |  |
| 1924 |  | Conclusão dos Estudos de Concepção das Melhorias do Sistema de Abastecimento de Água - Boninsegna/ES | 0d | 2018-09-05 A | 2018-09-05 A | 1923 | 100% |  |
| 1925 | 7.7.1.2 | **Engenharia Básica e Detalhada** | 370d | 2018-09-06 A | 2020-02-28 |  | 78% | 928d |
| 1926 | 7.7.1.2.1 | **Engenharia Captação Principal (Rio Doce) - SE 32103** | 338d | 2018-10-22 A | 2020-02-28 |  | 78% | 928d |
| 1927 |  | Aprovação Plano de Trabalho /abertura OSE - Captação Principal - Rio Doce - Boninsegna/ES | 73d | 2018-12-03 A | 2019-03-19 A | 1923 | 100% |  |
| 1928 |  | Realizar levantamento de Campo - Captação Principal - Rio Doce - Boninsegna/ES | 6d | 2019-06-05 A | 2019-06-12 A | 1927FS+52d | 100% |  |
| 1929 |  | Realizar sondagem - Captação Principal - Rio Doce - Boninsegna/ES | 19d | 2019-11-21 | 2019-12-18 | 1927FS+170d |  | 17.8d |
| 1930 |  | Executar Topografia - Captação Principal - Rio Doce - Boninsegna/ES | 30d | 2018-10-22 A | 2018-11-30 A | 1927SS-30d | 100% |  |
| 1931 |  | Realizar Batimetria - Captação Principal - Rio Doce - Boninsegna/ES | 19d | 2019-05-06 A | 2019-05-30 A | 1927FS+30d | 100% |  |
| 1932 |  | Elaborar arranjo para obtenção de Dados de Entrada Licenciamento e Fundiário - Captação Principal - Rio Doce - Boninsegna/ES | 31d | 2019-06-13 A | 2019-07-26 A | 1927FS+45d, 1928, 1930 | 100% |  |
| 1933 |  | Emitir RT/PQ para Suprimentos - Captação Principal - Rio Doce - Boninsegna/ES | 10d | 2019-12-02 | 2019-12-16 | 1932FS+88d |  | 461d |
| 1934 |  | Elaborar Projeto Executivo - Captação Principal - Rio Doce - Boninsegna/ES | 154d | 2019-07-17 A | 2020-02-28 | 1928, 1929FS-18d, 1931, 1932FS-8d | 70% | 533d |
| 1935 |  | Elaboração do Projeto Executivo - Captação Principal - Rio Doce - Boninsegna/ES | 0d | 2020-02-28 | 2020-02-28 | 1934 |  | 928d |
| 1936 | 7.7.1.2.2 | **Engenharia Captação Alternativa (Poço raso existente) - SE 32103** | 338d | 2018-10-22 A | 2020-02-28 |  | 77% | 928d |
| 1937 |  | Aprovação Plano de Trabalho /abertura OSE - Captação Alternativa - Cacimba - Boninsegna/ES | 73d | 2018-12-03 A | 2019-03-19 A | 1923 | 100% |  |
| 1938 |  | Realizar levantamento de Campo - Captação Alternativa - Cacimba - Boninsegna/ES | 6d | 2019-06-05 A | 2019-06-12 A | 1937FS+52d | 100% |  |
| 1939 |  | Realizar sondagem - Captação Alternativa - Cacimba - Boninsegna/ES | 19d | 2019-11-21 | 2019-12-18 | 1937FS+170d |  | 10.8d |
| 1940 |  | Executar Topografia - Captação Alternativa - Cacimba - Boninsegna/ES | 30d | 2018-10-22 A | 2018-11-30 A | 1937FS+30d | 100% |  |
| 1941 |  | Realizar Batimetria - Captação Alternativa - Cacimba - Boninsegna/ES | 19d | 2019-05-06 A | 2019-05-30 A | 1937FS+30d | 100% |  |
| 1942 |  | Elaborar arranjo para obtenção de Dados de Entrada Licenciamento e Fundiário - Captação Alternativa - Cacimba - Boninsegna/ES | 22d | 2019-06-13 A | 2019-07-15 A | 1938 | 100% |  |
| 1943 |  | Emitir RT/PQ para Suprimentos - Captação Alternativa - Cacimba - Boninsegna/ES | 10d | 2019-12-02 | 2019-12-16 | 1942FS+97d |  | 461d |
| 1944 |  | Elaborar Projeto Executivo - Captação Alternativa - Cacimba - Boninsegna/ES | 154d | 2019-07-17 A | 2020-02-28 | 1939FS-11d, 1940, 1941, 1942FS-11d | 70% | 533d |
| 1945 |  | Elaboração do Projeto Executivo - Captação Alternativa - Cacimba - Boninsegna/ES | 0d | 2020-02-28 | 2020-02-28 | 1944 |  | 928d |
| 1946 | 7.7.1.2.3 | **Engenharia nova ETA - SE 32103** | 370d | 2018-09-06 A | 2020-02-28 |  | 78% | 928d |
| 1947 |  | Aprovação Plano de Trabalho /abertura OSE - Nova ETA - Boninsegna/ES | 46d | 2018-09-06 A | 2018-11-08 A | 1923 | 100% |  |
| 1948 |  | Dados de Entrada (levantamento de campo, topografia e sondagem) - Nova ETA - Boninsegna/ES | 25d | 2018-11-09 A | 2018-12-13 A | 1947 | 100% |  |
| 1949 |  | Elaborar arranjo para obtenção de Dados de Entrada Licenciamento e Fundiário - Nova ETA - Boninsegna/ES | 22d | 2019-06-13 A | 2019-07-15 A | 1948FS+122d | 100% |  |
| 1950 |  | Emitir RT/PQ para Suprimentos - Nova ETA - Boninsegna/ES | 10d | 2019-12-02 | 2019-12-16 | 1942FS+97d |  | 461d |
| 1951 |  | Elaborar Projeto Executivo - Nova ETA - Boninsegna/ES | 166d | 2019-07-01 A | 2020-02-28 | 1949FS-11d | 70% | 928d |
| 1952 |  | Elaboração do Projeto Executivo - Nova ETA - Boninsegna/ES | 0d | 2020-02-28 | 2020-02-28 | 1951 |  | 928d |
| 1953 | 7.7.1.2.4 | **Engenharia UTR - SE 32103** | 370d | 2018-09-06 A | 2020-02-28 |  | 79% | 413d |
| 1954 |  | Aprovação Plano de Trabalho /abertura OSE - UTR - Boninsegna/ES | 46d | 2018-09-06 A | 2018-11-08 A | 1923 | 100% |  |
| 1955 |  | Dados de Entrada (levantamento de campo, topografia e sondagem) - UTR - Boninsegna/ES | 25d | 2018-11-09 A | 2018-12-13 A | 1954 | 100% |  |
| 1956 |  | Elaborar arranjo para obtenção de Dados de Entrada Licenciamento e Fundiário - UTR - Boninsegna/ES | 30d | 2019-06-03 A | 2019-07-15 A | 1955FS+114d | 100% |  |
| 1957 |  | Emitir RT/PQ para Suprimentos - UTR - Boninsegna/ES | 10d | 2019-12-02 | 2019-12-16 | 1942FS+97d |  | 461d |
| 1958 |  | Elaborar Projeto Executivo - UTR - Boninsegna/ES | 155d | 2019-07-16 A | 2020-02-28 | 1956 | 70% | 413d |
| 1959 |  | Elaboração do Projeto Executivo - UTR - Boninsegna/ES | 0d | 2020-02-28 | 2020-02-28 | 1958 |  | 413d |
| 1960 | 7.7.1.3 | **Fundiária** | 268d | 2019-05-17 A | 2020-06-15 |  | 16% | 856d |

| ID | WBS | Task | Duration | Start | Finish | Predecessors | Complete | Total float |
| --- | --- | --- | --- | --- | --- | --- | --- | --- |
| 1961 |  | Obter Termo de Autorização de Superficiário - Captação Principal - Boninsegna/ES | 99d | 2019-09-17 A | 2020-02-07 | 1923FS+259d | 21% | 461d |
| 1962 |  | Captação Principal - Desimpedimento da Área e Negociação de Servidão - Boninsegna/ES | 84d | 2020-02-10 | 2020-06-15 | 1932, 1961 |  | 461d |
| 1963 |  | Obter Termo de Autorização de Superficiário - Captação Alternativa - Boninsegna/ES | 184d | 2019-05-17 A | 2020-02-07 | 1923FS+174d | 25% | 461d |
| 1964 |  | Captação Alternativa - Desimpedimento da Área e Negociação de Servidão - Boninsegna/ES | 84d | 2020-02-10 | 2020-06-15 | 1942, 1963 |  | 461d |
| 1965 |  | Obter Termo de Autorização de Superficiário - Nova ETA / UTR - Boninsegna/ES | 184d | 2019-05-17 A | 2020-02-07 | 1923FS+174d | 25% | 856d |
| 1966 |  | Nova ETA / UTR - Desimpedimento da Área e Negociação de Servidão - Boninsegna/ES | 84d | 2020-02-10 | 2020-06-15 | 1949, 1956, 1965 |  | 856d |
| 1967 |  | Conclusão da Regularização Fundiária para as obras de Melhoria do Sistema de Abastecimento da Localidade - Boninsegna/ES | 0d | 2020-06-15 | 2020-06-15 | 1961, 1962, 1963, 1964, 1965, 1966 |  | 856d |
| 1968 | 7.7.1.4 | **Licenciamento** | 233d | 2019-08-01 A | 2020-07-09 |  | 28% | 838d |
| 1969 |  | Obter Outorga e autorizações (captação principal, construção ETA e UTR) - Boninsegna/ES | 233d | 2019-08-01 A | 2020-07-09 | 1932FS+3d, 1949, 1956 | 28% | 443d |
| 1970 |  | Captação Alternativa - Dispensa de Licença (Poço raso existente) - Boninsegna/ES | 149d | 2019-09-05 A | 2020-04-13 | 1942FS+36d | 28% | 503d |
| 1971 |  | Conclusão do Licenciamento Ambiental da Localidade - Boninsegna/ES | 0d | 2020-07-09 | 2020-07-09 | 1969, 1970 |  | 838d |
| 1972 | 7.7.1.5 | **Suprimentos** | 136d | 2019-12-17 | 2020-07-07 |  |  | 461d |
| 1973 | 7.7.1.5.1 | **Processo contratação - Captação Principal, nova ETA e UTR - Boninsegna/ES** | 88d | 2020-02-28 | 2020-07-07 |  |  | 413d |
| 1974 |  | Recebimento da RT/PQ pelo Suprimentos - Boninsegna/ES | 0d | 2020-02-28 | 2020-02-28 | 1933, 1950, 1957, 1959 |  | 413d |
| 1975 |  | Realizar Entendimento da Demanda - Boninsegna/ES | 10d | 2020-03-02 | 2020-03-13 | 1974 |  | 413d |
| 1976 |  | Abrir a RC - Boninsegna/ES | 8d | 2020-03-16 | 2020-03-25 | 1975 |  | 413d |
| 1977 |  | Aprovar a RC (liberação) - Boninsegna/ES | 8d | 2020-03-26 | 2020-04-06 | 1976 |  | 413d |
| 1978 |  | Prospectar fornecedores e receber proposta técnicas - Boninsegna/ES | 30d | 2020-04-07 | 2020-05-21 | 1977 |  | 413d |
| 1979 |  | Aprovar proposta técnica - Boninsegna/ES | 12d | 2020-05-22 | 2020-06-08 | 1978 |  | 413d |
| 1980 |  | Realizar negociação e aprovar o pedido - Boninsegna/ES | 20d | 2020-06-09 | 2020-07-07 | 1979 |  | 413d |
| 1981 |  | Conclusão da Contratação de Suprimentos - Boninsegna/ES | 0d | 2020-07-07 | 2020-07-07 | 1980 |  | 413d |
| 1982 |  | Processo contratação Serviço Limpeza em Poços Rasos - Boninsegna/ES | 88d | 2019-12-17 | 2020-04-28 | 1943 |  | 461d |
| 1983 |  | Conclusão da Contratação de Suprimentos das obras de Melhoria do Sistema de Abastecimento de Água - Boninsegna/ES | 0d | 2020-04-28 | 2020-04-28 | 1982 |  | 888d |
| 1984 | 7.7.1.6 | **Infraestrutura** | 428d | 2020-07-08 | 2022-03-26 |  |  | 412d |
| 1985 | 7.7.1.6.1 | **Obras** | 179d | 2020-07-08 | 2021-03-26 |  |  | 413d |
| 1986 | 7.7.1.6.1.1 | **Captação Alternativa - Poço raso (Cacimba)** | 179d | 2020-07-08 | 2021-03-26 |  |  | 413d |
| 1987 |  | Realizar Recuperação - Captação Alternativa - Cacimba - Boninsegna/ES | 5d | 2020-07-08 | 2020-07-14 | 1923, 1963, 1982, 1981 |  | 413d |
| 1988 |  | Elaborar Relatório Técnico - Captação Alternativa - Cacimba - Boninsegna/ES | 24d | 2020-07-15 | 2020-08-17 | 1987 |  | 413d |
| 1989 |  | Realizar Instrumentação - Captação Alternativa - Cacimba - Boninsegna/ES | 3d | 2020-08-18 | 2020-08-20 | 1988 |  | 413d |
| 1990 |  | Realizar Laudo dos Serviços de Coleta e Análise de Água - Captação Alternativa - Cacimba - Boninsegna/ES | 24d | 2020-07-15 | 2020-08-17 | 1987 |  | 416d |
| 1991 |  | Executar Captação Alternativa (Urbanização Poço Raso existente) - Boninsegna/ES | 147d | 2020-08-21 | 2021-03-26 | 1989, 1944, 1964, 1970, 1981, 1992 |  | 413d |
| 1992 |  | Conclusão das obras de Captação Alternativa - Poço Raso (Cacimba) - Boninsegna/ES | 0d | 2020-08-17 | 2020-08-17 | 1990 |  | 416d |
| 1993 |  | Executar Captação, ETA e UTR - Boninsegna/ES | 147d | 2020-07-10 | 2021-02-09 | 1934, 1962, 1969, 1981 |  | 443d |
| 1994 |  | Assinatura de Termo de Entrega das Obras de Melhoria do Sistema de Abastecimento de Água - Boninsegna/ES | 0d | 2021-03-26 | 2021-03-26 | 1993, 1991, 1935, 1945, 1952, 1967, 1971, 1983 |  | 661d |
| 1995 | 7.7.1.6.2 | **Operação** | 249d | 2021-03-26 | 2022-03-26 |  |  | 412d |
| 1996 |  | Realizar Treinamento Operacional do Sistema - Boninsegna/ES | 5d | 2021-03-29 | 2021-04-05 | 1993, 1991 |  | 642d |
| 1997 |  | Realizar Testes e Pré-operação - Boninsegna/ES | 14d | 2021-04-06 | 2021-04-26 | 1996 |  | 642d |
| 1998 |  | Realizar Acompanhamento da Funcionalidade do Sistema - Captação Principal, Alternativa, Nova ETA e UTR - Boninsegna (distrito Marilândia/ES) | 365ed | 2021-03-26 | 2022-03-26 | 2000SS |  | 1818d |
| 1999 | 7.7.1.6.2.4 | **Operação Assistida** | 61d | 2021-03-26 | 2021-06-24 |  |  | 413d |
| 2000 |  | Realizar Operação Assistida - Boninsegna/ES | 90ed | 2021-03-26 | 2021-06-24 | 1993, 1991 |  | 1818d |
| 2001 | 8 | **Território Foz do Rio Doce Litoral** | 1199d | 2017-12-22 A | 2022-09-29 |  | 10% | 283d |
| 2002 | 8.1 | **Linhares/ES (sede)** | 1199d | 2017-12-22 A | 2022-09-29 |  | 13% | 283d |
| 2003 | 8.1.1 | **Captação Alternativa - Adequação da captação na Lagoa Nova** | 846d | 2017-12-22 A | 2021-05-04 |  | 18% | 636d |
| 2004 | 8.1.1.1 | **Estudos de Concepção do Sistema** | 65d | 2017-12-22 A | 2018-03-23 A |  | 100% |  |
| 2005 |  | Declaração de Escopo e Premissas de Projeto (DEPP) concluída - Linhares/ES | 0d | 2018-03-23 A | 2018-03-23 A | 25, 26 | 100% |  |
| 2006 |  | Aprovação das DEPPs pela Operadora e Prefeitura - Linhares/ES | 0d | 2017-12-22 A | 2017-12-22 A | 25, 26 | 100% |  |
| 2007 | 8.1.1.2 | **Engenharia Básica e Detalhada** | 296d | 2018-09-18 A | 2019-11-19 |  | 92% | 994d |
| 2008 | 8.1.1.2.1 | **Engenharia Captação Alternativa - Lagoa Nova (Recuperação de Erosões) - SE32128** | 296d | 2018-09-18 A | 2019-11-19 |  | 90% | 994d |
| 2009 |  | Aprovar Plano de Trabalho e abrir OSE - Recuperação Erosões - Captação Alternativa - Lagoa Nova - Linhares/ES | 11d | 2018-09-25 A | 2018-10-09 A | 2005FS+132d | 100% |  |
| 2010 |  | Realizar Levantamento de Campo - Recuperação Erosões - Captação Alternativa - Lagoa Nova - Linhares/ES | 6d | 2018-10-10 A | 2018-10-17 A | 2009 | 100% |  |
| 2011 |  | Realizar Sondagem - Recuperação Erosões - Captação Alternativa - Lagoa Nova - Linhares/ES | 22d | 2018-09-18 A | 2018-10-17 A | 2009FS-16d | 100% |  |
| 2012 |  | Executar Topografia - Recuperação Erosões - Captação Alternativa - Lagoa Nova - Linhares/ES | 15d | 2018-09-27 A | 2018-10-17 A | 2009FS-9d | 100% |  |
| 2013 |  | Elaborar arranjo para obtenção de Dados de Entrada Licenciamento e Fundiário - Recuperação Erosões - Captação Alternativa - Lagoa Nova - Linhares/ES | 179d | 2018-10-18 A | 2019-07-05 A | 2010, 2011, 2012 | 100% |  |
| 2014 |  | Emitir RT/PQ para Infra (Guarda-chuva) - Recuperação Erosões - Captação Alternativa - Lagoa Nova - Linhares/ES | 10d | 2019-11-05 | 2019-11-19 | 2015FF |  | 663d |
| 2015 |  | Elaborar Projeto Executivo - Recuperação Erosões - Captação Alternativa - Lagoa Nova - Linhares/ES | 53d | 2019-09-05 A | 2019-11-19 | 2013FS+42d | 63% | 663d |
| 2016 |  | Elaboração do Projeto Executivo - Recuperação Erosões - Captação Alternativa - Lagoa Nova - Linhares/ES | 0d | 2019-11-19 | 2019-11-19 | 2015 |  | 994d |
| 2017 | 8.1.1.2.2 | **Engenharia Captação Alternativa - Lagoa Nova (Adequação do Sistema Captação - Barrilete)** | 55d | 2019-07-01 A | 2019-09-16 A |  | 100% |  |
| 2018 |  | Aprovar Plano de Trabalho e abrir OSE - Adequação do Sist. Captação - Captação Alternativa - Lagoa Nova - Linhares/ES | 4d | 2019-07-01 A | 2019-07-04 A | 2005FS+323d | 100% |  |
| 2019 |  | Elaborar arranjo para obtenção de Dados de Entrada Licenciamento e Fundiário - Adequação do Sist. Captação - Captação Alternativa - Lagoa Nova - Linhares/ES | 22d | 2019-07-05 A | 2019-08-05 A | 2018 | 100% |  |
| 2020 |  | Emitir RT/PQ para Suprimentos - Adequação do Sist. Captação - Captação Alternativa - Lagoa Nova - Linhares/ES | 10d | 2019-08-13 A | 2019-08-27 A | 2021FF-20d | 100% |  |
| 2021 |  | Elaborar Projeto Executivo - Adequação do Sist. Captação - Captação Alternativa - Lagoa Nova - Linhares/ES | 29d | 2019-08-06 A | 2019-09-16 A | 2019 | 100% |  |
| 2022 |  | Elaboração do Projeto Executivo - Adequação do Sist. Captação - Captação Alternativa - Lagoa Nova - Linhares/ES | 0d | 2019-09-16 A | 2019-09-16 A | 2019, 2021 | 100% |  |
| 2023 | 8.1.1.3 | **Suprimentos** | 110d | 2019-09-17 A | 2020-02-27 |  | 37% | 929d |
| 2024 | 8.1.1.3.1 | **Captação Alternativa** | 13d | 2019-09-18 A | 2019-10-04 A |  | 100% |  |
| 2025 |  | Aprovar APRO 130/2019 - Contratação Barrilete e Sist. de Automação - Linhares/ES | 1d | 2019-09-18 A | 2019-09-18 A | 2021 | 100% |  |
| 2026 |  | Realizar contratação Captação Alternativa (Caiado) - Barrilete e Sistema de Automação - Linhares/ES | 12d | 2019-09-19 A | 2019-10-04 A | 2020, 2025 | 100% |  |
| 2027 |  | Conclusão da Contratação de Suprimentos - Lagoa Nova - Captação Alternativa - Linhares/ES | 0d | 2019-10-04 A | 2019-10-04 A | 2026 | 100% |  |
| 2028 |  | Processo de Compras - Barco para Manutenção das Bombas - Lagoa Nova - Captação Alternativa - Linhares/ES | 110d | 2019-09-17 A | 2020-02-27 | 2021 | 30% | 637d |
| 2029 |  | Conclusão da Contratação de Suprimentos das obras de Melhoria do Sistema de Abastecimento de Água - Linhares/ES | 0d | 2020-02-27 | 2020-02-27 | 2026, 2028 |  | 929d |
| 2030 | 8.1.1.4 | **Infraestrutura** | 370d | 2019-11-01 | 2021-05-04 |  |  | 636d |

| ID | WBS | Task | Duration | Start | Finish | Predecessors | Complete | Total float |
| --- | --- | --- | --- | --- | --- | --- | --- | --- |
| 2031 | 8.1.1.4.1 | **Obras** | 121d | 2019-11-01 | 2020-05-04 |  |  | 675d |
| 2032 | 8.1.1.4.1.1 | **Captação Alternativa** | 121d | 2019-11-01 | 2020-05-04 |  |  | 637d |
| 2033 |  | Executar adequação na Captação Alternativa - Barrilete e Sistema de Automação - Linhares/ES | 25d | 2019-11-04 | 2019-12-09 | 2021, 2026FS+20d, 2027FS+20d |  | 732d |
| 2034 |  | Executar adequação na Captação Alternativa - Recuperação de Erosões - Linhares/ES | 83d | 2019-11-20 | 2020-03-24 | 2014, 2015 |  | 663d |
| 2035 |  | Executar adequação na Captação Alternativa - Manutenção nas 6 bombas de 2 cv do SAAE - Linhares/ES | 22d | 2019-11-01 | 2019-12-03 | 2025FS+31d |  | 736d |
| 2036 |  | Executar adequação na Captação Alternativa - Manutenção nas 2 bombas de 50 cv do SAAE - Linhares/ES | 27d | 2019-11-01 | 2019-12-10 | 2025FS+31d |  | 731d |
| 2037 |  | Realizar entrega do barco para manutenção das bombas ao SAAE - Lagoa Nova - Captação Alternativa - Linhares/ES | 44d | 2020-02-28 | 2020-05-04 | 2028 |  | 637d |
| 2038 |  | Conclusão das obras de adequação na Captação Alternativa - Linhares/ES | 0d | 2020-05-04 | 2020-05-04 | 2033, 2034, 2035, 2036, 2037 |  | 637d |
| 2039 |  | Assinatura de Termo de Entrega das Obras de Melhoria do Sistema de Abastecimento de Água - Linhares/ES | 0d | 2020-05-04 | 2020-05-04 | 2038, 2016, 2029 |  | 885d |
| 2040 | 8.1.1.4.2 | **Operação** | 249d | 2020-05-04 | 2021-05-04 |  |  | 636d |
| 2041 |  | Realizar Treinamento Operacional do Sistema - Linhares/ES | 5d | 2020-05-05 | 2020-05-11 | 2038 |  | 866d |
| 2042 |  | Realizar Testes e Pré-operação (Para as adequações da ETA) - Linhares/ES | 14d | 2020-05-12 | 2020-05-29 | 2041 |  | 866d |
| 2043 |  | Realizar Acompanhamento da Funcionalidade do Sistema - Captação Alternativa - Adequação da captação na Lagoa Nova - Linhares/ES (sede) | 365ed | 2020-05-04 | 2021-05-04 | 2045SS |  | 2796d |
| 2044 | 8.1.1.4.2.4 | **Operação Assistida** | 63d | 2020-05-04 | 2020-08-02 |  |  | 636d |
| 2045 |  | Realizar Operação Assistida - Linhares/ES | 90ed | 2020-05-04 | 2020-08-02 | 2038 |  | 2796d |
| 2046 | 8.1.2 | **Melhorias em ETA e Captação Principal** | 1087d | 2017-12-22 A | 2022-04-20 |  | 14% | 395d |
| 2047 | 8.1.2.1 | **Estudos de Concepção do Sistema** | 65d | 2017-12-22 A | 2018-03-23 A |  | 100% |  |
| 2048 |  | Declaração de Escopo e Premissas de Projeto (DEPP) concluída - Linhares/ES | 0d | 2018-03-23 A | 2018-03-23 A | 25, 26 | 100% |  |
| 2049 |  | Aprovação das DEPPs pela Operadora e Prefeitura - Linhares/ES | 0d | 2017-12-22 A | 2017-12-22 A | 25, 26 | 100% |  |
| 2050 | 8.1.2.2 | **Engenharia Básica e Detalhada** | 327d | 2019-01-07 A | 2020-05-04 |  | 53% | 885d |
| 2051 | 8.1.2.2.1 | **Engenharia Captação Principal (Pequenas Melhorias) - Rio Pequeno - SE32283** | 258d | 2019-01-07 A | 2020-01-20 |  | 46% | 954d |
| 2052 |  | Aprovar Plano de Trabalho e abrir OSE - Captação Principal - Rio Pequeno - Linhares/ES | 27d | 2019-01-07 A | 2019-02-12 A | 2048FS+205d | 100% |  |
| 2053 |  | Realizar Levantamento de Campo - Captação Principal - Rio Pequeno - Linhares/ES | 3d | 2019-03-19 A | 2019-03-21 A | 2052FS+21d | 100% |  |
| 2054 |  | Emitir RT/PQ para Infra - CGC - Captação Principal - Rio Pequeno - Linhares/ES | 10d | 2020-01-07 | 2020-01-20 | 2055FF |  | 623d |
| 2055 |  | Elaborar Projeto Executivo - Captação Principal - Rio Pequeno - Linhares/ES | 207d | 2019-03-22 A | 2020-01-20 | 2053 | 40% | 623d |
| 2056 |  | Elaboração do Projeto Executivo - Captação Principal - Rio Pequeno - Linhares/ES | 0d | 2020-01-20 | 2020-01-20 | 2055 |  | 954d |
| 2057 | 8.1.2.2.2 | **Engenharia Melhorias ETA** | 326d | 2019-01-08 A | 2020-05-04 |  | 57% | 885d |
| 2058 |  | Aprovar Plano de Trabalho e abrir OSE - Melhorias na ETA - Linhares/ES | 26d | 2019-01-08 A | 2019-02-12 A | 2048 | 100% |  |
| 2059 |  | Realizar Levantamento de Campo - Melhorias na ETA - Linhares/ES | 3d | 2019-03-19 A | 2019-03-21 A | 2058 | 100% |  |
| 2060 |  | Elaborar arranjo para obtenção de Dados de Entrada Licenciamento e Fundiário - Melhorias na ETA - Linhares/ES | 30d | 2019-08-01 A | 2019-09-12 A | 2059FS+90d | 100% |  |
| 2061 |  | Emitir RT/PQ para Infra - CGC - Melhorias na ETA - Linhares/ES | 10d | 2020-04-17 | 2020-05-04 | 2062FF, 2063FF |  | 554d |
| 2062 |  | Elaborar Projeto Executivo - Melhorias na ETA - Linhares/ES | 207d | 2019-03-22 A | 2020-01-20 | 2059, 2060 | 80% | 466d |
| 2063 |  | Elaborar Projeto Executivo - Automação das Válvulas - Linhares/ES | 116d | 2019-11-08 | 2020-05-04 | 2060FS+40d |  | 397d |
| 2064 |  | Elaboração do Projeto Executivo - Melhorias na ETA - Linhares/ES | 0d | 2020-05-04 | 2020-05-04 | 2062, 2063 |  | 885d |
| 2065 | 8.1.2.3 | **Infraestrutura** | 490d | 2020-05-05 | 2022-04-20 |  |  | 395d |
| 2066 | 8.1.2.3.1 | **Obras** | 240d | 2020-05-05 | 2021-04-20 |  |  | 397d |
| 2067 |  | Executar Obras de melhoria na Captação Principal - Captação rio Pequeno - Linhares/ES | 83d | 2020-05-05 | 2020-08-28 | 2054, 2055, 2061 |  | 554d |
| 2068 |  | Executar Melhorias na ETA - Linhares/ES | 240d | 2020-05-05 | 2021-04-20 | 2062, 2063 |  | 397d |
| 2069 |  | Assinatura de Termo de Entrega das Obras de Melhoria do Sistema de Abastecimento de Água - Linhares/ES | 0d | 2021-04-20 | 2021-04-20 | 2067, 2068, 2056, 2064 |  | 645d |
| 2070 | 8.1.2.3.2 | **Operação** | 250d | 2021-04-20 | 2022-04-20 |  |  | 395d |
| 2071 |  | Realizar Treinamento Operacional do Sistema - Linhares/ES | 5d | 2021-04-22 | 2021-04-28 | 2067, 2068 |  | 626d |
| 2072 |  | Realizar Testes e Pré-operação (Para as adequações da ETA) - Linhares/ES | 14d | 2021-04-29 | 2021-05-18 | 2071 |  | 626d |
| 2073 |  | Realizar Acompanhamento da Funcionalidade do Sistema - Melhorias em ETA e Captação Principal - Linhares/ES (sede) | 365ed | 2021-04-20 | 2022-04-20 | 2075SS |  | 1743d |
| 2074 | 8.1.2.3.2.4 | **Operação Assistida** | 62d | 2021-04-20 | 2021-07-19 |  |  | 397d |
| 2075 |  | Realizar Operação Assistida - Linhares/ES | 90ed | 2021-04-20 | 2021-07-19 | 2067, 2068 |  | 1743d |
| 2076 | 8.1.3 | **UTR** | 1199d | 2017-12-22 A | 2022-09-29 |  | 7% | 283d |
| 2077 | 8.1.3.1 | **Estudos de Concepção do Sistema** | 65d | 2017-12-22 A | 2018-03-23 A |  | 100% |  |
| 2078 |  | Declaração de Escopo e Premissas de Projeto (DEPP) concluída - Linhares/ES | 0d | 2018-03-23 A | 2018-03-23 A | 25, 26 | 100% |  |
| 2079 |  | Aprovação das DEPPs pela Operadora e Prefeitura - Linhares/ES | 0d | 2017-12-22 A | 2017-12-22 A | 25, 26 | 100% |  |
| 2080 | 8.1.3.2 | **Engenharia Básica e Detalhada** | 530d | 2018-06-07 A | 2020-07-16 |  | 48% | 833d |
| 2081 | 8.1.3.2.1 | **Engenharia UTR** | 530d | 2018-06-07 A | 2020-07-16 |  | 48% | 833d |
| 2082 |  | Aprovação Plano de Trabalho /abertura OSE - UTR - Linhares/ES | 42d | 2018-11-05 A | 2019-01-02 A | 2078 | 100% |  |
| 2083 |  | Realizar Levantamento de Campo - UTR - Linhares/ES | 3d | 2019-03-19 A | 2019-03-21 A | 2082 | 100% |  |
| 2084 |  | Realizar Sondagem - UTR - Linhares/ES | 4d | 2019-11-25 | 2019-11-28 | 2082FS+223d |  | 369d |
| 2085 |  | Executar Topografia - UTR - Linhares/ES | 97d | 2018-06-07 A | 2018-10-19 A | 2079 | 100% |  |
| 2086 |  | Elaborar Projeto Conceitual (Prof. Marcos Vianna) - UTR - Linhares/ES | 22d | 2019-09-13 A | 2019-10-14 A | 2083FS+120d, 2085 | 100% |  |
| 2087 |  | Elaborar arranjo para obtenção de Dados de Entrada Licenciamento e Fundiário - UTR - Linhares/ES | 65d | 2019-09-27 A | 2020-01-02 | 2083, 2085, 2086SS+10d | 27% | 284d |
| 2088 |  | Elaborar Projeto Básico - UTR - Linhares/ES | 64d | 2020-01-03 | 2020-04-06 | 2087, 2084FF |  | 284d |
| 2089 |  | Emitir RT/PQ para Suprimentos - UTR - Linhares/ES | 10d | 2020-04-07 | 2020-04-22 | 2088 |  | 284d |
| 2090 |  | Elaborar Projeto Executivo - UTR - Linhares/ES | 69d | 2020-04-07 | 2020-07-16 | 2088 |  | 335d |
| 2091 |  | Elaboração do Projeto Executivo - UTR - Linhares/ES | 0d | 2020-07-16 | 2020-07-16 | 2090 |  | 833d |
| 2092 | 8.1.3.3 | **Fundiária** | 183d | 2020-01-03 | 2020-09-25 |  |  | 285d |
| 2093 |  | Realizar regularização fundiária - UTR - Linhares/ES | 183d | 2020-01-03 | 2020-09-25 | 2087 |  | 285d |
| 2094 |  | Conclusão da Regularização Fundiária - UTR - Linhares/ES | 0d | 2020-09-25 | 2020-09-25 | 2093 |  | 285d |
| 2095 | 8.1.3.4 | **Licenciamento** | 176d | 2020-01-03 | 2020-09-16 |  |  | 292d |
| 2096 |  | Obter DAIA para construção de UTR - Linhares/ES | 176d | 2020-01-03 | 2020-09-16 | 2087 |  | 292d |
| 2097 |  | Conclusão do Licenciamento Ambiental - UTR - Linhares/ES | 0d | 2020-09-16 | 2020-09-16 | 2096 |  | 292d |
| 2098 | 8.1.3.5 | **Suprimentos** | 110d | 2020-04-23 | 2020-09-28 |  |  | 284d |
| 2099 |  | Processo contratação UTR - Linhares/ES | 110d | 2020-04-23 | 2020-09-28 | 2089 |  | 284d |
| 2100 |  | Conclusão da Contratação de Suprimentos das obras de Melhoria do Sistema de Abastecimento de Água - Linhares/ES | 0d | 2020-09-28 | 2020-09-28 | 2099 |  | 782d |

| ID | WBS | Task | Duration | Start | Finish | Predecessors | Complete | Total float |
| --- | --- | --- | --- | --- | --- | --- | --- | --- |
| 2101 | 8.1.3.6 | **Infraestrutura** | 499d | 2020-09-29 | 2022-09-29 |  |  | 283d |
| 2102 | 8.1.3.6.1 | **Obras** | 250d | 2020-09-29 | 2021-09-29 |  |  | 284d |
| 2103 |  | Executar UTR - Linhares/ES | 250d | 2020-09-29 | 2021-09-29 | 2090, 2099, 2094, 2097 |  | 284d |
| 2104 |  | Assinatura de Termo de Entrega das Obras de Melhoria do Sistema de Abastecimento de Água - Linhares/ES | 0d | 2021-09-29 | 2021-09-29 | 2103, 2091, 2100 |  | 532d |
| 2105 | 8.1.3.6.2 | **Operação** | 249d | 2021-09-29 | 2022-09-29 |  |  | 283d |
| 2106 |  | Realizar Treinamento Operacional do Sistema - Linhares/ES | 5d | 2021-09-30 | 2021-10-06 | 2103 |  | 513d |
| 2107 |  | Realizar Testes e Pré-operação (Para as adequações da ETA) - Linhares/ES | 14d | 2021-10-07 | 2021-10-27 | 2106 |  | 513d |
| 2108 |  | Realizar Acompanhamento da Funcionalidade do Sistema - UTR - Linhares/ES (sede) | 365ed | 2021-09-29 | 2022-09-29 | 2110SS |  | 1257d |
| 2109 | 8.1.3.6.2.4 | **Operação Assistida** | 60d | 2021-09-29 | 2021-12-28 |  |  | 284d |
| 2110 |  | Realizar Operação Assistida - Linhares/ES | 90ed | 2021-09-29 | 2021-12-28 | 2103 |  | 1257d |
| 2111 | 8.2 | **Regência (distrito Linhares/ES)** | 1097d | 2018-03-23 A | 2022-08-05 |  | 7% | 320d |
| 2112 | 8.2.1 | **Captação Alternativa** | 707d | 2018-03-23 A | 2021-01-13 |  | 45% | 710d |
| 2113 | 8.2.1.1 | **Estudos de Concepção do Sistema** | 222d | 2018-03-23 A | 2019-01-29 A |  | 100% |  |
| 2114 |  | Declaração de Escopo e Premissas de Projeto (DEPP) concluída - Regência/ES | 0d | 2018-03-23 A | 2018-03-23 A | 25, 26 | 100% |  |
| 2115 | 8.2.1.1.2 | **Estudos de Geofísica para Poço Tubular** | 16d | 2018-10-01 A | 2018-10-22 A |  | 100% |  |
| 2116 |  | Executar Levantamento de Campo - Regência/ES | 2d | 2018-10-01 A | 2018-10-02 A | 2114 | 100% |  |
| 2117 |  | Emitir Relatório - Regência/ES | 14d | 2018-10-03 A | 2018-10-22 A | 2116 | 100% |  |
| 2118 |  | Conclusão dos Estudos de Geofísica para Poço Tubular - Regência/ES | 0d | 2018-10-22 A | 2018-10-22 A | 2117 | 100% |  |
| 2119 | 8.2.1.1.3 | **Serviços em Poços Tubulares - Poço Existente Interligado** | 27d | 2018-05-10 A | 2018-06-15 A |  | 100% |  |
| 2120 |  | Realizar Perfilagem (Poço existente interligado) - Regência/ES | 2d | 2018-05-10 A | 2018-05-11 A | 2114 | 100% |  |
| 2121 |  | Realizar Recuperação (Poço existente interligado) - Regência/ES | 5d | 2018-05-14 A | 2018-05-18 A | 2120 | 100% |  |
| 2122 |  | Elaborar Relatório Técnico (poço existente interligado) - Regência/ES | 20d | 2018-05-21 A | 2018-06-15 A | 2121 | 100% |  |
| 2123 |  | Conclusão dos Serviços em poço tubular - Regência/ES | 0d | 2018-06-15 A | 2018-06-15 A | 2122 | 100% |  |
| 2124 |  | Conclusão dos Estudos de Concepção das Melhorias do Sistema de Abastecimento de Água - Regência/ES | 0d | 2019-01-29 A | 2019-01-29 A | 2118, 2123 | 100% |  |
| 2125 | 8.2.1.2 | **Engenharia Básica e Detalhada** | 20d | 2018-12-17 A | 2019-01-14 A |  | 100% |  |
| 2126 | 8.2.1.2.1 | **Engenharia Captação Alternativa (Poço interligado a ETA)** | 20d | 2018-12-17 A | 2019-01-14 A |  | 100% |  |
| 2127 |  | Aprovação Plano de Trabalho /abertura OSE - Captação Alternativa - Poço Existente - Regência/ES | 16d | 2018-12-17 A | 2019-01-08 A | 2114 | 100% |  |
| 2128 |  | Dados de Entrada (levantamento de campo, topografia e recebimento das informações do poço: perfil, vazão, análise água) - Captação Alternativa - Poço Existente - Regência/ES | 5d | 2019-01-08 A | 2019-01-14 A | 2127 | 100% |  |
| 2129 |  | Elaborar Projeto Executivo - Captação Alternativa - Poço Existente - Regência/ES | 1d | 2019-01-14 A | 2019-01-14 A | 2122, 2123, 2128FF | 100% |  |
| 2130 |  | Elaboração do Projeto Executivo - Captação Alternativa - Poço Existente - Regência/ES | 0d | 2019-01-14 A | 2019-01-14 A | 2129 | 100% |  |
| 2131 | 8.2.1.3 | **Infraestrutura** | 79d | 2020-09-18 | 2021-01-13 |  |  | 710d |
| 2132 | 8.2.1.3.1 | **Obras** | 79d | 2020-09-18 | 2021-01-13 |  |  | 710d |
| 2133 |  | Executar Captação Alternativa - Urbanização Poço existente - Regência/ES | 79d | 2020-09-18 | 2021-01-13 | 2129, 2130FS+417d |  | 710d |
| 2134 |  | Assinatura de Termo de Entrega das Obras de Melhoria do Sistema de Abastecimento de Água - Regência/ES | 0d | 2021-01-13 | 2021-01-13 | 2133 |  | 710d |
| 2135 | 8.2.2 | **Captação Principal (rio Doce) e adequações na ETA/UTR** | 783d | 2019-06-14 A | 2022-08-05 |  | 6% | 320d |
| 2136 | 8.2.2.1 | **Engenharia** | 313d | 2019-06-14 A | 2020-09-16 |  | 17% | 790d |
| 2137 | 8.2.2.1.1 | **Estudos de Concepção do Sistema** | 0d | 2019-06-14 A | 2019-06-14 A |  | 100% |  |
| 2138 |  | Aprovação da Revisão de Definição pela Operadora e Prefeitura - Regência/ES | 0d | 2019-06-14 A | 2019-06-14 A |  | 100% |  |
| 2139 | 8.2.2.1.2 | **Engenharia Básica e Detalhada** | 238d | 2019-10-02 A | 2020-09-16 |  | 17% | 790d |
| 2140 | 8.2.2.1.2.1 | **Engenharia Captação Principal (rio Doce) e adequação da ETA - SE 32029** | 238d | 2019-10-02 A | 2020-09-16 |  | 17% | 790d |
| 2141 |  | Aprovação Plano de Trabalho /abertura OSE + Levantamento de Campo - Captação Principal - Rio Doce - Regência/ES | 227d | 2019-10-02 A | 2020-08-31 | 26FS+478d | 10% | 801d |
| 2142 |  | Executar Topografia - Captação Principal - Rio Doce - Regência/ES | 73d | 2019-10-02 A | 2020-01-17 | 2141SS | 30% | 322d |
| 2143 |  | Realizar Sondagem - Captação Principal - Rio Doce - Regência/ES | 25d | 2019-10-02 A | 2019-11-05 | 2142SS | 88% | 499d |
| 2144 |  | Elaborar arranjo para obtenção de Dados de Entrada Licenciamento e Fundiário - Captação Principal - Rio Doce - Regência/ES | 22d | 2019-10-14 A | 2019-11-12 | 2143SS+8d | 64% | 354d |
| 2145 |  | Elaborar Projeto Básico - Captação Principal - Rio Doce - Regência/ES | 55d | 2020-01-20 | 2020-04-08 | 2138, 2142, 2144 |  | 322d |
| 2146 |  | Obter aprovação do Projeto Básico Regência/ES | 22d | 2020-04-09 | 2020-05-13 | 2145 |  | 322d |
| 2147 |  | Emitir RT/PQ para Suprimentos - Captação Principal - Rio Doce - Regência/ES | 15d | 2020-03-23 | 2020-04-13 | 2146FF-20d |  | 342d |
| 2148 |  | Elaborar Projeto Executivo - Captação Principal - Rio Doce - Regência/ES | 36d | 2020-07-28 | 2020-09-16 | 2138FS-3d, 2142FS+129d, 2143, 2146FS-22d |  | 322d |
| 2149 |  | Elaboração do Projeto Executivo - Captação Principal - Rio Doce - Regência/ES | 0d | 2020-09-16 | 2020-09-16 | 2148 |  | 771d |
| 2150 | 8.2.2.2 | **Fundiária** | 211d | 2019-08-19 A | 2020-06-24 |  | 35% | 830d |
| 2151 |  | Captação Principal (rio Doce) - Desimpedimento de área - Regência/ES | 211d | 2019-08-19 A | 2020-06-24 | 2144SS-19d | 35% | 381d |
| 2152 |  | Conclusão da Regularização Fundiária para as obras de Melhoria do Sistema de Abastecimento da Localidade - Regência/ES | 0d | 2020-06-24 | 2020-06-24 | 2151 |  | 830d |
| 2153 | 8.2.2.3 | **Licenciamento** | 176d | 2019-11-13 | 2020-07-31 |  |  | 354d |
| 2154 |  | Captação Principal - Outorga e Autorizações rio Doce - Regência/ES | 176d | 2019-11-13 | 2020-07-31 | 2144 |  | 354d |
| 2155 |  | Conclusão do Licenciamento Ambiental da Localidade - Regência/ES | 0d | 2020-07-31 | 2020-07-31 | 2154 |  | 803d |
| 2156 | 8.2.2.4 | **Suprimentos** | 88d | 2020-05-14 | 2020-09-16 |  |  | 322d |
| 2157 |  | Processo contratação - Captação Principal rio Doce - Regência/ES | 88d | 2020-05-14 | 2020-09-16 | 2146, 2147 |  | 322d |
| 2158 |  | Conclusão da Contratação de Suprimentos das obras de Melhoria do Sistema de Abastecimento de Água - Regência/ES | 0d | 2020-09-16 | 2020-09-16 | 2157 |  | 771d |
| 2159 | 8.2.2.5 | **Infraestrutura** | 470d | 2020-09-17 | 2022-08-05 |  |  | 320d |
| 2160 | 8.2.2.5.1 | **Obras** | 220d | 2020-09-17 | 2021-08-05 |  |  | 322d |
| 2161 |  | Executar Captação Principal e adutora de 11km do Rio Doce - Regência/ES | 220d | 2020-09-17 | 2021-08-05 | 2148, 2151, 2154, 2157 |  | 322d |
| 2162 |  | Executar Adequação ETA/UTR (caso haja nova captação no rio Doce) - Regência/ES | 120d | 2020-09-17 | 2021-03-15 | 2161SS |  | 651d |
| 2163 |  | Assinatura de Termo de Entrega das Obras de Melhoria do Sistema de Abastecimento de Água - Regência/ES | 0d | 2021-08-05 | 2021-08-05 | 2161, 2162, 2149, 2152, 2155, 2158 |  | 551d |
| 2164 | 8.2.2.5.2 | **Operação** | 250d | 2021-08-05 | 2022-08-05 |  |  | 320d |
| 2165 |  | Realizar Treinamento Operacional do Sistema - Regência/ES | 5d | 2021-08-06 | 2021-08-12 | 2161, 2163 |  | 551d |
| 2166 |  | Realizar Testes e Pré-operação - Regência/ES | 14d | 2021-08-13 | 2021-09-01 | 2165 |  | 551d |
| 2167 |  | Realizar Acompanhamento da Funcionalidade do Sistema - Captação Principal (rio Doce) e adequações na ETA/UTR - Regência (distrito Linhares/ES) | 365ed | 2021-08-05 | 2022-08-05 | 2169SS |  | 1422d |
| 2168 | 8.2.2.5.2.4 | **Operação Assistida** | 61d | 2021-08-05 | 2021-11-03 |  |  | 322d |
| 2169 |  | Realizar Operação Assistida - Regência/ES | 90ed | 2021-08-05 | 2021-11-03 | 2161 |  | 1422d |
| 2170 | 8.2.3 | **Captação Principal - Novo Poço** | 916d | 2018-03-23 A | 2021-11-16 |  | 6% | 501d |

| ID | WBS | Task | Duration | Start | Finish | Predecessors | Complete | Total float |
| --- | --- | --- | --- | --- | --- | --- | --- | --- |
| 2171 | 8.2.3.1 | **Estudos de Concepção do Sistema - Etapa 1** | 222d | 2018-03-23 A | 2019-01-29 A |  | 100% |  |
| 2172 |  | Declaração de Escopo e Premissas de Projeto (DEPP) concluída - Regência/ES | 0d | 2018-03-23 A | 2018-03-23 A | 25, 26 | 100% |  |
| 2173 | 8.2.3.1.2 | **Serviços em Poços Tubulares - Poço (Não será utilizado como fonte de captação)** | 47d | 2018-11-23 A | 2019-01-29 A |  | 100% |  |
| 2174 |  | Realizar Perfuração - Regência/ES | 12d | 2018-11-23 A | 2018-12-10 A | 2172 | 100% |  |
| 2175 |  | Realizar Teste bombeamento - Regência/ES | 3d | 2018-12-08 A | 2018-12-12 A | 2174 | 100% |  |
| 2176 |  | Elaborar Relatório Técnico - Regência/ES | 24d | 2018-12-11 A | 2019-01-14 A | 2174 | 100% |  |
| 2177 |  | Realizar Laudo dos Serviços de Coleta e Análise de Água - Regência/ES | 12d | 2018-12-13 A | 2018-12-28 A | 2175 | 100% |  |
| 2178 |  | Realizar Tamponamento - Regência/ES | 21d | 2018-12-31 A | 2019-01-29 A | 2177 | 100% |  |
| 2179 |  | Conclusão dos Serviços em poço tubular - Regência/ES | 0d | 2019-01-29 A | 2019-01-29 A | 2176, 2178 | 100% |  |
| 2180 | 8.2.3.2 | **Estudos de Concepção do Sistema - Etapa 2** | 270d | 2019-01-29 A | 2020-03-04 |  |  | 906d |
| 2181 |  | Aprovação da Revisão de Definição pela Operadora e Prefeitura - Regência/ES | 0d | 2019-06-14 A | 2019-06-14 A | 2172 | 100% |  |
| 2182 |  | Definição de perfuração de um novo poço para Captação Principal - Regência/ES | 0d | 2019-08-14 A | 2019-08-14 A | 2172 | 100% |  |
| 2183 | 8.2.3.2.3 | **Serviços em Poços Tubulares - Novo Poço** | 26d | 2020-01-24 | 2020-03-04 |  |  | 501d |
| 2184 |  | Realizar Perfuração - Regência/ES | 1d | 2020-01-24 | 2020-01-24 | 2201, 2205 |  | 501d |
| 2185 |  | Realizar Teste bombeamento - Regência/ES | 3d | 2020-01-27 | 2020-01-29 | 2184 |  | 501d |
| 2186 |  | Elaborar Relatório Técnico - Regência/ES | 22d | 2020-01-30 | 2020-03-04 | 2185 |  | 906d |
| 2187 |  | Realizar Laudo dos Serviços de Coleta e Análise de Água - Regência/ES | 22d | 2020-01-30 | 2020-03-04 | 2185 |  | 501d |
| 2188 |  | Conclusão dos Serviços em poço tubular - Regência/ES | 0d | 2020-03-04 | 2020-03-04 | 2186, 2187 |  | 906d |
| 2189 |  | Conclusão dos Estudos de Concepção das Melhorias do Sistema de Abastecimento de Água - Regência/ES | 0d | 2019-01-29 A | 2019-01-29 A | 2179 | 100% |  |
| 2190 | 8.2.3.3 | **Engenharia Básica e Detalhada** | 92d | 2020-03-05 | 2020-07-16 |  |  | 506d |
| 2191 | 8.2.3.3.1 | **Engenharia Captação Alternativa (Novo Poço)** | 92d | 2020-03-05 | 2020-07-16 |  |  | 506d |
| 2192 |  | Aprovação Plano de Trabalho /abertura OSE - Captação Alternativa - Novo Poço - Regência/ES | 5d | 2020-03-05 | 2020-03-11 | 2187 |  | 506d |
| 2193 |  | Dados de Entrada (levantamento de campo, topografia e recebimento das informações do poço: perfil, vazão, análise água) - Captação Alternativa - Regência/ES | 22d | 2020-03-12 | 2020-04-13 | 2192 |  | 506d |
| 2194 |  | Elaborar Projeto Executivo - Captação Alternativa - Novo Poço - Regência/ES | 65d | 2020-04-14 | 2020-07-16 | 2193 |  | 506d |
| 2195 |  | Elaboração do Projeto Executivo - Captação Alternativa - Novo Poço - Regência/ES | 0d | 2020-07-16 | 2020-07-16 | 2194 |  | 506d |
| 2196 | 8.2.3.4 | **Fundiária** | 119d | 2019-08-16 A | 2020-02-05 |  | 16% | 615d |
| 2197 |  | Obter Termo de Autorização de Superficiário - Captação Principal (Novo Poço) - Regência/ES | 75d | 2019-08-16 A | 2019-11-29 | 2182 | 25% | 506d |
| 2198 |  | Captação Principal (Novo Poço) - Desimpedimento de área - Regência/ES | 44d | 2019-12-02 | 2020-02-05 | 2197 |  | 615d |
| 2199 |  | Conclusão da Regularização Fundiária para as obras de Melhoria do Sistema de Abastecimento da Localidade - Regência/ES | 0d | 2020-02-05 | 2020-02-05 | 2198 |  | 615d |
| 2200 | 8.2.3.5 | **Licenciamento** | 237d | 2019-12-02 | 2020-11-16 |  |  | 501d |
| 2201 |  | Captação Principal - Autorização de Perfuração - Regência/ES | 30d | 2019-12-02 | 2020-01-16 | 2197 |  | 506d |
| 2202 |  | Captação Principal - Outorga novo poço - Regência/ES | 176d | 2020-03-05 | 2020-11-16 | 2187 |  | 501d |
| 2203 |  | Conclusão do Licenciamento Ambiental da Localidade - Regência/ES | 0d | 2020-11-16 | 2020-11-16 | 2201, 2202 |  | 501d |
| 2204 | 8.2.3.6 | **Suprimentos** | 110d | 2019-08-16 A | 2020-01-23 |  | 25% | 624d |
| 2205 |  | Processo de Contratação Tintori - Novo Poço - Captação Principal - Regência/ES | 110d | 2019-08-16 A | 2020-01-23 | 2182 | 25% | 501d |
| 2206 |  | Conclusão da Contratação de Suprimentos das obras de Melhoria do Sistema de Abastecimento de Água - Regência/ES | 0d | 2020-01-23 | 2020-01-23 | 2205 |  | 624d |
| 2207 | 8.2.3.7 | **Infraestrutura** | 327d | 2020-07-24 | 2021-11-16 |  |  | 501d |
| 2208 | 8.2.3.7.1 | **Obras** | 79d | 2020-07-24 | 2020-11-16 |  |  | 501d |
| 2209 |  | Executar Obras de Captação Principal - Novo Poço - Regência/ES | 79d | 2020-07-24 | 2020-11-16 | 2202FF, 2206, 2203FF, 2199, 2195 |  | 501d |
| 2210 |  | Assinatura de Termo de Entrega das Obras de Melhoria do Sistema de Abastecimento de Água - Regência/ES | 0d | 2020-11-16 | 2020-11-16 | 2209, 2188 |  | 730d |
| 2211 | 8.2.3.7.2 | **Operação** | 248d | 2020-11-16 | 2021-11-16 |  |  | 501d |
| 2212 |  | Realizar Treinamento Operacional do Sistema - Regência/ES | 5d | 2020-11-17 | 2020-11-23 | 2210 |  | 730d |
| 2213 |  | Realizar Testes e Pré-operação - Regência/ES | 14d | 2020-11-24 | 2020-12-11 | 2212 |  | 730d |
| 2214 |  | Realizar Acompanhamento da Funcionalidade do Sistema - Captação Principal - Novo Poço - Regência (distrito Linhares/ES) | 365ed | 2020-11-16 | 2021-11-16 | 2216SS |  | 2208d |
| 2215 | 8.2.3.7.2.4 | **Operação Assistida** | 61d | 2020-11-16 | 2021-02-14 |  |  | 501d |
| 2216 |  | Realizar Operação Assistida - Regência/ES | 90ed | 2020-11-16 | 2021-02-14 | 2209 |  | 2208d |
| 2217 | 9 | **Obras Emergenciais** | 484d | 2015-11-09 A | 2017-09-14 A |  | 100% |  |
| 2218 |  | Pedra Corrida (distrito de Periquito) | 64d | 2016-10-03 A | 2016-12-29 A | 24 | 100% |  |
| 2219 |  | Governador Valadares/MG (sede) | 16d | 2015-11-09 A | 2015-11-30 A | 24 | 100% |  |
| 2220 |  | São Vítor (distrito de Governador Valadares) | 64d | 2016-10-03 A | 2016-12-29 A | 24 | 100% |  |
| 2221 |  | São Tomé do Rio Doce (distrito de Tumiritinga) | 64d | 2016-10-03 A | 2016-12-29 A | 24 | 100% |  |
| 2222 |  | Galiléia/MG | 64d | 2016-10-03 A | 2016-12-29 A | 24 | 100% |  |
| 2223 |  | Captação Alternativa - Lagoa Nova - Linhares/ES | 315d | 2016-07-01 A | 2017-09-14 A | 24 | 100% |  |
| 2224 |  | Colatina (Sede) - Colatina/ES | 180d | 2016-03-23 A | 2016-11-29 A | 24 | 100% |  |
| 2225 |  | Fim da Execução | 0d | 2023-11-22 | 2023-11-22 | 265, 266, 267, 273, 312, 313, 314, 320, 327, 338, 407, 408, 409, 416, 423, 432, 459, 461, 464, 593, 594, 597, 600, 674, 676, 702, 703, 706, 709, 794, 795, 798, 801, 805, 833, 834, 835, 842, 845, 1206, 1207, 1210, 1213, 1272, 1275, 1271, 1278, 1281, 1284, 1376, 1377, 1380, 1383, 1424, 1439, 1443, 1457, 1536, 1560, 1561, 1564, 1567, 1572, 1613, 1614, 1615, 1616, 1617, 1621, 1623, 1629, 1667, 1668, 1669, 1673, 1675, 1773, 1774, 1777, 1780, 1785, 1823, 1824, 1827, 1830, 1909, 1910, 1913, 1916, 1921, 1923, 1993, 1991, 1994, 1997, 2000, 2079, 2103, 2104, 2107, 2110, 2181, 2176, 2178, 2210, 2213, 2216, 460, 836, 837, 838, 146, 155, 156, 202, 203, 209, 284, 306, 307, 467, 474, 477, 510, 511, 512, 515, 518, 522, 523, 529, 570, 573, 576, 605, 607, 663, 664, 667, 670, 714, 733, 755, 756, 760, 763, 766, 769, 850, 869, 873, 875, 880, 920, 921, 922, 927, 930, 935, 967, 968, 974, 977, 982, 1024, 1025, 1031, 1034, 1039, 1061, 1074, 1079, 1085, 1088, 1093, 1131, 1133, 1138, 1141, 1172, 1173, 1176, 1179, 1289, 1308, 1309, 1310, 1313, 1316, 1320, 1354, 1355, 1358, 1361, 1388, 1414, 1417, 1420, 1463, 1488, 1493, 1495, 1498, 1501, 1506, 1523, 1526, 1529, 1532, 1680, 1714, 1715, 1718, 1721, 1725, 1740, 1741, 1744, 1747, 1852, 1853, 1856, 1859, 1881, 1882, 1885, 1888, 2006, 2015, 2038, 2039, 2042, 2045, 2049, 2067, 2068, 2069, 2072, 2075, 2133, 2134, 2138, 2161, 2163, 2166, 2169, 210, 468, 516, 574, 598, 668, 707, 767, 799, 843, 874, 928, 975, 1032, 1086, 1139, 1177, 1211, 1282, 1314, 1359, 1381, 1418, 1499, 1530, 1565, 1618, 1670, 1719, 1745, 1778, 1828, 1857, 1886, 1914, 1998, 2043, 2073, 2108, 2167, 2214 |  | 0d |
| 2226 | 11 | **Encerramento** | 21d | 2023-10-23 | 2023-11-22 |  |  | 0d |
| 2227 |  | Apresentar Resultados à Diretoria | 21d | 2023-10-23 | 2023-11-22 | 2225FF |  | 0d |
| 2228 |  | Protocolar o encerramento do programa ao Sistema CIF | 21d | 2023-10-23 | 2023-11-22 | 2225FF |  | 0d |
| 2229 |  | Assinatura do Termo de Aceite | 0d | 2023-11-22 | 2023-11-22 | 27, 29, 30, 32, 2225, 2227, 2228, 31, 3, 4 |  | 0d |
| 2230 |  | Encerramento do Programa | 0d | 2023-11-22 | 2023-11-22 | 2229, 6, 7, 8, 9, 10, 11, 14, 12, 13, 15, 16, 17, 18, 19, 20, 21, 22, 125, 140, 235, 251, 260, 274, 349, 363, 504, 301, 1155, 1166, 1253, 1267, 1297, 1304, 1328, 1431, 1540, 1578, 1630, 1683, 1726, 1732, 1734, 1753, 1790, 1924, 2022, 2124, 2189, 103, 321, 417 |  | 0d |

## Version 2 (data date 2019-12-31, saved 2020-01-17, file Cronograma PG32_200117_(ii).mpp)

Last finish stays 2023-11-22. Complete tasks 621 → 682.

Added:

| ID | Task | Duration | Start | Finish | Predecessors |
| --- | --- | --- | --- | --- | --- |
| 762 | Executar Instalação do Filtro - Poço 1 - Pedra Corrida/MG | 75d | 2020-01-13 | 2020-05-04 | 760SS, 761 |
| 968 | Obter aprovação da OS - Melhorias na ETA exixtente - ETA Santa Rita - Governador Valadares/MG | 14d | 2020-02-20 | 2020-03-13 | 952FS+88d |
| 1134 | Executar ajuste da Captação Principal (Pendente prazo de revisão do projeto) - São Vítor/MG | 126d | 2020-05-28 | 2020-11-25 | 1113FS-15d, 1130FS-15d, 1114, 1133FS+126d |
| 2029 | Realizar contratação ou definir execução com contratos existentes - Captação Alternativa - Melhoria de acessos na lagoa nova (correção de focos erosivos) - Linhares/ES | 15d | 2020-01-06 | 2020-01-24 | 2017FS+21d |
| 2064 | **Suprimentos** | 163d | 2019-10-01 A | 2020-05-29 |  |
| 2065 | **Fornecimento de colmeias e leito filtrante para o SAAE - Linhares/ES** | 142d | 2019-10-01 A | 2020-04-29 |  |
| 2066 | Aprovação da APRO para fornecimento de colmeia e leito filtrante para o SAAE - Linhares/ES | 82d | 2019-10-01 A | 2020-01-29 | 2027FS+8d |
| 2067 | Emissão do pedido para compra de colmeias e leito filtrante para fornecimento ao SAAE - Linhares/ES | 15d | 2020-01-30 | 2020-02-19 | 2066 |
| 2068 | Entrega de colmeias e leito filtrante para o SAAE - Linhares/ES | 30d | 2020-03-17 | 2020-04-29 | 2067FS+15d |
| 2069 | Realizar processo de contratação das Melhorias na ETA e Adequação da Captação Principal - Linhares/ES | 88d | 2020-01-21 | 2020-05-29 | 2054, 2061 |
| 2077 | Conclusão das obras de adequação na Captação Principal e Melhoria de ETA - Linhares/ES | 0d | 2021-01-05 | 2021-01-05 | 2074, 2036, 2073, 2072, 2037, 2076, 2075 |
| 2203 | Emitir RT/PQ para Suprimentos - Captação Principal - Novo Poço - Regência/ES | 10d | 2020-03-11 | 2020-03-24 | 2204FF-58d |
| 2216 | Processo de Contratação da Obra - Novo Poço - Captação Principal - Regência/ES | 88d | 2020-03-25 | 2020-07-30 | 2203 |

Removed: 1799 Obter Aprovação da Operadora e Prefeitura; 2063 Elaborar Projeto Executivo - Automação das Válvulas - Linhares/ES

Changed:

| ID | Task | Start | Finish | Duration | Complete | Total float | Predecessors |
| --- | --- | --- | --- | --- | --- | --- | --- |
| 4 | Cláusula 171, Parágrafo 1º - Conclusão dos Levantamentos de Campo, Projetos Conceituais e Básicos em todas localidades. |  |  |  |  |  | 354, 583, 684, 782, 1369, 1636, 1647, 1763, 2097, 119, 224, 231, 66, 176, 482, 548, 888, 904, 1005, 1056, 1339, 1399, 2155 → 354, 583, 684, 782, 1369, 1636, 1647, 1763, 2097, 119, 224, 231, 66, 176, 482, 548, 888, 904, 1005, 1056, 1339, 1399 |
| 21 | Deliberação 308, Item 2: Determinar à Fundação Renova o atendimento imediato às diretrizes para elaboração de projetos básicos e do fluxograma de procedimento, previstos na Nota Técnica nº 45 da CT-SHQA. |  |  |  |  |  | 354, 583, 684, 782, 1369, 1636, 1647, 1763, 2097, 119, 224, 231, 66, 176, 482, 548, 888, 904, 1005, 1056, 1339, 1399, 2155 → 354, 583, 684, 782, 1369, 1636, 1647, 1763, 2097, 119, 224, 231, 66, 176, 482, 548, 888, 904, 1005, 1056, 1339, 1399 |
| 23 | **Definição** |  | 2019-12-26 → 2020-03-30 (+95d) | 984d → 1047d |  | 970d → 907d |  |
| 31 | Aprovação da Definição do programa pelo CIF | 2019-12-26 → 2020-03-30 (+95d) | 2019-12-26 → 2020-03-30 (+95d) |  |  | 970d → 907d | 30FS+60d → 30FS+123d |
| 33 | **Território Mariana** |  |  |  | 8% → 10% |  |  |
| 49 | **Estudos de Concepção do Sistema - Etapa 2** |  | 2020-04-02 → 2020-05-21 (+49d) | 190d → 222d |  | 428d → 396d |  |
| 51 | **Serviços em Poços Tubulares - Poço 2 - Captação Alternativa** | 2020-02-27 → 2020-04-14 (+47d) | 2020-04-02 → 2020-05-21 (+49d) |  |  | 404d → 372d |  |
| 52 | Realizar Perfuração - Poço 2 - Captação Alternativa - Camargos/MG | 2020-02-27 → 2020-04-14 (+47d) | 2020-02-28 → 2020-04-15 (+47d) |  |  | 404d → 372d |  |
| 53 | Realizar Teste de bombeamento - Poço 2 - Captação Alternativa - Camargos/MG | 2020-03-02 → 2020-04-16 (+45d) | 2020-03-02 → 2020-04-16 (+45d) |  |  | 404d → 372d |  |
| 54 | Realizar Laudo de Serviços de Coleta e Análise de Água - Poço 2 - Captação Alternativa - Camargos/MG | 2020-03-03 → 2020-04-17 (+45d) | 2020-03-30 → 2020-05-18 (+49d) |  |  | 431d → 399d |  |
| 55 | Elaborar Relatório Técnico - Poço 2 - Captação Alternativa - Camargos/MG | 2020-03-03 → 2020-04-17 (+45d) | 2020-03-30 → 2020-05-18 (+49d) |  |  | 404d → 372d |  |
| 56 | Realizar Instrumentação - Poço 2 - Captação Alternativa - Camargos/MG | 2020-03-31 → 2020-05-19 (+49d) | 2020-04-02 → 2020-05-21 (+49d) |  |  | 428d → 396d |  |
| 57 | Conclusão dos Serviços em poço tubular - Poço 2 - Captação Alternativa - Camargos/MG | 2020-04-02 → 2020-05-21 (+49d) | 2020-04-02 → 2020-05-21 (+49d) |  |  | 428d → 396d |  |
| 58 | Conclusão dos Estudos de Concepção das Melhorias do Sistema de Abastecimento de Água - Camargos/MG | 2020-04-02 → 2020-05-21 (+49d) | 2020-04-02 → 2020-05-21 (+49d) |  |  | 428d → 396d |  |
| 70 | **Fundiária** |  | 2020-07-24 → 2020-09-09 (+47d) | 308d → 340d |  | 498d → 466d |  |
| 72 | **Captação Alternativa - Poço 2 - Desimpedimento da Área e Negociação de Servidão** | 2020-03-31 → 2020-05-19 (+49d) | 2020-07-24 → 2020-09-09 (+47d) |  |  | 498d → 466d |  |
| 73 | Realizar Levantamento da documentação da propriedade - Camargos/MG | 2020-03-31 → 2020-05-19 (+49d) | 2020-04-14 → 2020-06-01 (+48d) |  |  | 498d → 466d |  |
| 74 | Obter assinatura do Contrato de servidão pelo proprietário - Camargos/MG | 2020-04-15 → 2020-06-02 (+48d) | 2020-05-14 → 2020-06-30 (+47d) |  |  | 498d → 466d |  |
| 75 | Lavrar Escritura Pública de Servidão no cartório de notas - Camargos/MG | 2020-05-15 → 2020-07-01 (+47d) | 2020-06-26 → 2020-08-11 (+46d) |  |  | 498d → 466d |  |
| 76 | Averbar a escritura pública na matrícula do imóvel - Camargos/MG | 2020-06-29 → 2020-08-12 (+44d) | 2020-07-24 → 2020-09-09 (+47d) |  |  | 498d → 466d |  |
| 77 | Regularização da Servidão do Imóvel - Poço 2 - Camargos/MG | 2020-07-24 → 2020-09-09 (+47d) | 2020-07-24 → 2020-09-09 (+47d) |  |  | 521d → 488d |  |
| 78 | Conclusão da Regularização Fundiária para as obras de Melhoria do Sistema de Abastecimento da Localidade - Camargos/MG | 2020-07-24 → 2020-09-09 (+47d) | 2020-07-24 → 2020-09-09 (+47d) |  |  | 498d → 466d |  |
| 79 | **Licenciamento** | 2019-11-14 → 2020-01-06 (+53d) | 2020-12-08 → 2021-01-26 (+49d) |  |  | 404d → 372d |  |
| 80 | **Captação Alternativa - Autorização de Perfuração Poço 2 (AM) - Captação Principal** | 2019-11-14 → 2020-01-06 (+53d) | 2020-02-21 → 2020-04-13 (+52d) |  |  | 404d → 372d |  |
| 81 | Realizar Análise Inicial da Demanda - Camargos/MG | 2019-11-14 → 2020-01-06 (+53d) | 2019-11-26 → 2020-01-15 (+50d) |  |  | 404d → 372d | 43, 71FS+118d → 43, 71FS+150d |
| 82 | Protocolar FCE e documentos do FOB - Camargos/MG | 2019-11-27 → 2020-01-16 (+50d) | 2019-12-18 → 2020-02-05 (+49d) |  |  | 404d → 372d |  |
| 83 | Acompanhar Processo Junto ao Órgão - Camargos/MG | 2019-12-19 → 2020-02-06 (+49d) | 2020-02-21 → 2020-04-13 (+52d) |  |  | 404d → 372d |  |
| 84 | Obtenção de Autorização de Perfuração - Poço 2 - Camargos/MG | 2020-02-21 → 2020-04-13 (+52d) | 2020-02-21 → 2020-04-13 (+52d) |  |  | 404d → 372d |  |
| 85 | **Outorga para Captação Alternativa (Poço 2)** | 2020-03-31 → 2020-05-19 (+49d) | 2020-12-08 → 2021-01-26 (+49d) |  |  | 404d → 372d |  |
| 86 | Protocolar FCE e documentos do FOB - Camargos/MG | 2020-03-31 → 2020-05-19 (+49d) | 2020-06-03 → 2020-07-20 (+47d) |  |  | 404d → 372d |  |
| 87 | Acompanhar Processo Junto ao Órgão - Camargos/MG | 2020-06-04 → 2020-07-21 (+47d) | 2020-12-08 → 2021-01-26 (+49d) |  |  | 404d → 372d |  |
| 88 | Obtenção da Outorga para captação - Poço 2 - Camargos/MG | 2020-12-08 → 2021-01-26 (+49d) | 2020-12-08 → 2021-01-26 (+49d) |  |  | 404d → 372d |  |
| 89 | Conclusão do Licenciamento Ambiental da Localidade - Camargos/MG | 2020-12-08 → 2021-01-26 (+49d) | 2020-12-08 → 2021-01-26 (+49d) |  |  | 404d → 372d |  |
| 141 | **Pedras (distrito Mariana/MG)** |  |  |  | 9% → 12% |  |  |
| 142 | **Captação Alternativa (Poço Tubular)** |  | 2022-06-24 → 2022-06-17 (-7d) | 1089d → 1084d | 18% → 21% | 351d → 356d |  |
| 143 | **Engenharia** |  | 2020-07-13 → 2020-07-06 (-7d) | 604d → 599d | 62% → 73% | 442d → 447d |  |
| 158 | **Estudos de Concepção do Sistema - Etapa 2** |  | 2019-11-29 → 2020-04-07 (+130d) | 159d → 244d | 80% → 97% | 592d → 507d |  |
| 159 | **Serviços em Poços Tubulares - Poço 2 - Captação Alternativa** |  | 2019-11-29 → 2020-04-07 (+130d) | 159d → 244d | 80% → 97% | 592d → 507d |  |
| 164 | Realizar Instrumentação - Poço 2 - Captação Alternativa - Pedras/MG | 2019-10-14 A → 2020-04-03 (+172d) | 2019-11-29 → 2020-04-07 (+130d) | 34d → 3d | 25% → 0% | 592d → 507d | 163FS+74d → 163FS+190d |
| 165 | Conclusão dos Serviços em poço tubular - Poço 2 - Captação Alternativa - Pedras/MG | 2019-11-29 → 2020-04-07 (+130d) | 2019-11-29 → 2020-04-07 (+130d) |  |  | 592d → 507d |  |
| 166 | Conclusão dos Estudos de Concepção das Melhorias do Sistema de Abastecimento de Água - Pedras/MG | 2019-11-29 → 2020-04-07 (+130d) | 2019-11-29 → 2020-04-07 (+130d) |  |  | 592d → 507d |  |
| 172 | **Engenharia Básica e Detalhada** | 2019-11-04 A | 2020-07-13 → 2020-07-06 (-7d) | 169d → 164d | 0% → 22% | 354d → 447d |  |
| 173 | **Engenharia Captação Alternativa (Poço 2) - Etapa 2** | 2019-11-04 A | 2020-07-13 → 2020-07-06 (-7d) | 169d → 164d | 0% → 22% | 354d → 447d |  |
| 174 | Aprovar Plano de Trabalho e Abrir OSE - OeM - Captação Alternativa - Poço 2 - Pedras/MG | 2019-11-04 A | 2019-11-18 A |  | 0% → 100% | 354d → none |  |
| 175 | Elaborar Projeto Básico - Captação Alternativa - Poço 2 - Pedras/MG | 2019-11-26 A | 2020-03-04 → 2020-02-21 (-12d) | 65d → 60d | 0% → 46% | 354d → 359d |  |
| 176 | Aprovar Projeto Básico com Prefeitura e Operadora - Captação Alternativa - Poço 2 - Pedras/MG | 2020-03-05 → 2020-02-27 (-7d) | 2020-04-03 → 2020-03-27 (-7d) |  |  | 354d → 359d |  |
| 177 | Emitir RT/PQ para Suprimentos - Captação Alternativa - Poço 2 - Pedras/MG | 2020-06-30 → 2020-06-23 (-7d) | 2020-07-13 → 2020-07-06 (-7d) |  |  | 354d → 359d |  |
| 178 | Elaborar Projeto Executivo - Captação Alternativa - Poço 2 - Pedras/MG | 2020-04-06 → 2020-03-30 (-7d) | 2020-07-13 → 2020-07-06 (-7d) |  |  | 354d → 359d |  |
| 179 | Elaboração do Projeto Executivo - Captação Alternativa - Poço 2 - Pedras/MG | 2020-07-13 → 2020-07-06 (-7d) | 2020-07-13 → 2020-07-06 (-7d) |  |  | 442d → 447d |  |
| 180 | Conclusão e Validação da Engenharia - Pedras/MG | 2019-11-29 → 2020-07-06 (+220d) | 2019-11-29 → 2020-07-06 (+220d) |  |  | 592d → 447d | 166 → 166, 179 |
| 181 | **Fundiária** |  | 2020-07-30 → 2020-07-23 (-7d) | 420d → 415d |  | 429d → 434d |  |
| 183 | **Captação Alternativa (Poço 2) - Desimpedimento de Área e Negociação de Servidão** | 2020-04-06 → 2020-03-30 (-7d) | 2020-07-30 → 2020-07-23 (-7d) |  |  | 429d → 434d |  |
| 184 | Realizar Levantamento da documentação da propriedade - Pedras/MG | 2020-04-06 → 2020-03-30 (-7d) | 2020-04-20 → 2020-04-13 (-7d) |  |  | 429d → 434d |  |
| 185 | Obter assinatura do Contrato de servidão pelo proprietário - Pedras/MG | 2020-04-22 → 2020-04-14 (-8d) | 2020-05-20 → 2020-05-13 (-7d) |  |  | 429d → 434d |  |
| 186 | Lavrar Escritura Pública de Servidão no cartório de notas - Pedras/MG | 2020-05-21 → 2020-05-14 (-7d) | 2020-07-02 → 2020-06-25 (-7d) |  |  | 429d → 434d |  |
| 187 | Averbar a escritura pública na matrícula do imóvel - Pedras/MG | 2020-07-03 → 2020-06-26 (-7d) | 2020-07-30 → 2020-07-23 (-7d) |  |  | 429d → 434d |  |
| 188 | Regularização da Servidão do Imóvel - Poço 2 - Pedras/MG | 2020-07-30 → 2020-07-23 (-7d) | 2020-07-30 → 2020-07-23 (-7d) |  |  | 429d → 434d |  |
| 189 | Conclusão da Regularização Fundiária para as obras de Melhoria do Sistema de Abastecimento da Localidade - Pedras/MG | 2020-07-30 → 2020-07-23 (-7d) | 2020-07-30 → 2020-07-23 (-7d) |  |  | 429d → 434d |  |
| 190 | **Licenciamento** |  |  |  | 34% → 66% |  |  |
| 192 | **Outorga para Captação Alternativa - Poço 2** | 2019-11-05 A |  |  | 0% → 49% |  |  |
| 193 | Protocolar FCE e documentos do FOB - Pedras/MG | 2019-11-05 A | 2019-11-19 A |  | 0% → 100% | 534d → none |  |
| 194 | Acompanhar Processo Junto ao Órgão - Pedras/MG | 2019-11-20 A |  |  | 0% → 41% |  |  |
| 197 | **Suprimentos** | 2020-07-14 → 2020-07-07 (-7d) | 2020-11-17 → 2020-11-10 (-7d) |  |  | 354d → 359d |  |
| 198 | Realizar contratação - Captações e ETA - Pedras/MG | 2020-07-14 → 2020-07-07 (-7d) | 2020-11-17 → 2020-11-10 (-7d) |  |  | 354d → 359d |  |
| 199 | Conclusão da Contratação de Suprimentos para as obras de Melhoria do Sistema de Abastecimento de Água- Pedras/MG | 2020-11-17 → 2020-11-10 (-7d) | 2020-11-17 → 2020-11-10 (-7d) |  |  | 354d → 359d |  |
| 200 | **Infraestrutura** | 2020-11-18 → 2020-11-11 (-7d) | 2022-06-24 → 2022-06-17 (-7d) |  |  | 351d → 356d |  |
| 201 | **Obras** | 2020-11-18 → 2020-11-11 (-7d) | 2021-03-18 → 2021-03-11 (-7d) |  |  | 354d → 359d |  |
| 202 | Executar obras de Captação Alternativa (Urbanização e Adução) - Poço 2 - Pedras/MG | 2020-11-18 → 2020-11-11 (-7d) | 2021-03-18 → 2021-03-11 (-7d) |  |  | 354d → 359d |  |
| 203 | Assinatura de Termo de Entrega das Obras de Melhoria do Sistema de Abastecimento de Água - Pedras/MG | 2021-03-18 → 2021-03-11 (-7d) | 2021-03-18 → 2021-03-11 (-7d) |  |  | 667d → 672d |  |
| 204 | **Operação** | 2021-03-19 → 2021-03-12 (-7d) | 2022-06-24 → 2022-06-17 (-7d) |  |  | 351d → 356d |  |

| ID | Task | Start | Finish | Duration | Complete | Total float | Predecessors |
| --- | --- | --- | --- | --- | --- | --- | --- |
| 205 | Realizar Treinamento Operacional do Sistema - Pedras/MG | 2021-03-19 → 2021-03-12 (-7d) | 2021-03-25 → 2021-03-18 (-7d) |  |  | 354d → 359d |  |
| 206 | Realizar Testes e Pré-operação - Pedras/MG | 2021-03-26 → 2021-03-19 (-7d) | 2021-04-15 → 2021-04-08 (-7d) |  |  | 354d → 359d |  |
| 207 | Realizar Acompanhamento da Funcionalidade do Sistema - Captação Alternativa (Poço Tubular) - Pedras (distrito Mariana/MG) | 2021-06-24 → 2021-06-17 (-7d) | 2022-06-24 → 2022-06-17 (-7d) |  |  | 1549.12d → 1570.12d |  |
| 208 | **Operação Assistida** | 2021-03-26 → 2021-03-19 (-7d) | 2021-06-24 → 2021-06-17 (-7d) |  |  | 353d → 358d |  |
| 209 | Realizar Operação Assistida - Pedras/MG | 2021-03-26 → 2021-03-19 (-7d) | 2021-06-24 → 2021-06-17 (-7d) |  |  | 1549.12d → 1570.12d |  |
| 210 | Entrega das obras e conclusão do período de acompanhamento da operação - Pedras/MG | 2022-06-24 → 2022-06-17 (-7d) | 2022-06-24 → 2022-06-17 (-7d) |  |  | 351d → 356d |  |
| 211 | **ETA (Sistema de Tratamento Simplificado) e Captação Principal (Nascente)** |  |  |  | 0% → 3% |  |  |
| 212 | **Engenharia** | 2019-11-04 A |  |  | 0% → 17% | 202d → 753d |  |
| 220 | **Engenharia Básica e Detalhada** | 2019-11-04 A |  |  | 0% → 21% | 202d → 502d |  |
| 221 | **Engenharia Captação Principal (Nascente)** | 2019-11-04 A |  |  | 0% → 23% | 202d → 502d |  |
| 222 | Aprovar Plano de Trabalho e Abrir OSE - OeM - Captação Principal - Pedras/MG | 2019-11-04 A | 2019-11-18 A |  | 0% → 100% | 202d → none |  |
| 223 | Elaborar Projeto Básico - Captação Principal - Nascente - Pedras/MG | 2019-11-26 A |  |  | 0% → 46% |  |  |
| 228 | **Engenharia ETA (Sistema de Tratamento Simplificado)** | 2019-11-04 A |  |  | 0% → 19% | 414d → 502d |  |
| 229 | Aprovar Plano de Trabalho e Abrir OSE - OeM - ETA - Pedras/MG | 2019-11-04 A | 2019-11-18 A |  | 0% → 100% | 414d → none |  |
| 230 | Elaborar Projeto Básico - ETA - Pedras/MG | 2019-11-26 A |  |  | 0% → 35% |  |  |
| 275 | **Território Alto Rio Doce** |  |  |  | 16% → 17% |  |  |
| 276 | **Gesteira (distrito Barra Longa/MG)** |  | 2021-04-29 → 2021-05-05 (+6d) | 1105d → 1109d |  | 640d → 636d |  |
| 308 | **Reforma do Reservatório + Adutora Poço Centro de Saúde + Melhorias no Acesso** |  | 2021-04-29 → 2021-05-05 (+6d) | 390d → 394d |  | 640d → 636d |  |
| 309 | **Infraestrutura** |  | 2021-04-29 → 2021-05-05 (+6d) | 390d → 394d |  | 640d → 636d |  |
| 310 | **Obras - Etapa 2** |  | 2020-04-28 → 2020-05-04 (+6d) | 142d → 145d |  | 888d → 885d |  |
| 312 | Executar Reforma Adutora Poço Beira Rio existente - Gesteira/MG | 2019-11-13 → 2020-01-06 (+54d) | 2020-04-28 → 2020-05-04 (+6d) | 110d → 80d |  | 640d → 637d | 311FS+32d → 311FS+65d |
| 313 | Executar Melhoria em ETA - Ampliação do reservatório - Gesteira/MG | 2019-11-13 → 2020-01-06 (+54d) | 2020-04-28 → 2020-05-04 (+6d) | 110d → 80d |  | 640d → 637d | 311FS+32d → 311FS+65d |
| 314 | Assinatura de Termo de Entrega das Obras de Melhoria do Sistema de Abastecimento de Água - Gesteira/MG | 2020-04-28 → 2020-05-04 (+6d) | 2020-04-28 → 2020-05-04 (+6d) |  |  | 888d → 885d |  |
| 315 | **Operação** | 2020-04-29 → 2020-05-05 (+6d) | 2021-04-29 → 2021-05-05 (+6d) | 248d → 249d |  | 640d → 636d |  |
| 316 | Realizar Treinamento Operacional do Sistema - Gesteira/MG | 2020-04-29 → 2020-05-05 (+6d) | 2020-05-06 → 2020-05-11 (+5d) |  |  | 640d → 637d |  |
| 317 | Realizar Testes e Pré-operação - Gesteira/MG | 2020-04-29 → 2020-05-05 (+6d) | 2020-05-19 → 2020-05-22 (+3d) |  |  | 640d → 637d |  |
| 318 | Realizar Acompanhamento da Funcionalidade do Sistema - Reforma do Reservatório + Adutora Poço Centro de Saúde + Melhorias no Acesso - Gesteira (distrito Barra Longa/MG) | 2020-04-29 → 2020-05-05 (+6d) | 2021-04-29 → 2021-05-05 (+6d) |  |  | 2812.12d → 2794.12d |  |
| 319 | **Operação Assistida** | 2020-04-29 → 2020-05-05 (+6d) | 2021-04-29 → 2021-05-05 (+6d) | 248d → 249d |  | 640d → 636d |  |
| 320 | Realizar Operação Assistida - Gesteira/MG | 2020-04-29 → 2020-05-05 (+6d) | 2020-07-28 → 2020-08-03 (+6d) |  |  | 2812.12d → 2794.12d |  |
| 321 | Entrega das obras e conclusão do período de acompanhamento da operação - Gesteira/MG | 2021-04-29 → 2021-05-05 (+6d) | 2021-04-29 → 2021-05-05 (+6d) |  |  | 640d → 636d |  |
| 322 | **Barreto (distrito Barra Longa/MG)** |  |  |  | 6% → 7% |  |  |
| 323 | **Captação Principal/Alternativa/ETA/Adução** |  |  |  | 6% → 7% |  |  |
| 343 | **Estudos de Concepção do Sistema - Etapa 2** | 2020-04-23 → 2020-06-05 (+43d) | 2020-08-13 → 2020-09-25 (+43d) |  |  | 411d → 395d |  |
| 344 | **Captações Superficiais (Captação Principal) - Nascente 2 (Córrego Barreto)** | 2020-04-23 → 2020-06-05 (+43d) | 2020-08-13 → 2020-09-25 (+43d) |  |  | 411d → 395d |  |
| 345 | Realizar Recuperação de Nascente - Nascente 2 (Córrego Barreto) - Captação Principal - Barreto/MG | 2020-04-23 → 2020-06-05 (+43d) | 2020-07-14 → 2020-08-25 (+42d) |  |  | 411d → 395d |  |
| 346 | Elaborar Relatório Técnico - Nascente 2 (Córrego Barreto) - Captação Principal - Barreto/MG | 2020-07-15 → 2020-08-26 (+42d) | 2020-08-13 → 2020-09-25 (+43d) |  |  | 411d → 395d |  |
| 347 | Realizar Laudo de Serviços de Coleta e Análise de Água - Nascente 2 (Córrego Barreto) - Captação Principal - Barreto/MG | 2020-07-15 → 2020-08-26 (+42d) | 2020-08-13 → 2020-09-25 (+43d) |  |  | 813d → 783d |  |
| 348 | Conclusão da Recuperação da Nascente 2 (Córrego Barreto) - Captação Principal - Barreto/MG | 2020-08-13 → 2020-09-25 (+43d) | 2020-08-13 → 2020-09-25 (+43d) |  |  | 813d → 783d |  |
| 349 | Conclusão dos Estudos de Concepção das Melhorias do Sistema de Abastecimento de Água - Barreto/MG | 2020-08-13 → 2020-09-25 (+43d) | 2020-08-13 → 2020-09-25 (+43d) |  |  | 813d → 783d |  |
| 350 | **Engenharia Básica e Detalhada** | 2019-11-22 A |  |  | 0% → 12% | 382d → 795d |  |
| 351 | **Engenharia Captação Principal/Alternativa/ETA/Adução** | 2019-11-22 A |  |  | 0% → 13% | 382d → 482d |  |
| 352 | Aprovar Plano de Trabalho e abrir OSE - Captação Principal/Alternativa/ETA/Adução - Barreto/MG | 2019-11-22 A | 2019-12-05 A |  | 0% → 100% | 382d → none |  |
| 353 | Executar Topografia - Captação Principal/Alternativa/ETA/Adução - Barreto/MG | 2019-12-06 A | 2019-12-31 A |  | 0% → 100% | 382d → none |  |
| 364 | **Fundiária** |  | 2020-07-31 → 2020-09-14 (+45d) | 578d → 608d |  | 477d → 447d |  |
| 366 | Obter Termo de Autorização do Superficiário - Captação Alternativa (Nascente 2) - Barreto/MG | 2019-11-22 → 2020-01-09 (+48d) | 2019-12-05 → 2020-01-22 (+48d) |  |  | 411d → 395d | 342FS+120d → 342FS+150d |
| 368 | **Captação Alternativa (Nascente 1) - Desimpedimento de Área e Negociação de Servidão** | 2019-12-06 → 2020-01-23 (+48d) | 2020-04-06 → 2020-05-21 (+45d) |  |  | 557d → 527d |  |
| 369 | Realizar Levantamento da documentação da propriedade - Barreto/MG | 2019-12-06 → 2020-01-23 (+48d) | 2019-12-20 → 2020-02-05 (+47d) |  |  | 557d → 527d |  |
| 370 | Obter assinatura do Contrato de servidão pelo proprietário - Barreto/MG | 2019-12-23 → 2020-02-06 (+45d) | 2020-01-22 → 2020-03-09 (+47d) |  |  | 557d → 527d |  |
| 371 | Lavrar Escritura Pública de Servidão no cartório de notas - Barreto/MG | 2020-01-23 → 2020-03-10 (+47d) | 2020-03-09 → 2020-04-22 (+44d) |  |  | 557d → 527d |  |
| 372 | Averbar a escritura pública na matrícula do imóvel - Barreto/MG | 2020-03-10 → 2020-04-23 (+44d) | 2020-04-06 → 2020-05-21 (+45d) |  |  | 557d → 527d |  |
| 373 | Regularização da Servidão - Nascente 1 - Barreto/MG | 2020-04-06 → 2020-05-21 (+45d) | 2020-04-06 → 2020-05-21 (+45d) |  |  | 557d → 527d |  |
| 374 | **Captação Alternativa (Nascente 2) - Desimpedimento de Área e Negociação de Servidão** | 2019-12-06 → 2020-01-23 (+48d) | 2020-04-06 → 2020-05-21 (+45d) |  |  | 477d → 447d |  |
| 375 | Realizar Levantamento da documentação da propriedade - Barreto/MG | 2019-12-06 → 2020-01-23 (+48d) | 2019-12-20 → 2020-02-05 (+47d) |  |  | 477d → 447d |  |
| 376 | Obter assinatura do Contrato de servidão pelo proprietário - Barreto/MG | 2019-12-23 → 2020-02-06 (+45d) | 2020-01-22 → 2020-03-09 (+47d) |  |  | 557d → 527d |  |
| 377 | Lavrar Escritura Pública de Servidão no cartório de notas - Barreto/MG | 2020-01-23 → 2020-03-10 (+47d) | 2020-03-09 → 2020-04-22 (+44d) |  |  | 557d → 527d |  |
| 378 | Averbar a escritura pública na matrícula do imóvel - Barreto/MG | 2020-03-10 → 2020-04-23 (+44d) | 2020-04-06 → 2020-05-21 (+45d) |  |  | 557d → 527d |  |
| 379 | Regularização da Servidão (Nascente 2) - Barreto/MG | 2020-04-06 → 2020-05-21 (+45d) | 2020-04-06 → 2020-05-21 (+45d) |  |  | 557d → 527d |  |
| 380 | **ETA (STA Simplificado)/Adutora - Desimpedimento de Área e Negociação de Servidão** | 2019-12-06 → 2020-01-23 (+48d) | 2020-07-31 → 2020-09-14 (+45d) |  |  | 477d → 447d |  |
| 381 | Realizar Levantamento da documentação da propriedade - Barreto/MG | 2019-12-06 → 2020-01-23 (+48d) | 2019-12-20 → 2020-02-05 (+47d) |  |  | 477d → 447d |  |
| 382 | Obter assinatura do Contrato de servidão pelo proprietário - Barreto/MG | 2019-12-23 → 2020-02-06 (+45d) | 2020-01-22 → 2020-03-09 (+47d) |  |  | 477d → 447d |  |
| 383 | Lavrar Escritura Pública de Servidão no cartório de notas - Barreto/MG | 2020-01-23 → 2020-03-10 (+47d) | 2020-07-03 → 2020-08-14 (+42d) |  |  | 477d → 447d |  |
| 384 | Averbar a escritura pública na matrícula do imóvel - Barreto/MG | 2020-07-06 → 2020-08-17 (+42d) | 2020-07-31 → 2020-09-14 (+45d) |  |  | 477d → 447d |  |
| 385 | Regularização da Servidão - ETA (STA Simplificado)/Adutora - Barreto/MG | 2020-07-31 → 2020-09-14 (+45d) | 2020-07-31 → 2020-09-14 (+45d) |  |  | 477d → 447d |  |
| 386 | Conclusão da Regularização Fundiária para as obras de Melhoria do Sistema de Abastecimento da Localidade - Barreto/MG | 2020-07-31 → 2020-09-14 (+45d) | 2020-07-31 → 2020-09-14 (+45d) |  |  | 477d → 447d |  |
| 387 | **Licenciamento** | 2019-11-22 → 2020-01-09 (+48d) | 2020-11-23 → 2020-12-15 (+22d) | 248d → 234d |  | 411d → 395d |  |
| 388 | **Captação Alternativa (Nascente 1) - Certidão de Uso Insignificante e DAIA para acumulação de água** | 2019-11-22 → 2020-01-09 (+48d) | 2020-10-07 → 2020-11-20 (+44d) |  |  | 430d → 400d |  |
| 389 | Enviar a documentação à prefeitura para obter a certidão de uso insignificante - Barreto/MG | 2019-11-22 → 2020-01-09 (+48d) | 2019-11-22 → 2020-01-09 (+48d) |  |  | 430d → 400d |  |
| 390 | Realizar Análise Inicial da Demanda para DAIA para acumulação de água - Barreto/MG | 2019-11-25 → 2020-01-10 (+46d) | 2019-12-06 → 2020-01-23 (+48d) |  |  | 430d → 400d |  |
| 391 | Elaborar Estudos Ambientais para DAIA para acumulação de água - Barreto/MG | 2019-12-09 → 2020-01-24 (+46d) | 2020-01-23 → 2020-03-10 (+47d) |  |  | 430d → 400d |  |
| 392 | Acompanhar Processo Junto ao Órgão para DAIA para acumulação de água - Barreto/MG | 2020-01-24 → 2020-03-11 (+47d) | 2020-10-07 → 2020-11-20 (+44d) |  |  | 430d → 400d |  |

| ID | Task | Start | Finish | Duration | Complete | Total float | Predecessors | Other |
| --- | --- | --- | --- | --- | --- | --- | --- | --- |
| 393 | Obtenção de DAIA para acumulação de água - Nascente 1 - Barreto/MG | 2020-10-07 → 2020-11-20 (+44d) | 2020-10-07 → 2020-11-20 (+44d) |  |  | 430d → 400d |  |  |
| 394 | **Captação Alternativa (Nascente 2) - Certidão de Uso Insignificante e DAIA para acumulação de água** | 2019-12-06 → 2020-01-23 (+48d) | 2020-11-23 → 2020-12-15 (+22d) | 238d → 224d |  | 411d → 395d |  |  |
| 395 | Enviar a documentação à prefeitura para obter a certidão de uso insignificante - Barreto/MG | 2019-12-06 → 2020-01-23 (+48d) | 2019-12-06 → 2020-01-23 (+48d) |  |  | 579d → 563d |  |  |
| 396 | Realizar Análise Inicial da Demanda para DAIA para acumulação de água - Barreto/MG | 2020-08-14 → 2020-09-28 (+45d) | 2020-08-27 → 2020-10-09 (+43d) |  |  | 411d → 395d |  |  |
| 397 | Elaborar Estudos Ambientais para DAIA para acumulação de água - Barreto/MG | 2020-08-28 → 2020-10-13 (+46d) | 2020-09-18 → 2020-11-03 (+46d) |  |  | 411d → 395d |  |  |
| 398 | Acompanhar Processo Junto ao Órgão para DAIA para acumulação de água - Barreto/MG | 2020-09-21 → 2020-11-04 (+44d) | 2020-11-23 → 2020-12-15 (+22d) | 44d → 30d |  | 411d → 395d |  |  |
| 399 | Obtenção de DAIA para acumulação de água - Nascente 2 - Barreto/MG | 2020-11-23 → 2020-12-15 (+22d) | 2020-11-23 → 2020-12-15 (+22d) |  |  | 411d → 395d |  |  |
| 401 | Conclusão do Licenciamento Ambiental da Localidade - Barreto/MG | 2020-11-23 → 2020-12-15 (+22d) | 2020-11-23 → 2020-12-15 (+22d) |  |  | 411d → 395d |  |  |
| 418 | **Território Calha do Rio Doce** |  |  |  | 34% → 37% |  |  |  |
| 419 | **Ipaba do Paraíso (distrito Santana do Paraíso/MG)** |  |  |  | 34% → 37% |  |  |  |
| 420 | **Sistemas de Abastecimento Individuais** |  |  |  | 34% → 37% |  |  |  |
| 433 | **Estudos de Concepção do Sistema - Etapa 2** | 2019-11-19 A |  |  | 0% → 21% | 659d → 907d |  |  |
| 434 | **Serviços em Cisternas e Poços** | 2019-11-19 A |  |  | 0% → 21% |  |  |  |
| 435 | Realizar Estudo de Geofísica e emitir relatório - Ipaba do Paraíso/MG | 2019-11-19 A |  |  | 0% → 64% |  |  | was named Realizar Estudo de Geofísica - Ipaba do Paraíso/MG |
| 453 | **Licenciamento - Poços** |  |  |  | 6% → 23% |  |  |  |
| 454 | Obter Autorização para Perfuração (Poços) - Ipaba do Paraíso/MG |  | 2019-12-30 A |  | 25% → 100% | 540d → none |  |  |
| 455 | Obter Outorga/Certidão de Uso Insignificante para Captação Subterrânea (Poços) - Ipaba do Paraíso/MG | 2019-12-31 → 2020-01-20 (+20d) |  | 180d → 167d |  |  | 454 → 454FS+13d | was named Obter Outorga para Captação Subterrânea (Poços) - Ipaba do Paraíso/MG |
| 457 | **Infraestrutura** | 2019-12-19 → 2020-02-17 (+60d) |  | 435d → 396d |  |  |  |  |
| 458 | **Obras** | 2019-12-19 → 2020-02-17 (+60d) |  | 186d → 147d |  | 636d → 617d |  |  |
| 459 | Executar obras dos Sistema Individuais de Abastecimento de Água - Etapa 1 - Ipaba do Paraíso/MG | 2019-12-19 → 2020-02-17 (+60d) | 2020-05-05 → 2020-05-18 (+13d) | 90d → 60d |  | 636d → 627d | 430FS+88d → 430FS+127d |  |
| 469 | **Território Médio Rio Doce** |  |  |  | 26% → 28% |  |  |  |
| 470 | **Cachoeira Escura (distrito Belo Oriente/MG)** |  |  |  | 33% → 35% |  |  |  |
| 471 | **Captação Principal e Melhorias na ETA** |  | 2022-07-01 → 2022-06-25 (-6d) | 1079d → 1074d | 25% → 29% | 345d → 350d |  |  |
| 475 | **Engenharia Básica e Detalhada** |  | 2020-04-20 → 2020-01-15 A (-96d) | 395d → 331d | 79% → 100% | 570d → none |  |  |
| 476 | **Engenharia Captação Principal (Melhorias) - SE 32159** |  | 2020-04-20 → 2020-01-15 A (-96d) | 395d → 331d | 65% → 100% | 570d → none |  |  |
| 481 | Elaborar Projeto Básico - Captação Principal - Rio Doce - Cachoeira Escura/MG |  | 2019-12-17 A |  | 55% → 100% | 347d → none |  |  |
| 482 | Aprovar Projeto Básico - Captação Principal - Rio Doce - Cachoeira Escura/MG | 2019-12-18 A | 2020-01-21 → 2020-01-15 A (-6d) | 22d → 18d | 0% → 100% | 347d → none |  |  |
| 483 | Emitir RT/PQ para Suprimentos - Captação Principal - Rio Doce - Cachoeira Escura/MG | 2019-10-16 A → 2019-12-03 A (+48d) | 2019-10-29 A → 2019-12-17 A (+49d) |  |  |  | 482SS+7d → 481FF |  |
| 484 | Elaborar Projeto Executivo - Captação Principal - Rio Doce - Cachoeira Escura/MG | 2020-01-22 → 2019-09-23 A (-121d) | 2020-04-20 → 2019-12-17 A (-125d) |  | 0% → 100% | 495d → none | 482 → 481FF |  |
| 485 | Elaboração do Projeto Executivo - Captação Principal - Rio Doce - Cachoeira Escura/MG | 2020-04-20 → 2019-12-17 A (-125d) | 2020-04-20 → 2019-12-17 A (-125d) |  | 0% → 100% | 570d → none |  |  |
| 492 | **Engenharia Melhorias ETA - Etapa 2** |  | 2019-11-11 → 2019-11-22 A (+11d) | 156d → 164d | 91% → 100% | 676d → none |  |  |
| 493 | Elaborar Projeto Executivo (Redimensionamento das Bombas e relocação do painel) SE 32158 - Melhorias na ETA - Cachoeira Escura/MG |  | 2019-11-11 → 2019-11-22 A (+11d) | 156d → 164d | 91% → 100% | 676d → none |  |  |
| 494 | Elaboração do Projeto Executivo - Melhorias na ETA - Cachoeira Escura/MG | 2019-11-11 → 2019-11-22 A (+11d) | 2019-11-11 → 2019-11-22 A (+11d) |  | 0% → 100% | 676d → none |  |  |
| 498 | **Licenciamento** | 2020-01-22 → 2020-01-16 (-6d) | 2020-11-20 → 2020-11-16 (-4d) |  |  | 347d → 351d |  |  |
| 499 | Obter Outorga para Adequação da Captação no Rio Doce - Captação Principal - Cachoeira Escura/MG | 2020-01-22 → 2020-01-16 (-6d) | 2020-11-20 → 2020-11-16 (-4d) |  |  | 347d → 351d |  |  |
| 500 | **DAIA para Captação Principal** | 2020-01-22 → 2020-01-16 (-6d) | 2020-10-26 → 2020-10-20 (-6d) |  |  | 355d → 359d |  |  |
| 501 | Protocolar FCE e documentos do FOB - Cachoeira Escura/MG | 2020-01-22 → 2020-01-16 (-6d) | 2020-02-04 → 2020-01-29 (-6d) |  |  | 355d → 359d |  |  |
| 502 | Acompanhar Processo Junto ao Órgão - Pedido de Informação Complementar - Cachoeira Escura/MG | 2020-02-05 → 2020-01-30 (-6d) | 2020-10-26 → 2020-10-20 (-6d) |  |  | 355d → 359d |  |  |
| 503 | Obtenção da DAIA para Captação Principal - Captação rio Doce - Cachoeira Escura/MG | 2020-10-26 → 2020-10-20 (-6d) | 2020-10-26 → 2020-10-20 (-6d) |  |  | 355d → 359d |  |  |
| 504 | Conclusão do Licenciamento Ambiental da Localidade - Cahoeira Escura/MG | 2020-11-20 → 2020-11-16 (-4d) | 2020-11-20 → 2020-11-16 (-4d) |  |  | 745d → 749d |  |  |
| 505 | **Infraestrutura** |  | 2022-07-01 → 2022-06-25 (-6d) | 808d → 803d |  | 345d → 350d |  |  |
| 508 | **Obras - Etapa 2** |  | 2021-07-01 → 2021-06-25 (-6d) | 298d → 294d |  |  |  |  |
| 509 | Contrato Guarda-Chuva(Captações e Melhorias ETA) - Cachoeira Escura/MG |  |  |  |  |  | 483, 485, 490, 491, 493, 494 → 483FS+82d, 485, 490, 491, 493, 494 |  |
| 510 | Executar Captação Principal (Melhorias - rio Doce) - Cachoeira Escura/MG | 2020-11-23 → 2020-11-17 (-6d) | 2021-07-01 → 2021-06-25 (-6d) |  |  | 347d → 351d |  |  |
| 512 | Assinatura de Termo de Entrega das Obras de Melhoria do Sistema de Abastecimento de Água - Cachoeira Escura/MG | 2021-07-01 → 2021-06-25 (-6d) | 2021-07-01 → 2021-06-25 (-6d) |  |  | 595d → 599d |  |  |
| 513 | **Operação** | 2021-07-01 → 2021-06-25 (-6d) | 2022-07-01 → 2022-06-25 (-6d) | 250d → 249d |  | 345d → 350d |  |  |
| 514 | Realizar Treinamento Operacional do Sistema - Cachoeira Escura/MG | 2021-07-02 → 2021-06-28 (-4d) | 2021-07-08 → 2021-07-02 (-6d) |  |  | 576d → 580d |  |  |
| 515 | Realizar Testes e Pré-operação - Cachoeira Escura/MG | 2021-07-09 → 2021-07-05 (-4d) | 2021-07-28 → 2021-07-22 (-6d) |  |  | 576d → 580d |  |  |
| 516 | Realizar Acompanhamento da Funcionalidade do Sistema - Captação Principal e Melhorias na ETA - Cachoeira Escura (distrito Belo Oriente/MG) | 2021-07-01 → 2021-06-25 (-6d) | 2022-07-01 → 2022-06-25 (-6d) |  |  | 1527d → 1545d |  |  |
| 517 | **Operação Assistida** | 2021-07-01 → 2021-06-25 (-6d) | 2021-09-29 → 2021-09-23 (-6d) |  |  | 346d → 350d |  |  |
| 518 | Realizar Operação Assistida - Cachoeira Escura/MG | 2021-07-01 → 2021-06-25 (-6d) | 2021-09-29 → 2021-09-23 (-6d) |  |  | 1527d → 1545d |  |  |
| 519 | **Captação Alternativa** |  |  |  | 54% → 55% |  |  |  |
| 541 | **Engenharia Básica e Detalhada** |  |  |  | 48% → 52% |  |  |  |
| 542 | **Engenharia Captação Alternativa (3 novos poços) - SE 32316** |  |  |  | 48% → 52% |  |  |  |
| 547 | Elaborar Projeto Básico - Captação Alternativa - 3 novos poços - Cachoeira Escura/MG | 2019-11-01 A |  |  | 0% → 20% |  |  |  |
| 556 | **Licenciamento** |  | 2019-11-11 → 2020-01-13 (+63d) | 466d → 506d |  | 571d → 531d |  |  |
| 558 | **DAIA para Captação Alternativa (Poço dentro da ETA e UTR)** |  | 2019-11-11 → 2020-01-13 (+63d) | 466d → 506d |  | 571d → 531d |  |  |
| 563 | Acompanhar Processo Junto ao Órgão - Cachoeira Escura/MG |  | 2019-11-11 → 2020-01-13 (+63d) | 126d → 166d | 94% → 95% | 571d → 531d |  |  |
| 564 | Obtenção da DAIA para captação - (Poço dentro da ETA e UTR) - Cachoeira Escura/MG | 2019-11-11 → 2020-01-13 (+63d) | 2019-11-11 → 2020-01-13 (+63d) |  |  | 571d → 531d |  |  |
| 565 | Conclusão do Licenciamento Ambiental da Localidade - Cahoeira Escura/MG | 2019-11-11 → 2020-01-13 (+63d) | 2019-11-11 → 2020-01-13 (+63d) |  |  | 571d → 531d |  |  |
| 577 | **UTR** | 2019-11-04 A |  |  | 0% → 2% |  |  |  |
| 578 | **Engenharia** | 2019-11-04 A |  |  | 0% → 13% | 216d → 226d |  |  |
| 579 | **Engenharia Básica e Detalhada** | 2019-11-04 A |  |  | 0% → 13% | 216d → 226d |  |  |
| 580 | **Engenharia UTR - 40L/s** | 2019-11-04 A |  |  | 0% → 13% | 216d → 226d |  |  |
| 581 | Aprovar Plano de Trabalho e abrir OSE - UTR - Cachoeira Escura/MG | 2019-11-04 A | 2019-11-25 → 2019-12-03 A (+8d) | 15d → 21d | 0% → 100% | 216d → none |  |  |
| 582 | Elaborar arranjo para obtenção de Dados de Entrada Licenciamento e Fundiário - UTR - Cachoeira Escura/MG | 2019-11-26 → 2019-12-04 A (+8d) |  | 105d → 99d | 0% → 25% |  |  |  |
| 601 | **Senhora da Penha (distrito Fernandes Tourinho/MG)** |  |  |  | 19% → 20% |  |  |  |
| 602 | **Engenharia Captação Alternativa - Poço 3** |  |  |  | 29% → 30% |  |  |  |
| 653 | **Fundiária** |  | 2019-12-20 → 2020-01-03 (+14d) | 136d → 143d | 41% → 99% | 366d → 4d |  |  |
| 654 | [Cancelada] Obter Termo de Autorização do Superficiário (Poço 3) - Geofísica - Captação Alternativa - Senhora da Penha/MG |  |  |  |  |  |  | was named Obter Termo de Autorização do Superficiário (Poço 3) - Geofísica - Captação Alternativa - Senhora da Penha/MG |

| ID | Task | Start | Finish | Duration | Complete | Total float | Predecessors | Other |
| --- | --- | --- | --- | --- | --- | --- | --- | --- |
| 655 | [Cancelada] Obter Termo de Autorização do Superficiário (Poço 3) - Perfuração - Captação Alternativa - Senhora da Penha/MG |  | 2019-12-20 A |  | 25% → 100% | 366d → none |  | was named Obter Termo de Autorização do Superficiário (Poço 3) - Perfuração - Captação Alternativa - Senhora da Penha/MG |
| 656 | Conclusão da Regularização Fundiária para as obras de Melhoria do Sistema de Abastecimento da Localidade - Senhora da Penha/MG | 2019-12-20 → 2020-01-03 (+14d) | 2019-12-20 → 2020-01-03 (+14d) |  |  | 366d → 4d | 655 → 655FS+7d |  |
| 657 | **Licenciamento** | 2019-12-23 A |  |  | 0% → 25% | 366d → 680d |  |  |
| 658 | [Cancelada] Captação Alternativa - Autorização de perfuração (Poço 3) - Senhora da Penha/MG | 2019-12-23 A |  |  | 0% → 25% |  |  | was named Captação Alternativa - Autorização de perfuração (Poço 3) - Senhora da Penha/MG |
| 677 | **Engenharia Básica e Detalhada** | 2019-12-27 A |  |  | 0% → 1% | 322d → 415d |  |  |
| 678 | **Engenharia Captação Principal, Nova ETA e UTR** | 2019-12-27 A |  |  | 0% → 1% | 322d → 415d |  |  |
| 679 | Aprovar Plano de Trabalho e abrir OSE - Captação Principal, ETA/UTR - Senhora da Penha/MG | 2019-12-27 A |  |  | 0% → 9% | 322d → 435d |  |  |
| 710 | **Pedra Corrida (distrito Periquito/MG)** |  |  |  | 32% → 36% |  |  |  |
| 711 | **Captação Principal, Alternativa e Melhorias em ETA** |  | 2021-01-02 → 2021-01-09 (+7d) | 747d → 752d | 50% → 56% | 718d → 713d |  |  |
| 747 | **Licenciamento** |  | 2019-12-30 → 2020-01-22 (+23d) | 497d → 513d | 81% → 80% | 968d → 952d |  |  |
| 749 | Obter DAIA para Captação Alternativa (Poço 1) - Pedra Corrida/MG |  | 2019-12-30 → 2020-01-22 (+23d) | 497d → 513d |  | 720d → 952d |  |  |
| 750 | Conclusão do Licenciamento Ambiental da Localidade - Pedra Corrida/MG | 2019-12-30 → 2020-01-22 (+23d) | 2019-12-30 → 2020-01-22 (+23d) |  |  | 968d → 952d |  |  |
| 751 | **Infraestrutura** |  | 2021-01-02 → 2021-01-09 (+7d) | 399d → 404d | 8% → 22% | 718d → 713d |  |  |
| 752 | **Obras** |  | 2020-01-03 → 2020-05-04 (+122d) | 152d → 232d | 38% → 85% | 965d → 885d |  |  |
| 753 | **Captação Principal e Melhorias em ETA** |  | 2019-12-30 → 2020-01-22 (+23d) | 149d → 165d | 62% → 99% | 968d → 952d |  |  |
| 755 | Executar Captação Principal (Melhorias) - Pedra Corrida/MG |  | 2019-11-01 → 2019-11-22 A (+21d) | 84d → 98d | 70% → 100% | 757d → none |  |  |
| 756 | Executar Melhorias de ETA - Pedra Corrida/MG |  | 2019-11-01 → 2020-01-10 A (+70d) | 84d → 129d | 70% → 100% | 757d → none |  |  |
| 757 | Realizar fornecimento dos Pallets de Contenção de Químicos (Melhorias em ETA) - Pedra Corrida/MG |  | 2019-11-28 → 2019-11-18 A (-10d) | 39d → 31d | 25% → 100% | 987d → none |  |  |
| 758 | Conclusão das Obras de Captação Principal e Melhorias em ETA - Pedra Corrida/MG | 2019-12-30 → 2020-01-22 (+23d) | 2019-12-30 → 2020-01-22 (+23d) |  |  | 968d → 952d |  |  |
| 759 | **Captação Alternativa** |  | 2020-01-03 → 2020-05-04 (+122d) | 75d → 155d | 4% → 68% | 965d → 885d |  |  |
| 760 | Executar Captação Alternativa (Adutora - Poço 1) - Pedra Corrida/MG |  | 2020-01-03 → 2020-01-10 A (+7d) | 75d → 80d | 4% → 100% | 717d → none |  |  |
| 761 | Executar Urbanização do Poço 1 - Pedra Corrida/MG |  | 2020-01-03 → 2020-01-10 A (+7d) | 75d → 80d | 4% → 100% | 965d → none |  |  |
| 763 | Conclusão das Obras de Captação Alternativa - Pedra Corrida/MG | 2020-01-03 → 2020-05-04 (+122d) | 2020-01-03 → 2020-05-04 (+122d) |  |  | 965d → 885d | 760, 761 → 760, 761, 762 |  |
| 764 | Assinatura de Termo de Entrega das Obras de Melhoria do Sistema de Abastecimento de Água - Pedra Corrida/MG | 2020-01-03 → 2020-05-04 (+122d) | 2020-01-03 → 2020-05-04 (+122d) |  |  | 965d → 885d |  |  |
| 765 | **Operação** | 2020-01-03 → 2020-01-10 (+7d) | 2021-01-02 → 2021-01-09 (+7d) |  |  | 717d → 712d |  |  |
| 766 | Realizar Treinamento Operacional do Sistema - Pedra Corrida/MG | 2020-01-06 → 2020-01-13 (+7d) | 2020-01-10 → 2020-01-17 (+7d) |  |  | 946d → 941d |  |  |
| 767 | Realizar Testes e Pré-operação - Pedra Corrida/MG | 2020-01-13 → 2020-01-20 (+7d) | 2020-01-30 → 2020-02-06 (+7d) |  |  | 946d → 941d |  |  |
| 768 | Realizar Acompanhamento da Funcionalidade do Sistema - Captação Principal, Alternativa e Melhorias em ETA - Pedra Corrida (distrito Periquito/MG) | 2020-01-03 → 2020-01-10 (+7d) | 2021-01-02 → 2021-01-09 (+7d) |  |  | 3162d → 3141d |  |  |
| 769 | **Operação Assistida** | 2020-01-03 → 2020-01-10 (+7d) | 2020-04-02 → 2020-04-09 (+7d) |  |  | 717d → 712d |  |  |
| 770 | Realizar Operação Assistida - Pedra Corrida/MG | 2020-01-03 → 2020-01-10 (+7d) | 2020-04-02 → 2020-04-09 (+7d) |  |  | 3162d → 3141d |  |  |
| 777 | **Engenharia Básica e Detalhada** |  |  |  | 1% → 7% |  |  |  |
| 778 | **Engenharia UTR** |  |  |  | 1% → 7% |  |  |  |
| 779 | Aprovar Plano de Trabalho /abertura OSE - UTR - Pedra Corrida/MG |  | 2019-11-04 A |  | 25% → 100% | 192d → none |  |  |
| 780 | Realizar Sondagem - UTR - Pedra Corrida/MG | 2019-11-05 A | 2019-11-12 A |  | 0% → 100% | 192d → none |  |  |
| 847 | **Governador Valadares/MG (sede)** |  |  |  | 27% → 29% |  |  |  |
| 883 | **Engenharia Captação Principal - ETA Central (Melhorias) - SE 32008** |  | 2020-07-30 → 2020-09-25 (+57d) | 556d → 596d |  | 375d → 335d |  |  |
| 886 | Realizar testes para definição do dimensionamento do novo conjunto flutuante - Captação Principal - ETA Central - Governador Valadares/MG |  | 2019-12-30 → 2020-02-28 (+60d) | 114d → 154d |  | 375d → 335d |  |  |
| 887 | Realizar Sondagem Mista - Captação Principal - ETA Central - Governador Valadares/MG | 2019-11-11 A | 2019-12-11 → 2019-11-14 A (-27d) | 22d → 4d | 0% → 100% | 530d → none |  |  |
| 888 | Elaborar Projeto Básico - Captação Principal - ETA Central - Governador Valadares/MG | 2020-01-09 → 2020-03-10 (+61d) | 2020-04-22 → 2020-06-19 (+58d) |  |  | 375d → 335d |  |  |
| 889 | Aprovar Projeto Básico - Captação Principal - ETA Central - Governador Valadares/MG | 2020-04-23 → 2020-06-22 (+60d) | 2020-05-25 → 2020-07-21 (+57d) |  |  | 375d → 335d |  |  |
| 890 | Emitir RT/PQ para Suprimentos - Captação Principal - ETA Central - Governador Valadares/MG | 2020-07-16 → 2020-09-11 (+57d) | 2020-07-30 → 2020-09-25 (+57d) |  |  | 375d → 335d |  |  |
| 891 | Elaborar Projeto Executivo - Captação Principal - ETA Central - Governador Valadares/MG | 2020-05-26 → 2020-07-22 (+57d) | 2020-07-30 → 2020-09-25 (+57d) |  |  | 375d → 335d |  |  |
| 892 | Elaboração do Projeto Executivo - Captação Principal - ETA Central - Governador Valadares/MG | 2020-07-30 → 2020-09-25 (+57d) | 2020-07-30 → 2020-09-25 (+57d) |  |  | 375d → 335d |  |  |
| 893 | **Engenharia Melhorias ETA - ETA Central - SE 32260** |  | 2019-12-19 → 2019-11-28 A (-21d) | 258d → 244d | 96% → 100% | 642d → none |  |  |
| 897 | Elaborar Projeto Executivo (Acréscimo do Macromedidor na SE) - Melhorias na ETA - ETA Central - Governador Valadares/MG |  | 2019-12-19 → 2019-11-28 A (-21d) | 67d → 53d | 85% → 100% | 642d → none |  |  |
| 898 | Elaboração do Projeto Executivo - Melhorias na ETA - ETA Central - Governador Valadares/MG | 2019-12-19 → 2019-11-28 A (-21d) | 2019-12-19 → 2019-11-28 A (-21d) |  | 0% → 100% | 642d → none |  |  |
| 932 | **ETA Santa Rita** |  | 2021-11-06 → 2022-03-22 (+136d) | 1066d → 1158d | 35% → 37% | 507d → 415d |  |  |
| 960 | **Suprimentos** |  | 2019-11-01 → 2020-01-17 (+77d) | 122d → 172d | 38% → 70% | 507d → 417d |  |  |
| 961 | **Santa Rita** |  | 2019-11-01 → 2020-01-17 (+77d) | 122d → 172d | 38% → 70% | 507d → 417d |  |  |
| 963 | Processo contratação Nova ETA (Captações, nova ETA e UTR) - ETA Santa Rita - Governador Valadares/MG |  | 2019-11-01 → 2020-01-17 (+77d) | 100d → 150d | 25% → 66% | 507d → 417d |  |  |
| 964 | Conclusão da Contratação de Suprimentos - ETA Santa Rita - Governador Valadares/MG | 2019-11-01 → 2020-01-17 (+77d) | 2019-11-01 → 2020-01-17 (+77d) |  |  | 507d → 417d |  |  |
| 965 | **Infraestrutura** | 2019-11-04 → 2020-02-20 (+108d) | 2021-11-06 → 2022-03-22 (+136d) | 498d → 517d |  | 507d → 415d |  |  |
| 966 | **Obras** | 2019-11-04 → 2020-02-20 (+108d) | 2020-11-06 → 2021-03-22 (+136d) | 250d → 267d |  | 507d → 434d |  |  |
| 967 | **ETA Santa Rita** | 2019-11-04 → 2020-02-20 (+108d) | 2020-11-06 → 2021-03-22 (+136d) | 250d → 267d |  | 507d → 434d |  |  |
| 969 | Executar Melhorias na ETA existente (36L/s) - ETA Santa Rita - Governador Valadares/MG | 2019-11-04 → 2020-03-16 (+133d) | 2020-01-31 → 2020-06-10 (+131d) |  |  | 697d → 610d | 943, 952, 954, 957, 963 → 943, 952, 954, 957, 963, 968 | was named Executar Melhorias na ETA existente - ETA Santa Rita - Governador Valadares/MG |
| 970 | Executar Nova ETA/Captação Principal/UTR (120L/s) - ETA Santa Rita - Governador Valadares/MG | 2019-11-04 → 2020-03-19 (+136d) | 2020-11-06 → 2021-03-22 (+136d) |  |  | 507d → 417d | 943, 958, 963, 955, 964, 959 → 943, 958, 963, 955, 964FS+40d, 959 | was named Executar Nova ETA/Captação Principal/UTR - ETA Santa Rita - Governador Valadares/MG |
| 971 | Assinatura de Termo de Entrega das Obras de Melhoria do Sistema de Abastecimento de Água ETA Santa Rita - Governador Valadares/MG | 2020-11-06 → 2021-03-22 (+136d) | 2020-11-06 → 2021-03-22 (+136d) |  |  | 755d → 665d |  |  |
| 972 | Assinatura de Termo de Entrega das Obras de Melhoria do Sistema de Abastecimento de Água - Governador Valadares/MG | 2020-11-06 → 2021-03-22 (+136d) | 2020-11-06 → 2021-03-22 (+136d) |  |  | 755d → 665d |  |  |
| 973 | **Operação** | 2020-11-06 → 2021-03-22 (+136d) | 2021-11-06 → 2022-03-22 (+136d) | 248d → 250d |  | 507d → 415d |  |  |
| 974 | **ETA Santa Rita** | 2020-11-06 → 2021-03-22 (+136d) | 2021-11-06 → 2022-03-22 (+136d) | 248d → 250d |  | 507d → 415d |  |  |
| 975 | Realizar Treinamento Operacional do Sistema - Governador Valadares/MG | 2020-11-09 → 2021-03-23 (+134d) | 2020-11-13 → 2021-03-29 (+136d) |  |  | 736d → 646d |  |  |
| 976 | Realizar Testes e Pré-operação - Governador Valadares/MG | 2020-11-16 → 2021-03-30 (+134d) | 2020-12-03 → 2021-04-19 (+137d) |  |  | 736d → 646d |  |  |
| 977 | Realizar Acompanhamento da Funcionalidade do Sistema - ETA Santa Rita - Governador Valadares/MG (sede) | 2020-11-06 → 2021-03-22 (+136d) | 2021-11-06 → 2022-03-22 (+136d) |  |  | 2238d → 1830d |  |  |
| 978 | **Operação Assistida** | 2020-11-06 → 2021-03-22 (+136d) | 2021-02-04 → 2021-06-20 (+136d) |  |  | 507d → 417d |  |  |
| 979 | Realizar Operação Assistida - Governador Valadares/MG | 2020-11-06 → 2021-03-22 (+136d) | 2021-02-04 → 2021-06-20 (+136d) |  |  | 2238d → 1830d |  |  |
| 980 | **ETA Vila Isa** |  |  |  | 13% → 17% |  |  |  |
| 981 | **Engenharia** |  |  |  | 44% → 59% | 740d → 242d |  |  |
| 985 | **Engenharia Básica e Detalhada** |  |  |  | 44% → 59% | 740d → 242d |  |  |
| 995 | **Engenharia Captação Alternativa (Derivação da Adutora de GV) - ETA Vila Isa** |  | 2019-12-16 A |  | 60% → 100% | 976d → none |  |  |
| 998 | Emitir RT/PQ para Suprimentos - Captação Alternativa - ETA Vila Isa - Governador Valadares/MG | 2019-12-02 A | 2019-12-16 A |  | 0% → 100% | 976d → none |  |  |

| ID | Task | Start | Finish | Duration | Complete | Total float | Predecessors | Other |
| --- | --- | --- | --- | --- | --- | --- | --- | --- |
| 999 | Elaborar Projeto Executivo - Captação Alternativa - ETA Vila Isa - Governador Valadares/MG |  | 2019-12-16 A |  | 25% → 100% | 976d → none |  |  |
| 1000 | Elaboração do Projeto Executivo - Captação Alternativa - ETA Vila Isa - Governador Valadares/MG | 2019-12-16 A | 2019-12-16 A |  | 0% → 100% | 976d → none |  |  |
| 1001 | **Engenharia UTR - ETA Vila Isa** | 2019-11-07 A |  |  | 0% → 13% | 142d → 242d |  |  |
| 1002 | Aprovar Plano de Trabalho e abrir OSE - UTR - ETA Vila Isa - Governador Valadares/MG | 2019-11-07 A | 2019-11-25 A |  | 0% → 100% | 142d → none |  |  |
| 1003 | Realizar Levantamento de Campo - UTR - ETA Vila Isa - Governador Valadares/MG | 2019-11-26 A | 2019-11-26 A |  | 0% → 100% | 142d → none |  |  |
| 1004 | Elaborar projeto conceitual - UTR - ETA Vila Isa - Governador Valadares/MG | 2019-11-27 A |  |  | 0% → 23% |  |  |  |
| 1022 | **Infraestrutura** |  |  |  | 2% → 4% |  |  |  |
| 1023 | **Obras** |  |  |  | 10% → 16% |  |  |  |
| 1024 | **ETA Vila Isa** |  |  |  | 10% → 16% |  |  |  |
| 1026 | Executar Melhorias ETA - ETA Vila Isa - Governador Valadares/MG | 2019-12-04 → 2019-11-25 A (-9d) | 2020-06-12 → 2020-06-02 (-10d) |  | 0% → 19% | 609d → 616d | 994FS+44d → 994FS+37d |  |
| 1037 | **Captação Principal e Melhorias na ETA Recanto dos Sonhos** |  |  |  | 22% → 24% |  |  |  |
| 1038 | **Engenharia** |  |  |  | 52% → 57% | 673d → 303d |  |  |
| 1042 | **Engenharia Básica e Detalhada** |  |  |  | 52% → 57% | 673d → 303d |  |  |
| 1043 | **Engenharia Melhorias ETA - ETA Recanto dos Sonhos** |  | 2019-11-18 → 2019-11-27 A (+9d) | 278d → 285d | 91% → 100% | 917d → none |  |  |
| 1051 | Elaborar Projeto Executivo (Acréscimo do Macromedidor na SE) - Melhorias na ETA - ETA Recanto dos Sonhos - Governador Valadares/MG |  | 2019-11-18 → 2019-11-27 A (+9d) | 31d → 38d | 25% → 100% | 917d → none |  |  |
| 1052 | Acréscimo no escopo do Projeto Executivo (Macromedidor) - Melhorias na ETA - ETA Recanto dos Sonhos - Governador Valadares/MG | 2019-11-18 → 2019-11-27 A (+9d) | 2019-11-18 → 2019-11-27 A (+9d) |  | 0% → 100% | 917d → none |  |  |
| 1073 | **Infraestrutura** |  |  |  | 7% → 9% |  |  |  |
| 1074 | **Obras** |  |  |  | 32% → 38% |  |  |  |
| 1075 | **ETA Recanto dos Sonhos** |  |  |  | 32% → 38% |  |  |  |
| 1077 | **Melhorias na ETA Recanto do Sonhos** |  |  |  | 59% → 73% |  |  |  |
| 1079 | Executar Obras de Melhorias na ETA (Macromedidor, Móveis e Leito Filtrante) - ETA Recanto dos Sonhos - Governador Valadares/MG | 2019-11-19 → 2019-11-28 A (+9d) |  | 78d → 71d | 0% → 30% |  |  | was named Executar Obras de Melhorias na ETA (Macromedidor) - ETA Recanto dos Sonhos - Governador Valadares/MG |
| 1092 | **Captação Principal e Melhorias na ETA** |  | 2021-01-30 → 2021-11-25 (+299d) | 719d → 923d |  | 698d → 494d |  |  |
| 1107 | **Engenharia Básica e Detalhada** |  | 2019-11-18 A |  | 99% → 100% | 898d → none |  |  |
| 1115 | **Engenharia Melhorias ETA - SE 32262** |  | 2019-11-18 A |  | 99% → 100% | 898d → none |  |  |
| 1122 | Elaborar Projeto Executivo (Acréscimo do Macromedidor na SE) - Melhorias na ETA - São Vítor/MG |  | 2019-11-18 A |  | 97% → 100% | 898d → none |  |  |
| 1123 | Acréscimo no escopo do Projeto Executivo (Macromedidor) - Melhorias na ETA - São Vítor/MG | 2019-11-18 A | 2019-11-18 A |  | 0% → 100% | 898d → none |  |  |
| 1131 | **Infraestrutura** |  | 2021-01-30 → 2021-11-25 (+299d) | 422d → 626d | 15% → 16% | 698d → 494d |  |  |
| 1132 | **Obras** |  | 2020-03-16 → 2020-11-25 (+254d) | 203d → 378d | 71% → 61% | 898d → 723d |  |  |
| 1133 | Executar obras de Melhorias na Captação Principal - São Vítor/MG |  | 2019-11-19 A |  | 90% → 100% | 746d → none |  | was named Executar Melhorias na Captação Principal - São Vítor/MG |
| 1135 | **Melhorias na ETA** |  |  |  | 62% → 74% |  |  |  |
| 1136 | Executar Melhorias na ETA - São Vítor/MG |  | 2020-01-31 → 2019-12-19 A (-43d) | 175d → 147d | 90% → 100% | 697d → none |  |  |
| 1137 | Executar Melhorias na ETA (Acréscimo do Macromedidor) - São Vítor/MG | 2019-11-19 A |  |  | 0% → 25% |  |  |  |
| 1139 | **Operação** | 2020-01-31 → 2020-11-25 (+299d) | 2021-01-30 → 2021-11-25 (+299d) | 247d → 248d |  | 697d → 494d |  |  |
| 1140 | Realizar Treinamento Operacional do Sistema - São Vítor/MG | 2020-03-17 → 2020-11-26 (+254d) | 2020-03-23 → 2020-12-02 (+254d) |  |  | 898d → 723d | 1133, 1136, 1138 → 1133, 1136, 1138, 1134 |  |
| 1141 | Realizar Testes e Pré-operação - São Vítor/MG | 2020-03-24 → 2020-12-03 (+254d) | 2020-04-13 → 2020-12-22 (+253d) |  |  | 898d → 723d |  |  |
| 1142 | Realizar Acompanhamento da Funcionalidade do Sistema - Captação Principal e Melhorias na ETA - São Vítor (distrito Governador Valadares/MG) | 2020-01-31 → 2020-11-25 (+299d) | 2021-01-30 → 2021-11-25 (+299d) |  |  | 3078d → 2181d |  |  |
| 1143 | **Operação Assistida** | 2020-01-31 → 2020-11-25 (+299d) | 2020-04-30 → 2021-02-23 (+299d) | 59d → 58d |  | 697d → 494d |  |  |
| 1144 | Realizar Operação Assistida - São Vítor/MG | 2020-01-31 → 2020-11-25 (+299d) | 2020-04-30 → 2021-02-23 (+299d) |  |  | 3078d → 2181d | 1133, 1136 → 1133, 1136, 1134 |  |
| 1145 | **Captação Alternativa** |  | 2021-03-12 → 2021-03-19 (+7d) | 798d → 803d |  | 671d → 666d |  |  |
| 1159 | **Engenharia Básica e Detalhada** |  | 2019-11-26 → 2019-11-22 A (-4d) | 480d → 478d | 99% → 100% | 671d → none |  |  |
| 1160 | **Engenharia Captação Alternativa (Poço São Vítor) - SE 32012** |  | 2019-11-26 → 2019-11-22 A (-4d) | 480d → 478d | 99% → 100% | 671d → none |  |  |
| 1165 | Elaborar e Aprovar Projeto Executivo para incluir o STA do poço - Captação Alternativa - Poço São Vítor - São Vítor/MG |  | 2019-11-26 → 2019-11-22 A (-4d) | 90d → 88d | 97% → 100% | 671d → none |  |  |
| 1166 | Elaboração do Projeto Executivo - Captação Alternativa - Poço São Vítor - São Vítor/MG | 2019-11-26 → 2019-11-22 A (-4d) | 2019-11-26 → 2019-11-22 A (-4d) |  | 0% → 100% | 671d → none |  |  |
| 1173 | **Infraestrutura** | 2019-11-27 → 2019-12-04 A (+7d) | 2021-03-12 → 2021-03-19 (+7d) |  | 0% → 1% | 671d → 666d |  |  |
| 1174 | **Obras** | 2019-11-27 → 2019-12-04 A (+7d) | 2020-03-12 → 2020-03-19 (+7d) |  | 0% → 25% | 671d → 914d |  |  |
| 1175 | Executar Captação Alternativa (Poço São Vítor) - Interligação do poço a ETA e STA - São Vítor/MG | 2019-11-27 → 2019-12-04 A (+7d) | 2020-03-12 → 2020-03-19 (+7d) |  | 0% → 25% | 671d → 666d | 1155, 1163, 1166, 1168 → 1155, 1163, 1166FS+7d, 1168 |  |
| 1176 | Assinatura de Termo de Entrega das Obras de Melhoria do Sistema de Abastecimento de Água - São Vítor/MG | 2020-03-12 → 2020-03-19 (+7d) | 2020-03-12 → 2020-03-19 (+7d) |  |  | 919d → 914d |  |  |
| 1177 | **Operação** | 2020-03-12 → 2020-03-19 (+7d) | 2021-03-12 → 2021-03-19 (+7d) |  |  | 671d → 666d |  |  |
| 1178 | Realizar Treinamento Operacional do Sistema - São Vítor/MG | 2020-03-13 → 2020-03-20 (+7d) | 2020-03-19 → 2020-03-26 (+7d) |  |  | 900d → 895d |  |  |
| 1179 | Realizar Testes e Pré-operação - São Vítor/MG | 2020-03-20 → 2020-03-27 (+7d) | 2020-04-08 → 2020-04-16 (+8d) |  |  | 900d → 895d |  |  |
| 1180 | Realizar Acompanhamento da Funcionalidade do Sistema - Captação Alternativa - São Vítor (distrito Governador Valadares/MG) | 2020-03-12 → 2020-03-19 (+7d) | 2021-03-12 → 2021-03-19 (+7d) |  |  | 2955d → 2934d |  |  |
| 1181 | **Operação Assistida** | 2020-03-12 → 2020-03-19 (+7d) | 2020-06-10 → 2020-06-17 (+7d) | 61d → 60d |  | 671d → 666d |  |  |
| 1182 | Realizar Operação Assistida - São Vítor/MG | 2020-03-12 → 2020-03-19 (+7d) | 2020-06-10 → 2020-06-17 (+7d) |  |  | 2955d → 2934d |  |  |
| 1183 | **UTR** | 2019-12-03 A |  |  | 0% → 2% |  |  |  |
| 1184 | **Engenharia Básica e Detalhada** | 2019-12-03 A |  |  | 0% → 17% | 322d → 351d |  |  |
| 1185 | **Engenharia UTR** | 2019-12-03 A |  |  | 0% → 17% | 322d → 351d |  |  |
| 1186 | Aprovar Plano de Trabalho e Abrir SE - UTR - São Vítor/MG | 2019-12-03 A |  |  | 0% → 95% |  |  |  |
| 1187 | Realizar Levantamento de Campo - UTR - São Vítor/MG | 2019-12-18 A |  |  | 0% → 80% |  |  |  |
| 1188 | Realizar Sondagem - UTR - São Vítor/MG | 2019-12-18 A |  |  | 0% → 80% |  |  |  |
| 1217 | **Galileia/MG (sede)** |  |  |  | 60% → 67% |  |  |  |
| 1218 | **Captação Principal, Alternativa, Melhorias em ETA e UTR** |  |  |  | 60% → 67% |  |  |  |
| 1271 | **Infraestrutura** |  |  |  | 15% → 29% |  |  |  |
| 1272 | **Obras** |  | 2019-11-29 → 2020-01-30 (+62d) | 435d → 475d | 93% → 99% | 986d → 946d |  |  |
| 1280 | Realizar ajustes no escopo do projeto para atender solicitações do MP - Galiléia/MG |  | 2019-11-29 A |  | 53% → 100% | 738d → none |  |  |
| 1281 | Assinatura de Termo de Entrega das Obras de Melhoria do Sistema de Abastecimento de Água - Galiléia/MG | 2019-11-29 → 2020-01-30 (+62d) | 2019-11-29 → 2020-01-30 (+62d) |  |  | 986d → 946d | 1275, 1278, 1274, 1264, 1280 → 1275, 1278, 1274, 1264, 1280FS+40d |  |
| 1282 | **Operação** | 2019-11-29 A |  |  | 0% → 15% | 738d → 740d |  |  |
| 1283 | Realizar Treinamento Operacional do Sistema - Galiléia/MG | 2019-12-02 A | 2019-12-06 A |  | 0% → 100% | 967d → none |  |  |
| 1284 | Realizar Testes e Pré-operação - Galiléia/MG | 2019-12-09 A | 2019-12-31 A |  | 0% → 100% | 967d → none |  |  |
| 1285 | Realizar Acompanhamento da Funcionalidade do Sistema - Captação Principal, Alternativa, Melhorias em ETA e UTR - Galileia/MG (sede) | 2019-11-29 A |  |  | 0% → 9% |  |  |  |
| 1286 | **Operação Assistida** | 2019-11-29 A |  |  | 0% → 36% | 738d → 929d |  |  |

| ID | Task | Start | Finish | Duration | Complete | Total float | Predecessors |
| --- | --- | --- | --- | --- | --- | --- | --- |
| 1287 | Realizar Operação Assistida - Galiléia/MG | 2019-11-29 A |  |  | 0% → 36% | 3267d → 4092d |  |
| 1320 | **Captação Alternativa** |  |  |  | 5% → 6% |  |  |
| 1332 | **Engenharia Básica e Detalhada** |  |  |  | 12% → 16% |  |  |
| 1333 | **Engenharia Captação Alternativa (Poço 4) - SE 32154** |  |  |  | 12% → 16% |  |  |
| 1336 | Realizar Sondagem - Captação Alternativa - Poço 4 - Tumiritinga/MG |  | 2019-11-11 A |  | 25% → 100% | 347d → none |  |
| 1387 | **São Tomé do Rio Doce (distrito Tumiritinga/MG)** |  |  |  | 39% → 41% |  |  |
| 1388 | **Captação Principal / Nova ETA / UTR** |  |  |  | 22% → 25% |  |  |
| 1392 | **Engenharia Básica e Detalhada** |  |  |  | 38% → 66% |  |  |
| 1393 | **Engenharia Captação Principal / Nova ETA / UTR - SE 32156** |  |  |  | 38% → 66% |  |  |
| 1396 | Realizar Sondagem - Captação Principal / Nova ETA / UTR - São Tomé do Rio Doce/MG | 2019-11-26 A | 2019-12-27 A |  | 0% → 100% | 345d → none |  |
| 1399 | Elaborar Projeto Básico - Captação Principal / Nova ETA / UTR - São Tomé do Rio Doce/MG |  | 2020-01-13 A |  | 11% → 100% | 335d → none |  |
| 1408 | **Licenciamento** |  |  |  | 46% → 48% |  |  |
| 1410 | Obter DAIA Nova ETA - São Tomé do Rio Doce/MG |  | 2019-11-28 → 2020-01-10 (+43d) | 240d → 267d |  | 539d → 512d |  |
| 1461 | **Território Baixo Rio Doce (MG/ES)** |  | 2023-07-14 → 2023-07-01 (-13d) | 1630d → 1620d | 16% → 17% | 88d → 98d |  |
| 1462 | **Resplendor/MG (sede)** |  |  |  | 24% → 26% |  |  |
| 1463 | **Captação Alternativa** |  | 2020-12-19 → 2021-02-20 (+63d) | 993d → 1032d | 49% → 50% | 725d → 686d |  |
| 1493 | **Infraestrutura** |  | 2020-12-19 → 2021-02-20 (+63d) | 687d → 726d | 23% → 25% | 725d → 686d |  |
| 1494 | **Obras** |  | 2019-12-20 → 2020-02-21 (+63d) | 440d → 482d |  | 972d → 930d |  |
| 1495 | **Captação Alternativa** |  | 2019-12-20 → 2020-02-21 (+63d) | 440d → 482d |  | 972d → 930d |  |
| 1496 | Executar Captação Alternativa (Poço C1 e C2) - Resplendor/MG |  | 2019-12-20 → 2020-02-21 (+63d) | 440d → 482d |  | 724d → 682d |  |
| 1497 | Conclusão das Obras de Captação Alternativa (Poço C1 e C2) - Resplendor/MG | 2019-12-20 → 2020-02-21 (+63d) | 2019-12-20 → 2020-02-21 (+63d) |  |  | 972d → 930d |  |
| 1498 | Assinatura de Termo de Entrega das Obras de Melhoria do Sistema de Abastecimento de Água - Resplendor/MG | 2019-12-20 → 2020-02-21 (+63d) | 2019-12-20 → 2020-02-21 (+63d) |  |  | 972d → 930d |  |
| 1499 | **Operação** | 2019-12-20 → 2020-02-21 (+63d) | 2020-12-19 → 2021-02-20 (+63d) | 247d → 244d |  | 724d → 682d |  |
| 1500 | Realizar Treinamento Operacional do Sistema - Resplendor/MG | 2019-12-23 → 2020-02-27 (+66d) | 2019-12-31 → 2020-03-04 (+64d) |  |  | 953d → 911d |  |
| 1501 | Realizar Testes e Pré-operação - Resplendor/MG | 2020-01-02 → 2020-03-05 (+63d) | 2020-01-21 → 2020-03-24 (+63d) |  |  | 953d → 911d |  |
| 1502 | Realizar Acompanhamento da Funcionalidade do Sistema - Captação Alternativa - Resplendor/MG (sede) | 2019-12-20 → 2020-02-21 (+63d) | 2020-12-19 → 2021-02-20 (+63d) |  |  | 3204d → 3015d |  |
| 1503 | **Operação Assistida** | 2019-12-20 → 2020-02-21 (+63d) | 2020-03-19 → 2020-05-21 (+63d) |  |  | 724d → 682d |  |
| 1504 | Realizar Operação Assistida - Resplendor/MG | 2019-12-20 → 2020-02-21 (+63d) | 2020-03-19 → 2020-05-21 (+63d) |  |  | 3204d → 3015d |  |
| 1505 | **Melhorias de ETA e na Captação Principal** |  | 2021-06-05 → 2021-06-30 (+25d) | 810d → 828d | 15% → 20% | 614d → 596d |  |
| 1506 | **Engenharia** |  | 2019-11-22 → 2019-11-29 A (+7d) | 433d → 438d | 87% → 100% | 623d → none |  |
| 1510 | **Engenharia Básica e Detalhada** |  | 2019-11-22 → 2019-11-29 A (+7d) | 386d → 391d | 87% → 100% | 623d → none |  |
| 1511 | **Engenharia Melhorias ETA - SE 32247** |  | 2019-11-22 → 2019-11-29 A (+7d) | 386d → 391d | 87% → 100% | 623d → none |  |
| 1515 | Emitir RT/PQ para Suprimentos - Melhorias na ETA - Resplendor/MG | 2019-11-08 → 2019-11-18 A (+10d) | 2019-11-22 → 2019-11-29 A (+7d) |  | 0% → 100% | 613d → none |  |
| 1516 | Elaborar Projeto Executivo - Melhorias na ETA - Resplendor/MG |  | 2019-11-22 → 2019-11-29 A (+7d) | 202d → 207d | 88% → 100% | 613d → none |  |
| 1517 | Elaboração do Projeto Executivo - Melhorias na ETA - Resplendor/MG | 2019-11-22 → 2019-11-29 A (+7d) | 2019-11-22 → 2019-11-29 A (+7d) |  | 0% → 100% | 623d → none |  |
| 1518 | **Suprimentos** | 2019-11-25 → 2019-12-02 A (+7d) | 2020-04-13 → 2020-04-08 (-5d) | 93d → 86d | 0% → 8% | 898d → 900d |  |
| 1519 | Verificar se obra está incluída no CGC existente - Processo contratação Captações e ETA - Resplendor/MG | 2019-11-25 → 2019-12-02 A (+7d) | 2019-11-29 → 2020-01-10 (+42d) | 5d → 26d | 0% → 25% | 898d → 597d |  |
| 1520 | Processo de contratação - Melhorias na ETA - Resplendor/MG | 2019-12-02 → 2020-01-13 (+42d) | 2020-04-13 → 2020-04-08 (-5d) | 88d → 60d |  | 898d → 564d |  |
| 1521 | Conclusão da Contratação de Suprimentos das obras de Melhoria do Sistema de Abastecimento de Água - Resplendor/MG | 2020-04-13 → 2020-04-08 (-5d) | 2020-04-13 → 2020-04-08 (-5d) |  |  | 898d → 900d |  |
| 1522 | **Infraestrutura** |  | 2021-06-05 → 2021-06-30 (+25d) | 614d → 632d | 5% → 7% | 614d → 596d |  |
| 1523 | **Obras** |  | 2020-06-05 → 2020-06-30 (+25d) | 367d → 383d | 30% → 66% | 861d → 845d |  |
| 1524 | Executar Captação Principal - Balsa de Captação do Rio Doce - Resplendor/MG |  | 2020-01-24 → 2020-01-17 (-7d) | 60d → 55d | 25% → 95% | 950d → 955d |  |
| 1525 | **Melhorias na ETA** |  | 2020-06-05 → 2020-06-30 (+25d) | 367d → 383d | 31% → 52% | 613d → 597d |  |
| 1527 | Executar Melhorias de ETA - Resplendor/MG | 2019-11-25 → 2020-04-09 (+136d) | 2020-06-05 → 2020-06-30 (+25d) | 130d → 55d |  | 613d → 597d | 1515, 1517FS-10d → 1515, 1517, 1519, 1520 |
| 1528 | Conclusão das Obras de Melhorias em ETA - Resplendor/MG | 2020-06-05 → 2020-06-30 (+25d) | 2020-06-05 → 2020-06-30 (+25d) |  |  | 613d → 597d |  |
| 1529 | Assinatura de Termo de Entrega das Obras de Melhoria do Sistema de Abastecimento de Água - Resplendor/MG | 2020-06-05 → 2020-06-30 (+25d) | 2020-06-05 → 2020-06-30 (+25d) |  |  | 861d → 845d |  |
| 1530 | **Operação** | 2020-06-05 → 2020-06-30 (+25d) | 2021-06-05 → 2021-06-30 (+25d) | 247d → 249d |  | 613d → 596d |  |
| 1531 | Realizar Treinamento Operacional do Sistema - Resplendor/MG | 2020-06-08 → 2020-07-01 (+23d) | 2020-06-15 → 2020-07-07 (+22d) |  |  | 842d → 826d |  |
| 1532 | Realizar Testes e Pré-operação - Resplendor/MG | 2020-06-16 → 2020-07-08 (+22d) | 2020-07-03 → 2020-07-27 (+24d) |  |  | 842d → 826d |  |
| 1533 | Realizar Acompanhamento da Funcionalidade do Sistema - Melhorias de ETA e na Captação Principal - Resplendor/MG (sede) | 2020-06-05 → 2020-06-30 (+25d) | 2021-06-05 → 2021-06-30 (+25d) |  |  | 2700d → 2625d |  |
| 1534 | **Operação Assistida** | 2020-06-05 → 2020-06-30 (+25d) | 2020-09-03 → 2020-09-28 (+25d) |  |  | 612d → 596d |  |
| 1535 | Realizar Operação Assistida - Resplendor/MG | 2020-06-05 → 2020-06-30 (+25d) | 2020-09-03 → 2020-09-28 (+25d) |  |  | 2700d → 2625d |  |
| 1544 | **Engenharia Básica e Detalhada** | 2019-11-14 → 2020-01-02 (+49d) |  | 259d → 229d |  | 249d → 258d |  |
| 1545 | **Engenharia UTR** | 2019-11-14 → 2020-01-02 (+49d) |  | 259d → 229d |  | 249d → 258d |  |
| 1546 | Aprovar Plano de Trabalho e abrir OSE - UTR - Resplendor/MG | 2019-11-14 → 2020-01-02 (+49d) | 2019-12-10 → 2020-01-10 (+31d) | 18d → 7d |  | 249d → 294d | 1538FS+420d, 1542 → 1538FS+450d, 1542 |
| 1547 | Realizar Levantamento de Campo - UTR - Resplendor/MG |  |  |  |  | 249d → 294d | 1546FS+22d → 1546FS+3d |
| 1548 | Realizar Sondagem - UTR - Resplendor/MG |  |  |  |  | 249d → 294d | 1546FS+22d → 1547SS |
| 1549 | Elaborar Projeto Conceitual - UTR - Resplendor/MG | 2020-01-06 → 2020-01-15 (+9d) |  | 67d → 60d |  |  | 1547FS-22d, 1548FS-22d → 1547SS-1d, 1548SS-1d |
| 1550 | Elaborar Projeto Básico - UTR - Resplendor/MG |  | 2020-07-23 → 2020-07-09 (-14d) | 70d → 60d |  |  |  |
| 1551 | Aprovar Projeto Básico - UTR - Resplendor/MG | 2020-07-24 → 2020-07-10 (-14d) |  | 22d → 32d |  | 738d → 249d |  |
| 1552 | Emitir RT/PQ para Suprimentos - UTR - Resplendor/MG | 2020-07-24 → 2020-09-21 (+59d) |  | 43d → 3d |  |  | 1550 → 1553FF-47d |
| 1571 | **Itueta/MG (sede)** |  | 2023-05-11 → 2023-04-25 (-16d) | 1284d → 1273d | 3% → 4% | 133d → 144d |  |
| 1572 | **Captação Alternativa (Rio Manhuaçu) / Nova ETA e UTR** |  | 2023-05-11 → 2023-04-25 (-16d) | 1284d → 1273d | 3% → 4% | 133d → 144d |  |
| 1582 | **Engenharia Básica e Detalhada** |  |  |  | 15% → 24% |  |  |
| 1583 | **Engenharia Captação Alternativa (Rio Manhuaçu) / Nova ETA e UTR** |  |  |  | 16% → 26% |  |  |
| 1584 | Aprovar Plano de Trabalho e abrir OSE - Captação Alternativa, ETA e UTR, Nova ETA e UTR - Itueta/MG |  | 2019-11-26 → 2019-12-11 A (+15d) | 25d → 36d | 25% → 100% | 133d → none |  |
| 1585 | Realizar Sondagem - Captação Alternativa, ETA e UTR -Itueta/MG |  |  |  |  | 201d → 213d | 1584FS+45d → 1584FS+34d |
| 1587 | Elaborar arranjo para obtenção de Dados de Entrada Licenciamento e Fundiário - Captação Alternativa, ETA e UTR -Itueta/MG | 2019-11-27 → 2020-01-10 (+44d) |  | 58d → 30d |  | 133d → 145d | 1584 → 1584FS+17d |
| 1588 | Elaborar Projeto Básico - Captação Alternativa, ETA e UTR - Itueta/MG |  |  |  |  | 133d → 145d | 1585FF, 1586FF, 1587SS+58d → 1585FF, 1586FF, 1587 |
| 1589 | Aprovar Projeto Básico - Captação Alternativa, ETA e UTR - Itueta/MG |  | 2020-07-29 → 2020-07-22 (-7d) | 22d → 17d |  | 133d → 145d |  |

| ID | Task | Start | Finish | Duration | Complete | Total float | Predecessors |
| --- | --- | --- | --- | --- | --- | --- | --- |
| 1590 | Emitir RT/PQ para Suprimentos - Captação Alternativa, ETA e UTR - Itueta/MG | 2020-10-02 → 2020-09-16 (-16d) | 2020-10-16 → 2020-09-24 (-22d) | 10d → 7d |  | 133d → 145d | 1591FF-10d → 1591FF-25d |
| 1591 | Elaborar Projeto Executivo - Captação Alternativa, ETA e UTR - Itueta/MG | 2020-07-30 → 2020-07-23 (-7d) |  | 65d → 70d |  | 133d → 145d |  |
| 1610 | **Suprimentos** | 2020-10-19 → 2020-09-25 (-24d) | 2021-03-12 → 2021-02-24 (-16d) | 98d → 101d |  | 133d → 145d |  |
| 1611 | Realizar análise da RT/PQ pela Infra - Adutora, Nova ETA e UTR - Itueta/MG | 2020-10-19 → 2020-09-25 (-24d) | 2020-10-30 → 2020-10-08 (-22d) |  |  | 133d → 145d |  |
| 1612 | Realizar Processo contratação - Adutora, Nova ETA e UTR - Itueta/MG | 2020-11-03 → 2020-10-09 (-25d) | 2021-03-12 → 2021-02-24 (-16d) | 88d → 91d |  | 133d → 145d |  |
| 1613 | Conclusão da Contratação de Suprimentos - Adutora, Nova ETA e UTR - Itueta/MG | 2021-03-12 → 2021-02-24 (-16d) | 2021-03-12 → 2021-02-24 (-16d) |  |  | 133d → 145d |  |
| 1614 | **Infraestrutura** | 2021-03-15 → 2021-02-25 (-18d) | 2023-05-11 → 2023-04-25 (-16d) | 538d → 539d |  | 133d → 144d |  |
| 1615 | **Obras** | 2021-03-15 → 2021-02-25 (-18d) | 2023-05-11 → 2023-04-25 (-16d) | 538d → 539d |  | 133d → 144d |  |
| 1616 | Executar Captação Principal (Pequenas Melhorias Captação rio Doce) - Itueta/MG | 2021-03-15 → 2021-02-25 (-18d) | 2021-06-17 → 2021-05-31 (-17d) |  |  | 357d → 369d | 1602FS-3d, 1613 → 1602, 1613 |
| 1617 | Executar Captação Alternativa (Rio Manhuaçu) - Itueta/MG | 2021-03-15 → 2021-02-25 (-18d) | 2022-05-11 → 2022-04-25 (-16d) |  |  | 133d → 145d |  |
| 1618 | Executar Nova ETA - Itueta/MG | 2021-03-15 → 2021-02-25 (-18d) | 2021-09-27 → 2021-09-09 (-18d) |  |  | 286d → 298d |  |
| 1619 | Executar UTR - Itueta/MG |  |  |  |  |  | 1603, 1608, 1613 → 1603, 1608, 1613FS+12d |
| 1620 | Assinatura de Termo de Entrega das Obras de Melhoria do Sistema de Abastecimento de Água - Itueta/MG | 2022-05-11 → 2022-04-25 (-16d) | 2022-05-11 → 2022-04-25 (-16d) |  |  | 381d → 393d |  |
| 1621 | Realizar Acompanhamento da Funcionalidade do Sistema - Captação Alternativa (Rio Manhuaçu) / Nova ETA e UTR - Itueta/MG (sede) | 2022-05-11 → 2022-04-25 (-16d) | 2023-05-11 → 2023-04-25 (-16d) |  |  | 585d → 633d |  |
| 1622 | **Operação** | 2022-05-11 → 2022-04-25 (-16d) | 2022-08-09 → 2022-07-24 (-16d) |  |  | 133d → 145d |  |
| 1623 | Realizar Treinamento Operacional do Sistema - Itueta/MG | 2022-05-12 → 2022-04-26 (-16d) | 2022-05-18 → 2022-05-02 (-16d) |  |  | 362d → 374d |  |
| 1624 | Realizar Testes e Pré-operação - Itueta/MG | 2022-05-19 → 2022-05-03 (-16d) | 2022-06-07 → 2022-05-20 (-18d) |  |  | 362d → 374d |  |
| 1625 | **Operação Assistida** | 2022-05-11 → 2022-04-25 (-16d) | 2022-08-09 → 2022-07-24 (-16d) |  |  | 132d → 144d |  |
| 1626 | Realizar Operação Assistida - Itueta/MG | 2022-05-11 → 2022-04-25 (-16d) | 2022-08-09 → 2022-07-24 (-16d) |  |  | 585d → 633d |  |
| 1627 | **Santo Antônio do Rio Doce (distrito Aimorés/MG)** |  | 2023-07-14 → 2023-07-01 (-13d) | 1329d → 1319d | 6% → 7% | 88d → 98d |  |
| 1628 | **Captação Principal, UTR na ETA de Aimorés** |  | 2023-07-14 → 2023-07-01 (-13d) | 1329d → 1319d | 6% → 7% | 88d → 98d |  |
| 1634 | **Engenharia Básica e Detalhada** |  |  |  | 21% → 30% |  |  |
| 1635 | **Engenharia Projeto Município Aimorés (Captação principal)** |  |  |  | 39% → 48% |  |  |
| 1637 | Aprovar Plano de Trabalho e abrir OSE - Captação Principal - Santo Antônio do Rio Doce/MG |  | 2019-11-25 → 2019-12-02 A (+7d) | 19d → 24d | 25% → 100% | 195d → none |  |
| 1638 | Realizar Levantamento de Campo/Sondagem - Captação Principal - Santo Antônio do Rio Doce/MG | 2019-11-26 → 2019-12-03 A (+7d) | 2020-01-10 → 2020-01-17 (+7d) |  | 0% → 25% | 195d → 97d |  |
| 1639 | Elaborar Projeto Básico - Captação Principal - Santo Antônio do Rio Doce/MG | 2020-01-13 → 2020-01-27 (+14d) | 2020-05-11 → 2020-04-24 (-17d) | 80d → 60d |  | 195d → 97d | 1638 → 1638FS+5d |
| 1640 | Aprovar Projeto Básico - Captação Principal - Santo Antônio do Rio Doce/MG | 2020-05-12 → 2020-04-27 (-15d) |  | 22d → 32d |  |  |  |
| 1641 | Emitir RT/PQ para Suprimentos - Captação Principal - Santo Antônio do Rio Doce/MG | 2020-07-07 → 2020-07-14 (+7d) |  | 10d → 5d |  |  |  |
| 1644 | **Engenharia UTR na ETA de Aimorés/MG** | 2019-11-29 → 2019-12-02 A (+3d) |  | 249d → 248d | 0% → 3% | 88d → 738d |  |
| 1645 | Aprovar Plano de Trabalho e abrir OSE - UTR - Santo Antônio do Rio Doce/MG | 2019-11-29 → 2019-12-02 A (+3d) | 2019-12-10 A | 8d → 7d | 0% → 100% | 88d → none | 1636FS+22d → 1636FS+23d |
| 1646 | Elaborar arranjo para obtenção de Dados de Entrada Licenciamento e Fundiário - UTR - Santo Antônio do Rio Doce/MG | 2020-01-16 → 2020-02-19 (+34d) | 2020-04-28 → 2020-04-13 (-15d) | 69d → 35d |  | 88d → 227d | 1645FS+22d → 1645FS+46d |
| 1647 | Elaborar Projeto Básico - UTR - Santo Antônio do Rio Doce/MG |  |  |  |  | 88d → 227d | 1646FS-10d → 1646 |
| 1649 | Emitir RT/PQ para Suprimentos - UTR - Santo Antônio do Rio Doce/MG | 2020-04-29 → 2020-10-22 (+176d) | 2020-05-20 → 2020-10-26 (+159d) | 15d → 3d |  | 337d → 227d | 1646 → 1650FF-25d |
| 1656 | **Fundiária** | 2019-11-20 → 2020-04-27 (+159d) | 2021-05-04 → 2021-04-20 (-14d) | 358d → 245d |  | 201d → 97d |  |
| 1657 | Obter Termo de Autorização de Superficiário - Captação Principal - Santo Antônio do Rio Doce/MG | 2019-11-20 → 2020-04-27 (+159d) | 2019-11-26 → 2020-05-04 (+160d) |  |  | 201d → 97d | 1632FS+25d, 1636FS+15d → 1639 |
| 1658 | Captação Principal - Desimpedimento de área - Santo Antônio do Rio Doce/MG | 2020-05-18 → 2020-05-05 (-13d) | 2021-05-04 → 2021-04-20 (-14d) |  |  | 88d → 97d | 1657, 1647SS+22d → 1657 |
| 1659 | Conclusão da Regularização Fundiária para as obras de Melhoria do Sistema de Abastecimento da Localidade - Santo Antônio do Rio Doce/MG | 2021-05-04 → 2021-04-20 (-14d) | 2021-05-04 → 2021-04-20 (-14d) |  |  | 636d → 645d |  |
| 1660 | **Licenciamento** | 2020-04-29 → 2020-04-14 (-15d) | 2021-01-27 → 2021-01-07 (-20d) | 188d → 184d |  | 164d → 174d |  |
| 1661 | Obter Outorga/DAIA para Captação Principal - Santo Antônio do Rio Doce/MG | 2020-05-18 → 2020-04-27 (-21d) | 2021-01-27 → 2021-01-07 (-20d) |  |  | 152d → 166d | 1636FS+22d, 1657, 1647SS+22d → 1639 |
| 1662 | Licença/Autorização ETA / UTR - Santo Antônio do Rio Doce/MG | 2020-04-29 → 2020-04-14 (-15d) | 2021-01-11 → 2020-12-23 (-19d) |  |  | 264d → 274d |  |
| 1663 | Conclusão do Licenciamento Ambiental da Localidade - Santo Antônio do Rio Doce/MG | 2021-01-27 → 2021-01-07 (-20d) | 2021-01-27 → 2021-01-07 (-20d) |  |  | 700d → 714d |  |
| 1664 | **Suprimentos** | 2020-05-21 → 2020-07-21 (+61d) | 2020-11-24 → 2021-03-08 (+104d) | 130d → 156d |  | 237d → 195d |  |
| 1666 | Processo contratação MAS 2 (UTR) - Santo Antônio do Rio Doce/MG | 2020-05-21 → 2020-10-27 (+159d) | 2020-09-23 → 2021-03-08 (+166d) |  |  | 337d → 227d |  |
| 1667 | Conclusão da Contratação de Suprimentos das obras de Melhoria do Sistema de Abastecimento de Água - Santo Antônio do Rio Doce/MG | 2020-11-24 → 2021-03-08 (+104d) | 2020-11-24 → 2021-03-08 (+104d) |  |  | 743d → 675d |  |
| 1668 | **Infraestrutura** | 2021-01-12 → 2021-03-09 (+56d) | 2023-07-14 → 2023-07-01 (-13d) | 624d → 577d |  | 88d → 98d |  |
| 1669 | **Obras** | 2021-01-12 → 2021-03-09 (+56d) | 2023-07-14 → 2023-07-01 (-13d) | 624d → 577d |  | 88d → 98d |  |
| 1670 | Executar Captação Principal (Adutora de Aimorés e expansão do Reservatório) - Santo Antônio do Rio Doce/MG | 2021-05-05 → 2021-04-22 (-13d) | 2022-07-14 → 2022-07-01 (-13d) |  |  | 88d → 97d |  |
| 1671 | Executar UTR na ETA de Aimorés/MG - Santo Antônio do Rio Doce/MG | 2021-01-12 → 2021-03-09 (+56d) | 2021-10-28 → 2021-12-22 (+55d) |  |  | 264d → 227d |  |
| 1672 | Assinatura de Termo de Entrega das Obras de Melhoria do Sistema de Abastecimento de Água - Santo Antônio do Rio Doce | 2022-07-14 → 2022-07-01 (-13d) | 2022-07-14 → 2022-07-01 (-13d) |  |  | 336d → 345d |  |
| 1673 | Realizar Acompanhamento da Funcionalidade do Sistema - Captação Principal, UTR na ETA de Aimorés - Santo Antônio do Rio Doce (distrito Aimorés/MG) | 2022-07-14 → 2022-07-01 (-13d) | 2023-07-14 → 2023-07-01 (-13d) |  |  | 393d → 432d |  |
| 1674 | **Operação** | 2022-07-14 → 2022-07-01 (-13d) | 2022-10-12 → 2022-09-29 (-13d) | 61d → 62d |  | 88d → 97d |  |
| 1675 | Realizar Treinamento Operacional do Sistema - Santo Antônio do Rio Doce/MG | 2022-07-15 → 2022-07-04 (-11d) | 2022-07-21 → 2022-07-08 (-13d) |  |  | 317d → 326d |  |
| 1676 | Realizar Testes e Pré-operação - Santo Antônio do Rio Doce/MG | 2022-07-22 → 2022-07-11 (-11d) | 2022-08-10 → 2022-07-28 (-13d) |  |  | 317d → 326d |  |
| 1677 | **Operação Assistida** | 2022-07-14 → 2022-07-01 (-13d) | 2022-10-12 → 2022-09-29 (-13d) | 61d → 62d |  | 88d → 97d |  |
| 1678 | Realizar Operação Assistida - Santo Antônio do Rio Doce/MG | 2022-07-14 → 2022-07-01 (-13d) | 2022-10-12 → 2022-09-29 (-13d) |  |  | 393d → 432d |  |
| 1679 | **Baixo Guandu/ES (sede)** |  |  |  | 21% → 22% |  |  |
| 1680 | **Captação Alternativa** |  |  |  | 34% → 37% |  |  |
| 1687 | **Engenharia Básica e Detalhada** |  |  |  | 86% → 88% |  |  |
| 1688 | **Engenharia Captação Alternativa (Rio Guandu)** |  |  |  | 86% → 88% |  |  |
| 1697 | Elaborar Projeto Executivo - Repotenciamento da Elevatória (SE 32252) - Captação Alternativa - Rio Guandu - Baixo Guandu/ES |  |  |  | 14% → 25% |  |  |
| 1700 | **Fundiária** |  |  |  | 10% → 48% |  |  |
| 1701 | **Captação Alternativa - Adutora Rio Guandu - Desimpedimento da Área e Negociação de Servidão** |  |  |  | 10% → 48% |  |  |
| 1702 | Realizar Levantamento da documentação da propriedade - Cadastro dos proprietários - Baixo Guandu/ES |  | 2019-11-29 → 2019-12-20 A (+21d) | 75d → 89d | 25% → 100% | 502d → none |  |
| 1703 | Obter laudo de Avaliação - Baixo Guandu/ES | 2019-12-02 → 2020-01-02 (+31d) | 2020-01-06 → 2020-01-23 (+17d) | 22d → 16d |  |  | 1702 → 1702FS+5d |
| 1704 | Obter assinatura do Contrato de servidão pelo proprietário - Baixo Guandu/ES | 2020-01-07 → 2020-01-24 (+17d) |  | 44d → 31d |  |  |  |
| 1709 | **Licenciamento** | 2019-08-01 A → 2019-12-18 A (+139d) | 2020-04-23 → 2020-05-21 (+28d) | 180d → 103d | 26% → 25% | 891d → 872d |  |
| 1710 | Captação Alternativa - Outorga para captação e Autorizações - Baixo Guandu/ES | 2019-08-01 A → 2019-12-18 A (+139d) | 2020-04-23 → 2020-05-21 (+28d) | 180d → 103d | 26% → 25% | 523d → 504d | none → 1695FS+95d |
| 1711 | Conclusão do Licenciamento Ambiental da Localidade - Baixo Gandu/ES | 2020-04-23 → 2020-05-21 (+28d) | 2020-04-23 → 2020-05-21 (+28d) |  |  | 891d → 872d |  |
| 1712 | **Suprimentos** |  | 2020-02-06 → 2020-02-10 (+4d) | 88d → 90d | 26% → 25% | 941d → 939d |  |
| 1713 | Realizar processo de contratação - Adequação Adutora Rio Guandu e Repotenciamento da Elevatória - Baixo Guandu/ES |  | 2020-02-06 → 2020-02-10 (+4d) | 88d → 90d | 26% → 25% | 573d → 571d |  |

| ID | Task | Start | Finish | Duration | Complete | Total float | Predecessors | Other |
| --- | --- | --- | --- | --- | --- | --- | --- | --- |
| 1714 | Conclusão da Contratação de Suprimentos das obras de Melhoria do Sistema de Abastecimento de Água - Baixo Gandu/ES | 2020-02-06 → 2020-02-10 (+4d) | 2020-02-06 → 2020-02-10 (+4d) |  |  | 941d → 939d |  |  |
| 1725 | **Melhorias na ETA** |  |  |  | 10% → 9% |  |  |  |
| 1738 | **Suprimentos** | 2019-10-01 A → 2020-01-07 (+98d) | 2020-02-06 → 2020-05-15 (+99d) |  | 26% → 0% | 941d → 548d |  |  |
| 1739 | Realizar processo de contratação - Melhorias de ETA - Baixo Guandu/ES | 2019-10-01 A → 2020-01-07 (+98d) | 2020-02-06 → 2020-05-15 (+99d) |  | 26% → 0% |  | none → 1737FS+130d | was named Realizar processo de contratação - Adequação Adutora Rio Guandu e Repotenciamento da Elevatória - Baixo Guandu/ES |
| 1740 | Conclusão da Contratação de Suprimentos das obras de Melhoria do Sistema de Abastecimento de Água - Baixo Gandu/ES | 2020-02-06 → 2020-05-15 (+99d) | 2020-02-06 → 2020-05-15 (+99d) |  |  | 941d → 876d |  |  |
| 1741 | **Infraestrutura** | 2020-02-07 → 2020-05-18 (+101d) |  | 394d → 329d |  |  |  |  |
| 1742 | **Obras** | 2020-02-07 → 2020-05-18 (+101d) |  | 145d → 80d |  |  |  |  |
| 1743 | Executar Melhorias de ETA e Melhorias na Captação Principal - Baixo Guandu/ES | 2020-02-07 → 2020-05-18 (+101d) |  | 145d → 80d |  |  |  |  |
| 1751 | **Nova ETA e UTR** |  |  |  | 11% → 12% |  |  |  |
| 1763 | Elaborar Projeto Básico - Nova ETA/UTR - Baixo Guandu/ES |  | 2019-11-13 → 2020-01-17 (+65d) | 45d → 87d | 45% → 25% | 997d → 425d |  |  |
| 1764 | Emitir RT/PQ para Suprimentos - Nova ETA/UTR - Baixo Guandu/ES |  |  |  |  | 425d → 299d | 1767FF → 1763FF+34d |  |
| 1765 | Elaborar Projeto Executivo - Nova ETA/UTR - Baixo Guandu/ES |  | 2020-02-04 → 2020-01-21 (-14d) | 228d → 218d | 20% → 25% | 425d → 523d |  |  |
| 1766 | Obter aprovação da Operadora/Prefeitura | 2020-02-05 → 2020-01-22 (-14d) | 2020-03-10 → 2020-02-20 (-19d) |  |  | 425d → 397d |  |  |
| 1767 | Elaboração do Projeto Executivo - Nova ETA/UTR - Baixo Guandu/ES | 2020-03-10 → 2020-02-20 (-19d) | 2020-03-10 → 2020-02-20 (-19d) |  |  | 425d → 397d |  |  |
| 1768 | **Licenciamento** |  |  |  | 21% → 25% |  |  |  |
| 1769 | Nova ETA - Licenças e Autorizações - Baixo Guandu/ES |  |  |  | 21% → 25% |  |  |  |
| 1784 | **Mascarenhas (distrito Baixo Guandu/ES)** |  |  |  | 27% → 32% |  |  |  |
| 1785 | **Adutora de Água Tratada de Baixo Guandu** |  |  |  | 27% → 32% |  |  |  |
| 1794 | **Engenharia Básica e Detalhada** |  | 2020-02-21 → 2020-02-05 (-16d) | 488d → 476d | 84% → 95% | 930d → 942d |  |  |
| 1795 | **Engenharia Adutora Água Tratada (ETA Baixo Guandu até reservatório em Mascarenhas) - SE 32085** |  | 2020-01-24 → 2020-01-08 (-16d) | 468d → 456d | 86% → 97% | 1.87d → 33.75d |  |  |
| 1798 | Realizar sondagem - Adutora de Água Tratada - Mascarenhas/ES | 2019-11-13 → 2020-01-06 (+54d) | 2019-11-18 → 2020-01-08 (+51d) |  |  | 24.87d → 33.75d | 1796FS+253d → 1796FS+286d |  |
| 1801 | Elaborar Projeto Executivo - Adutora de Água Tratada - Mascarenhas/ES |  | 2019-12-20 → 2020-01-08 (+19d) | 264d → 266d | 70% → 94% | 1.87d → 33.75d | 1796, 1797FS-50d, 1798FF → 1796, 1798FF |  |
| 1802 | Elaboração do Projeto Executivo - Adutora de Água Tratada - Mascarenhas/ES | 2020-01-24 → 2020-01-08 (-16d) | 2020-01-24 → 2020-01-08 (-16d) |  |  | 1.87d → 33.75d | Obter Aprovação da Operadora e Prefeitura → 1797, 1801 |  |
| 1803 | **Validação dos Projetos** | 2020-01-27 → 2020-01-09 (-18d) | 2020-02-21 → 2020-02-05 (-16d) |  |  | 930d → 942d |  |  |
| 1804 | Validar Projetos com Prefeitura e Operadora - Mascarenhas/ES | 2020-01-27 → 2020-01-09 (-18d) | 2020-02-21 → 2020-02-05 (-16d) |  |  | 930d → 942d |  |  |
| 1805 | Validação com Prefeitura e Operadora dos Projetos de Melhoria do Sistema de Abastecimento de Água - Mascarenhas/ES | 2020-02-21 → 2020-02-05 (-16d) | 2020-02-21 → 2020-02-05 (-16d) |  |  | 930d → 942d |  |  |
| 1806 | **Fundiária** |  | 2020-06-22 → 2020-06-26 (+4d) | 210d → 214d | 23% → 25% | 851d → 847d |  |  |
| 1807 | Obter Termos de Autorização de Superficiário e Desimpedimento da Área - Adutora Água Tratada da ETA de Baixo Guandu ao reservatório em Mascarenhas/ES |  | 2020-06-22 → 2020-06-26 (+4d) | 210d → 214d | 23% → 25% | 453d → 449d |  |  |
| 1808 | Conclusão da Regularização Fundiária para as obras de Melhoria do Sistema de Abastecimento - Mascarenhas/ES | 2020-06-22 → 2020-06-26 (+4d) | 2020-06-22 → 2020-06-26 (+4d) |  |  | 851d → 847d |  |  |
| 1809 | **Licenciamento** |  | 2020-06-26 → 2020-05-21 (-36d) | 200d → 175d | 12% → 25% | 847d → 872d |  |  |
| 1810 | Licenciamento e autorização para construção - Adutora Água Tratada (da ETA de Baixo Guandu até reservatório em Mascarenhas) |  | 2020-06-26 → 2020-05-21 (-36d) | 200d → 175d | 12% → 25% | 449d → 474d |  |  |
| 1811 | Conclusão do Licenciamento Ambiental da Localidade - Mascarenhas/ES | 2020-06-26 → 2020-05-21 (-36d) | 2020-06-26 → 2020-05-21 (-36d) |  |  | 847d → 872d |  |  |
| 1812 | **Suprimentos** |  | 2020-02-06 → 2020-02-10 (+4d) | 102d → 104d | 29% → 76% | 941d → 939d |  |  |
| 1813 | **Processo contratação MAS 1 (Adutora)** |  | 2020-02-06 → 2020-02-10 (+4d) | 102d → 104d | 29% → 76% | 941d → 939d |  |  |
| 1818 | Prospectar fornecedores e receber proposta técnicas - Mascarenhas/ES |  | 2019-11-04 → 2019-11-29 A (+25d) | 13d → 31d | 25% → 100% | 543d → none |  |  |
| 1819 | Aprovar proposta técnica - Mascarenhas/ES | 2019-11-05 → 2019-12-02 A (+27d) | 2019-11-25 → 2019-12-20 A (+25d) |  | 0% → 100% | 543d → none |  |  |
| 1820 | Realizar negociação e aprovar o pedido - Mascarenhas/ES | 2019-11-26 → 2019-12-23 A (+27d) | 2020-02-06 → 2020-02-10 (+4d) | 49d → 33d | 0% → 25% | 543d → 541d |  |  |
| 1821 | Conclusão da Contratação de Suprimentos - Adutora - Mascarenhas/ES | 2020-02-06 → 2020-02-10 (+4d) | 2020-02-06 → 2020-02-10 (+4d) |  |  | 941d → 939d |  |  |
| 1822 | Conclusão da Contratação de Suprimentos das obras de Melhoria do Sistema de Abastecimento de Água - Mascarenhas/ES | 2020-02-06 → 2020-02-10 (+4d) | 2020-02-06 → 2020-02-10 (+4d) |  |  | 941d → 939d |  |  |
| 1833 | **Colatina/ES (sede)** | 2018-08-07 A → 2019-11-04 A (+454d) | 2023-04-05 → 2023-04-13 (+8d) | 1164d → 854d | 5% → 0% | 156d → 151d |  |  |
| 1834 | **UTR - ETA Marista** | 2018-08-07 A → 2019-12-02 A (+482d) | 2023-04-05 → 2023-04-13 (+8d) | 1164d → 835d | 5% → 0% | 156d → 151d |  |  |
| 1835 | **Engenharia Básica e Detalhada** | 2019-11-04 → 2019-12-02 A (+28d) | 2020-09-14 → 2021-01-11 (+119d) | 213d → 274d | 0% → 2% | 157d → 214d |  |  |
| 1836 | **Engenharia UTR (ETA Marista) - SE 32257** | 2019-11-04 → 2019-12-02 A (+28d) | 2020-09-14 → 2021-01-11 (+119d) | 213d → 274d | 0% → 2% | 157d → 214d |  |  |
| 1837 | Aprovação Plano de Trabalho /abertura OSE - UTR - ETA Marista - Colatina/ES | 2019-11-04 → 2019-12-02 A (+28d) | 2019-11-25 → 2020-01-10 (+46d) | 15d → 26d | 0% → 25% | 157d → 151d | 24FS+949d → 24FS+968d |  |
| 1838 | Realizar Levantamento de Campo (Sondagem, Topografia) - UTR - ETA Marista - Colatina/ES | 2019-11-26 → 2020-01-13 (+48d) | 2020-01-27 → 2020-03-12 (+45d) |  |  | 196d → 167d |  |  |
| 1839 | Elaborar projeto Conceitual (Dados de Entrada Licenciamento e Fundiário) - UTR - ETA Marista - Colatina/ES | 2019-11-26 → 2020-01-13 (+48d) | 2020-03-25 → 2020-04-03 (+9d) | 80d → 57d |  | 157d → 151d |  |  |
| 1840 | Elaborar Projeto Básico - UTR - ETA Marista - Colatina/ES | 2020-03-26 → 2020-07-24 (+120d) | 2020-07-14 → 2020-11-10 (+119d) |  |  | 157d → 151d | 1839 → 1839FS+75d |  |
| 1841 | Obter Aprovação do projeto Básico com Prefeitura/Operadora- UTR - ETA Marista - Colatina/ES | 2020-07-15 → 2020-11-11 (+119d) | 2020-08-13 → 2020-12-10 (+119d) |  |  | 157d → 233d |  |  |
| 1842 | Emitir RT/PQ para Suprimentos - UTR - ETA Marista - Colatina/ES | 2020-08-14 → 2020-11-09 (+87d) | 2020-09-09 → 2020-12-02 (+84d) |  |  | 157d → 151d | 1840, 1841 → 1843FF-25d |  |
| 1843 | Elaborar Projeto Executivo - UTR - ETA Marista - Colatina/ES | 2020-06-09 → 2020-10-05 (+118d) | 2020-09-14 → 2021-01-11 (+119d) | 68d → 66d |  | 294d → 151d |  |  |
| 1844 | Elaboração do Projeto Executivo - UTR - ETA Marista - Colatina/ES | 2020-09-14 → 2021-01-11 (+119d) | 2020-09-14 → 2021-01-11 (+119d) |  |  | 294d → 214d | 1843 → 1843, 1841 |  |
| 1845 | **Fundiária** | 2018-08-07 A → 2020-04-06 (+608d) | 2021-06-02 → 2020-12-31 (-153d) | 705d → 185d | 23% → 0% | 615d → 260d |  |  |
| 1846 | Obter Termos de Autorização de Superficiário - UTRs - Imóveis 1, 2 e 4 (Marista, Aparecida e Columbia) - Colatina/ES | 2018-08-07 A → 2020-04-06 (+608d) | 2019-12-23 → 2020-04-13 (+112d) | 349d → 5d | 34% → 0% | 473d → 260d | 24 → 24, 1839 |  |
| 1847 | Realizar Negociação da Servidão do Imóvel - UTR Marista - Colatina/ES | 2020-09-10 → 2020-04-14 (-149d) | 2021-06-02 → 2020-12-31 (-153d) |  |  | 157d → 260d | 1842 → 1846 |  |
| 1848 | Conclusão da Regularização Fundiária para as obras de Melhoria do Sistema de Abastecimento da Localidade - Colatina/ES | 2021-06-02 → 2020-12-31 (-153d) | 2021-06-02 → 2020-12-31 (-153d) |  |  | 615d → 718d |  |  |
| 1849 | **Suprimentos** | 2020-09-10 → 2020-12-03 (+84d) | 2021-01-18 → 2021-04-14 (+86d) |  |  | 209d → 151d |  |  |
| 1850 | Suprimentos - Processo contratação UTRs - Colatina/ES | 2020-09-10 → 2020-12-03 (+84d) | 2021-01-18 → 2021-04-14 (+86d) |  |  | 209d → 151d |  |  |
| 1851 | Conclusão da Contratação de Suprimentos das obras de Melhoria do Sistema de Abastecimento de Água - Colatina/ES | 2021-01-18 → 2021-04-14 (+86d) | 2021-01-18 → 2021-04-14 (+86d) |  |  | 707d → 649d |  |  |
| 1852 | **Infraestrutura** | 2021-04-07 → 2021-04-15 (+8d) | 2023-04-05 → 2023-04-13 (+8d) | 499d → 498d |  | 156d → 151d |  |  |
| 1853 | **Obras** | 2021-04-07 → 2021-04-15 (+8d) | 2022-04-05 → 2022-04-13 (+8d) |  |  | 157d → 151d |  |  |
| 1854 | Executar UTR (ETA Marista 250L/s) - Colatina/ES | 2021-04-07 → 2021-04-15 (+8d) | 2022-04-05 → 2022-04-13 (+8d) |  |  | 157d → 151d |  |  |
| 1855 | Assinatura de Termo de Entrega das Obras de Melhoria do Sistema de Abastecimento de Água - Colatina/ES | 2022-04-05 → 2022-04-13 (+8d) | 2022-04-05 → 2022-04-13 (+8d) |  |  | 405d → 399d |  |  |
| 1856 | **Operação** | 2022-04-05 → 2022-04-13 (+8d) | 2023-04-05 → 2023-04-13 (+8d) | 249d → 248d |  | 156d → 151d |  |  |
| 1857 | Realizar Treinamento Operacional do Sistema - Colatina/ES | 2022-04-06 → 2022-04-14 (+8d) | 2022-04-12 → 2022-04-22 (+10d) |  |  | 386d → 380d |  |  |
| 1858 | Realizar Testes e Pré-operação - Colatina/ES | 2022-04-13 → 2022-04-25 (+12d) | 2022-05-04 → 2022-05-12 (+8d) |  |  | 386d → 380d |  |  |
| 1859 | Realizar Acompanhamento da Funcionalidade do Sistema - UTR - ETA Marista - Colatina/ES (sede) | 2022-04-05 → 2022-04-13 (+8d) | 2023-04-05 → 2023-04-13 (+8d) |  |  | 693d → 669d |  |  |
| 1860 | **Operação Assistida** | 2022-04-05 → 2022-04-13 (+8d) | 2022-07-04 → 2022-07-12 (+8d) |  |  | 157d → 151d |  |  |
| 1861 | Realizar Operação Assistida - Colatina/ES | 2022-04-05 → 2022-04-13 (+8d) | 2022-07-04 → 2022-07-12 (+8d) |  |  | 693d → 669d |  |  |
| 1862 | **UTR - ETA Aparecida** | 2018-08-07 A → 2019-11-04 A (+454d) | 2023-01-06 → 2023-01-03 (-3d) | 1104d → 786d | 5% → 1% | 216d → 219d |  |  |
| 1863 | **Engenharia** | 2019-11-04 A | 2020-10-09 → 2020-09-09 (-30d) | 232d → 210d | 0% → 4% | 217d → 297d |  |  |

| ID | Task | Start | Finish | Duration | Complete | Total float | Predecessors |
| --- | --- | --- | --- | --- | --- | --- | --- |
| 1864 | **Engenharia Básica e Detalhada** | 2019-11-04 A | 2020-10-09 → 2020-09-09 (-30d) | 232d → 210d | 0% → 4% | 217d → 297d |  |
| 1865 | **Engenharia UTR (ETA Aparecida) - SE 32256** | 2019-11-04 A | 2020-10-09 → 2020-09-09 (-30d) | 232d → 210d | 0% → 4% | 217d → 297d |  |
| 1866 | Aprovação Plano de Trabalho /abertura OSE - UTR - ETA Aparecida - Colatina/ES | 2019-11-04 A | 2019-11-25 → 2020-01-10 (+46d) | 15d → 45d | 0% → 25% | 217d → 220d |  |
| 1867 | Realizar levantamento de Campo e Sondagem - UTR - ETA Aparecida - Colatina/ES | 2019-11-26 → 2020-01-13 (+48d) | 2020-01-27 → 2020-03-12 (+45d) |  |  | 256d → 236d |  |
| 1868 | Elaborar projeto Conceitual (Dados de Entrada Licenciamento e Fundiário) - UTR - Aparecida - Colatina/ES | 2019-11-26 → 2020-01-13 (+48d) | 2020-03-25 → 2020-04-03 (+9d) | 80d → 57d |  | 217d → 220d |  |
| 1869 | Elaborar Projeto Básico - UTR - ETA Aparecida - Colatina/ES | 2020-03-26 → 2020-04-06 (+11d) | 2020-07-09 → 2020-07-22 (+13d) | 72d → 74d |  | 217d → 234d |  |
| 1870 | Obter Aprovação do projeto Básico com Prefeitura/Operadora - UTR - ETA Aparecida - Colatina/ES | 2020-07-10 → 2020-07-23 (+13d) | 2020-08-10 → 2020-08-21 (+11d) |  |  | 217d → 309d |  |
| 1871 | Emitir RT/PQ para Suprimentos - UTR - ETA Aparecida - Colatina/ES | 2020-08-11 → 2020-07-17 (-25d) | 2020-08-27 → 2020-08-04 (-23d) |  |  | 217d → 234d | 1870 → 1872FF-25d |
| 1872 | Elaborar Projeto Executivo - UTR - ETA Aparecida - Colatina/ES | 2020-07-07 → 2020-06-19 (-18d) | 2020-10-09 → 2020-09-09 (-30d) | 68d → 58d |  | 275d → 234d | 1870FS-25d → 1869FS-24d |
| 1873 | Elaboração do Projeto Executivo - UTR - ETA Aparecida - Colatina/ES | 2020-10-09 → 2020-09-09 (-30d) | 2020-10-09 → 2020-09-09 (-30d) |  |  | 275d → 297d | 1872 → 1872, 1870 |
| 1874 | **Fundiária** | 2018-08-07 A → 2020-04-06 (+608d) | 2020-12-11 → 2020-12-31 (+20d) | 590d → 185d | 23% → 0% | 730d → 220d |  |
| 1875 | Obter Termos de Autorização de Superficiário - UTRs - Imóveis 1, 2 e 4 (Marista, Aparecida e Columbia) - Colatina/ES | 2018-08-07 A → 2020-04-06 (+608d) | 2019-12-23 → 2020-04-13 (+112d) | 349d → 5d | 34% → 0% | 473d → 220d | none → 1868 |
| 1876 | Realizar Negociação da Servidão do Imóvel - UTR Aparecida - Colatina/ES | 2020-03-26 → 2020-04-14 (+19d) | 2020-12-11 → 2020-12-31 (+20d) |  |  | 272d → 220d | 1868 → 1875 |
| 1877 | Conclusão da Regularização Fundiária para as obras de Melhoria do Sistema de Abastecimento da Localidade - Colatina/ES | 2020-12-11 → 2020-12-31 (+20d) | 2020-12-11 → 2020-12-31 (+20d) |  |  | 730d → 718d |  |
| 1878 | **Suprimentos** | 2020-08-28 → 2020-08-05 (-23d) | 2021-01-06 → 2020-12-09 (-28d) |  |  | 217d → 234d |  |
| 1879 | Suprimentos - Processo contratação UTRs - Colatina/ES | 2020-08-28 → 2020-08-05 (-23d) | 2021-01-06 → 2020-12-09 (-28d) |  |  | 217d → 234d |  |
| 1880 | Conclusão da Contratação de Suprimentos das obras de Melhoria do Sistema de Abastecimento de Água - Colatina/ES | 2021-01-06 → 2020-12-09 (-28d) | 2021-01-06 → 2020-12-09 (-28d) |  |  | 715d → 732d |  |
| 1881 | **Infraestrutura** | 2021-01-07 → 2021-01-04 (-3d) | 2023-01-06 → 2023-01-03 (-3d) |  |  | 216d → 219d |  |
| 1882 | **Obras** | 2021-01-07 → 2021-01-04 (-3d) | 2022-01-06 → 2022-01-03 (-3d) |  |  | 217d → 220d |  |
| 1883 | Executar UTR (ETA Aparecida 250L/s) - Colatina/ES | 2021-01-07 → 2021-01-04 (-3d) | 2022-01-06 → 2022-01-03 (-3d) |  |  | 217d → 220d | 1873, 1875, 1876FS-40d, 1879 → 1873, 1875, 1876, 1879 |
| 1884 | Assinatura de Termo de Entrega das Obras de Melhoria do Sistema de Abastecimento de Água - Colatina/ES | 2022-01-06 → 2022-01-03 (-3d) | 2022-01-06 → 2022-01-03 (-3d) |  |  | 465d → 468d |  |
| 1885 | **Operação** | 2022-01-06 → 2022-01-03 (-3d) | 2023-01-06 → 2023-01-03 (-3d) |  |  | 216d → 219d |  |
| 1886 | Realizar Treinamento Operacional do Sistema - Colatina/ES | 2022-01-07 → 2022-01-04 (-3d) | 2022-01-13 → 2022-01-10 (-3d) |  |  | 446d → 449d |  |
| 1887 | Realizar Testes e Pré-operação - Colatina/ES | 2022-01-14 → 2022-01-11 (-3d) | 2022-02-02 → 2022-01-28 (-5d) |  |  | 446d → 449d |  |
| 1888 | Realizar Acompanhamento da Funcionalidade do Sistema - UTR - ETA Aparecida - Colatina/ES (sede) | 2022-01-06 → 2022-01-03 (-3d) | 2023-01-06 → 2023-01-03 (-3d) |  |  | 960d → 969d |  |
| 1889 | **Operação Assistida** | 2022-01-06 → 2022-01-03 (-3d) | 2022-04-06 → 2022-04-03 (-3d) |  |  | 217d → 220d |  |
| 1890 | Realizar Operação Assistida - Colatina/ES | 2022-01-06 → 2022-01-03 (-3d) | 2022-04-06 → 2022-04-03 (-3d) |  |  | 960d → 969d |  |
| 1891 | **UTR - ETA Columbia** | 2018-08-07 A → 2019-11-29 A (+479d) |  | 1002d → 669d | 5% → 0% |  |  |
| 1892 | **Engenharia Básica e Detalhada** | 2020-03-02 → 2019-11-29 A (-94d) | 2020-11-12 → 2020-10-22 (-21d) | 177d → 222d | 0% → 2% | 320d → 407d |  |
| 1893 | **Engenharia UTR (ETA Columbia) - SE 32258** | 2020-03-02 → 2019-11-29 A (-94d) | 2020-11-12 → 2020-10-22 (-21d) | 177d → 222d | 0% → 2% | 320d → 407d |  |
| 1894 | Aprovação Plano de Trabalho /abertura OSE - UTR - ETA Columbia - Colatina/ES | 2020-03-02 → 2019-11-29 A (-94d) | 2020-03-20 → 2020-01-10 (-70d) | 15d → 27d | 0% → 25% |  | 24FS+1026d → 24FS+967d |
| 1895 | Realizar levantamento de Campo e Sondagem - UTR - ETA Columbia - Colatina/ES | 2020-03-23 → 2020-01-13 (-70d) | 2020-05-14 → 2020-03-19 (-56d) | 36d → 46d |  | 354d → 320d |  |
| 1896 | Elaborar Projeto Conceitual (Dados de Entrada Licenciamento e Fundiário) - UTR - ETA Columbia - Colatina/ES | 2020-03-30 → 2020-03-20 (-10d) | 2020-07-02 → 2020-06-18 (-14d) | 65d → 61d |  |  | 1894FS+5d, 1895FF → 1895 |
| 1897 | Elaborar Projeto Básico - UTR - ETA Columbia - Colatina/ES |  |  |  |  | 320d → 344d | 1896FS-10d → 1896 |
| 1899 | Emitir RT/PQ para Suprimentos - UTR - ETA Columbia - Colatina/ES | 2020-10-07 → 2020-09-14 (-23d) | 2020-10-21 → 2020-09-16 (-35d) | 10d → 3d |  | 320d → 344d | 1898 → 1900FF-25d |
| 1900 | Elaborar Projeto Executivo - UTR - ETA Columbia - Colatina/ES | 2020-08-31 → 2020-07-31 (-31d) | 2020-11-12 → 2020-10-22 (-21d) | 51d → 58d |  | 393d → 344d | 1898FS-26d → 1897FS-25d |
| 1901 | Elaboração do Projeto Executivo - UTR - ETA Columbia - Colatina/ES | 2020-11-12 → 2020-10-22 (-21d) | 2020-11-12 → 2020-10-22 (-21d) |  |  | 393d → 407d | 1900 → 1900, 1898 |
| 1902 | **Fundiária** | 2018-08-07 A → 2020-06-19 (+682d) | 2021-03-24 → 2021-03-03 (-21d) | 657d → 175d | 23% → 0% | 663d → 320d |  |
| 1903 | Obter Termos de Autorização de Superficiário - UTRs - Imóveis 1, 2 e 4 (Marista, Aparecida e Columbia) - Colatina/ES | 2018-08-07 A → 2020-06-19 (+682d) | 2019-12-23 → 2020-06-25 (+185d) | 349d → 5d | 34% → 0% | 613d → 320d | none → 1896 |
| 1904 | Realizar Negociação da Servidão do Imóvel - UTR Columbia - Colatina/ES | 2020-07-03 → 2020-06-26 (-7d) | 2021-03-24 → 2021-03-03 (-21d) | 180d → 170d |  | 345d → 320d | 1896 → 1903 |
| 1905 | Conclusão da Regularização Fundiária para as obras de Melhoria do Sistema de Abastecimento da Localidade - Colatina/ES | 2021-03-24 → 2021-03-03 (-21d) | 2021-03-24 → 2021-03-03 (-21d) |  |  | 663d → 678d | 1903, 1904 → 1904 |
| 1906 | **Suprimentos** | 2020-10-22 → 2020-09-17 (-35d) | 2021-03-03 → 2021-01-25 (-37d) |  |  | 320d → 344d |  |
| 1907 | Suprimentos - Processo contratação UTRs - Colatina/ES | 2020-10-22 → 2020-09-17 (-35d) | 2021-03-03 → 2021-01-25 (-37d) |  |  | 320d → 344d |  |
| 1908 | Conclusão da Contratação de Suprimentos das obras de Melhoria do Sistema de Abastecimento de Água - Colatina/ES | 2021-03-03 → 2021-01-25 (-37d) | 2021-03-03 → 2021-01-25 (-37d) |  |  | 678d → 702d |  |
| 1911 | Executar UTR (ETA Columbia 19L/s) - Colatina/ES |  |  |  |  |  | 1903, 1907, 1901, 1904FS-40d → 1907, 1901, 1904 |
| 1919 | **Boninsegna (distrito Marilândia/ES)** |  | 2022-03-26 → 2022-03-05 (-21d) | 1041d → 1026d |  | 412d → 427d |  |
| 1920 | **Captação Principal, Alternativa, Nova ETA e UTR** |  | 2022-03-26 → 2022-03-05 (-21d) | 1041d → 1026d |  | 412d → 427d |  |
| 1927 | **Engenharia Básica e Detalhada** |  |  |  | 78% → 82% |  |  |
| 1928 | **Engenharia Captação Principal (Rio Doce) - SE 32103** |  |  |  | 78% → 84% |  |  |
| 1931 | Realizar sondagem - Captação Principal - Rio Doce - Boninsegna/ES | 2019-11-21 → 2020-01-02 (+42d) | 2019-12-18 → 2020-01-02 (+15d) | 19d → 1d |  | 17.8d → 2.1d | 1929FS+170d → 1929FS+196d |
| 1935 | Emitir RT/PQ para Suprimentos - Captação Principal - Rio Doce - Boninsegna/ES | 2019-12-02 A | 2019-12-16 → 2020-01-02 A (+17d) | 10d → 20d | 0% → 100% | 461d → none |  |
| 1936 | Elaborar Projeto Executivo - Captação Principal - Rio Doce - Boninsegna/ES |  |  |  | 70% → 65% |  |  |
| 1938 | **Engenharia Captação Alternativa (Poço raso existente) - SE 32103** |  |  |  | 77% → 82% |  |  |
| 1941 | Realizar sondagem - Captação Alternativa - Cacimba - Boninsegna/ES | 2019-11-21 → 2020-01-02 (+42d) | 2019-12-18 → 2020-01-02 (+15d) | 19d → 1d |  | 10.8d → 571d | 1939FS+170d → 1939FS+196d |
| 1945 | Emitir RT/PQ para Suprimentos - Captação Alternativa - Cacimba - Boninsegna/ES | 2019-12-02 A | 2019-12-16 → 2020-01-02 A (+17d) | 10d → 20d | 0% → 100% | 461d → none |  |
| 1946 | Elaborar Projeto Executivo - Captação Alternativa - Cacimba - Boninsegna/ES | 2019-07-17 A → 2019-07-01 A (-16d) |  | 154d → 166d | 70% → 65% |  | 1941FS-11d, 1942, 1943, 1944FS-11d → 1941FF, 1942, 1943, 1944FS-11d |
| 1948 | **Engenharia nova ETA - SE 32103** |  |  |  | 78% → 79% |  |  |
| 1952 | Emitir RT/PQ para Suprimentos - Nova ETA - Boninsegna/ES | 2019-12-02 A | 2019-12-16 → 2020-01-02 A (+17d) | 10d → 20d | 0% → 100% | 461d → none |  |
| 1953 | Elaborar Projeto Executivo - Nova ETA - Boninsegna/ES |  |  |  | 70% → 65% |  |  |
| 1955 | **Engenharia UTR - SE 32103** |  |  |  | 79% → 80% | 413d → 533d |  |
| 1959 | Emitir RT/PQ para Suprimentos - UTR - Boninsegna/ES | 2019-12-02 A | 2019-12-16 → 2020-01-02 A (+17d) | 10d → 20d | 0% → 100% | 461d → none |  |
| 1960 | Elaborar Projeto Executivo - UTR - Boninsegna/ES |  |  |  | 70% → 65% | 413d → 533d |  |
| 1962 | **Fundiária** |  | 2020-06-15 → 2020-06-26 (+11d) | 268d → 277d |  | 856d → 847d |  |
| 1963 | Obter Termo de Autorização de Superficiário - Captação Principal - Boninsegna/ES |  | 2020-02-07 → 2020-02-20 (+13d) | 99d → 108d | 21% → 23% | 461d → 452d |  |
| 1964 | Captação Principal - Desimpedimento da Área e Negociação de Servidão - Boninsegna/ES | 2020-02-10 → 2020-02-21 (+11d) | 2020-06-15 → 2020-06-26 (+11d) |  |  | 461d → 452d |  |
| 1965 | Obter Termo de Autorização de Superficiário - Captação Alternativa - Boninsegna/ES |  | 2020-02-07 → 2020-02-20 (+13d) | 184d → 193d | 25% → 24% | 461d → 452d |  |
| 1966 | Captação Alternativa - Desimpedimento da Área e Negociação de Servidão - Boninsegna/ES | 2020-02-10 → 2020-02-21 (+11d) | 2020-06-15 → 2020-06-26 (+11d) |  |  | 461d → 452d |  |
| 1967 | Obter Termo de Autorização de Superficiário - Nova ETA / UTR - Boninsegna/ES |  | 2020-02-07 → 2020-02-20 (+13d) | 184d → 193d | 25% → 24% | 856d → 847d |  |
| 1968 | Nova ETA / UTR - Desimpedimento da Área e Negociação de Servidão - Boninsegna/ES | 2020-02-10 → 2020-02-21 (+11d) | 2020-06-15 → 2020-06-26 (+11d) |  |  | 856d → 847d |  |
| 1969 | Conclusão da Regularização Fundiária para as obras de Melhoria do Sistema de Abastecimento da Localidade - Boninsegna/ES | 2020-06-15 → 2020-06-26 (+11d) | 2020-06-15 → 2020-06-26 (+11d) |  |  | 856d → 847d |  |

| ID | Task | Start | Finish | Duration | Complete | Total float | Predecessors | Other |
| --- | --- | --- | --- | --- | --- | --- | --- | --- |
| 1970 | **Licenciamento** |  | 2020-07-09 → 2020-07-10 (+1d) | 233d → 234d | 28% → 25% | 838d → 837d |  |  |
| 1971 | Obter Outorga e autorizações (captação principal, construção ETA e UTR) - Boninsegna/ES |  | 2020-07-09 → 2020-07-10 (+1d) | 233d → 234d | 28% → 25% | 443d → 442d |  |  |
| 1972 | Captação Alternativa - Dispensa de Licença (Poço raso existente) - Boninsegna/ES |  |  |  | 28% → 25% |  |  |  |
| 1973 | Conclusão do Licenciamento Ambiental da Localidade - Boninsegna/ES | 2020-07-09 → 2020-07-10 (+1d) | 2020-07-09 → 2020-07-10 (+1d) |  |  | 838d → 837d |  |  |
| 1974 | **Suprimentos** | 2019-12-17 → 2020-01-02 (+16d) | 2020-07-07 → 2020-06-16 (-21d) | 136d → 111d |  | 461d → 428d |  |  |
| 1975 | **Processo contratação - Captação Principal, nova ETA e UTR - Boninsegna/ES** | 2020-02-28 → 2020-01-02 (-57d) | 2020-07-07 → 2020-05-13 (-55d) |  |  | 413d → 451d |  |  |
| 1976 | Recebimento da RT/PQ pelo Suprimentos - Boninsegna/ES | 2020-02-28 → 2020-01-02 (-57d) | 2020-02-28 → 2020-01-02 (-57d) |  |  | 413d → 451d | 1935, 1952, 1959, 1961 → 1935, 1952, 1959 |  |
| 1977 | Realizar Entendimento da Demanda - Boninsegna/ES | 2020-03-02 → 2020-01-03 (-59d) | 2020-03-13 → 2020-01-16 (-57d) |  |  | 413d → 451d |  |  |
| 1978 | Abrir a RC - Boninsegna/ES | 2020-03-16 → 2020-01-17 (-59d) | 2020-03-25 → 2020-01-28 (-57d) |  |  | 413d → 451d |  |  |
| 1979 | Aprovar a RC (liberação) - Boninsegna/ES | 2020-03-26 → 2020-01-29 (-57d) | 2020-04-06 → 2020-02-07 (-59d) |  |  | 413d → 451d |  |  |
| 1980 | Prospectar fornecedores e receber proposta técnicas - Boninsegna/ES | 2020-04-07 → 2020-02-10 (-57d) | 2020-05-21 → 2020-03-25 (-57d) |  |  | 413d → 451d |  |  |
| 1981 | Aprovar proposta técnica - Boninsegna/ES | 2020-05-22 → 2020-03-26 (-57d) | 2020-06-08 → 2020-04-13 (-56d) |  |  | 413d → 451d |  |  |
| 1982 | Realizar negociação e aprovar o pedido - Boninsegna/ES | 2020-06-09 → 2020-04-14 (-56d) | 2020-07-07 → 2020-05-13 (-55d) |  |  | 413d → 451d |  |  |
| 1983 | Conclusão da Contratação de Suprimentos - Boninsegna/ES | 2020-07-07 → 2020-05-13 (-55d) | 2020-07-07 → 2020-05-13 (-55d) |  |  | 413d → 451d |  |  |
| 1984 | Processo contratação Serviço Limpeza em Poços Rasos (Tintori) - Boninsegna/ES | 2019-12-17 → 2020-01-03 (+17d) | 2020-04-28 → 2020-06-16 (+49d) | 88d → 111d |  | 461d → 428d |  | was named Processo contratação Serviço Limpeza em Poços Rasos - Boninsegna/ES |
| 1985 | Conclusão da Contratação de Suprimentos das obras de Melhoria do Sistema de Abastecimento de Água - Boninsegna/ES | 2020-04-28 → 2020-06-16 (+49d) | 2020-04-28 → 2020-06-16 (+49d) |  |  | 888d → 855d |  |  |
| 1986 | **Infraestrutura** | 2020-07-08 → 2020-06-17 (-21d) | 2022-03-26 → 2022-03-05 (-21d) |  |  | 412d → 427d |  |  |
| 1987 | **Obras** | 2020-07-08 → 2020-06-17 (-21d) | 2021-03-26 → 2021-03-05 (-21d) |  |  | 413d → 428d |  |  |
| 1988 | **Captação Alternativa - Poço raso (Cacimba)** | 2020-07-08 → 2020-06-17 (-21d) | 2021-03-26 → 2021-03-05 (-21d) |  |  | 413d → 428d |  |  |
| 1989 | Realizar Recuperação - Captação Alternativa - Cacimba - Boninsegna/ES | 2020-07-08 → 2020-06-17 (-21d) | 2020-07-14 → 2020-06-23 (-21d) |  |  | 413d → 428d |  |  |
| 1990 | Elaborar Relatório Técnico - Captação Alternativa - Cacimba - Boninsegna/ES | 2020-07-15 → 2020-06-24 (-21d) | 2020-08-17 → 2020-07-27 (-21d) |  |  | 413d → 428d |  |  |
| 1991 | Realizar Instrumentação - Captação Alternativa - Cacimba - Boninsegna/ES | 2020-08-18 → 2020-07-28 (-21d) | 2020-08-20 → 2020-07-30 (-21d) |  |  | 413d → 428d |  |  |
| 1992 | Realizar Laudo dos Serviços de Coleta e Análise de Água - Captação Alternativa - Cacimba - Boninsegna/ES | 2020-07-15 → 2020-06-24 (-21d) | 2020-08-17 → 2020-07-27 (-21d) |  |  | 416d → 431d |  |  |
| 1993 | Executar Captação Alternativa (Urbanização Poço Raso existente) - Boninsegna/ES | 2020-08-21 → 2020-07-31 (-21d) | 2021-03-26 → 2021-03-05 (-21d) |  |  | 413d → 428d |  |  |
| 1994 | Conclusão das obras de Captação Alternativa - Poço Raso (Cacimba) - Boninsegna/ES | 2020-08-17 → 2020-07-27 (-21d) | 2020-08-17 → 2020-07-27 (-21d) |  |  | 416d → 431d |  |  |
| 1995 | Executar Captação, ETA e UTR - Boninsegna/ES | 2020-07-10 → 2020-07-13 (+3d) | 2021-02-09 → 2021-02-10 (+1d) |  |  | 443d → 442d | 1936, 1964, 1971, 1983 → 1936, 1964, 1971, 1983, 1961 |  |
| 1996 | Assinatura de Termo de Entrega das Obras de Melhoria do Sistema de Abastecimento de Água - Boninsegna/ES | 2021-03-26 → 2021-03-05 (-21d) | 2021-03-26 → 2021-03-05 (-21d) |  |  | 661d → 676d |  |  |
| 1997 | **Operação** | 2021-03-26 → 2021-03-05 (-21d) | 2022-03-26 → 2022-03-05 (-21d) |  |  | 412d → 427d |  |  |
| 1998 | Realizar Treinamento Operacional do Sistema - Boninsegna/ES | 2021-03-29 → 2021-03-08 (-21d) | 2021-04-05 → 2021-03-12 (-24d) |  |  | 642d → 657d |  |  |
| 1999 | Realizar Testes e Pré-operação - Boninsegna/ES | 2021-04-06 → 2021-03-15 (-22d) | 2021-04-26 → 2021-04-01 (-25d) |  |  | 642d → 657d |  |  |
| 2000 | Realizar Acompanhamento da Funcionalidade do Sistema - Captação Principal, Alternativa, Nova ETA e UTR - Boninsegna (distrito Marilândia/ES) | 2021-03-26 → 2021-03-05 (-21d) | 2022-03-26 → 2022-03-05 (-21d) |  |  | 1818d → 1881d |  |  |
| 2001 | **Operação Assistida** | 2021-03-26 → 2021-03-05 (-21d) | 2021-06-24 → 2021-06-03 (-21d) |  |  | 413d → 428d |  |  |
| 2002 | Realizar Operação Assistida - Boninsegna/ES | 2021-03-26 → 2021-03-05 (-21d) | 2021-06-24 → 2021-06-03 (-21d) |  |  | 1818d → 1881d |  |  |
| 2003 | **Território Foz do Rio Doce Litoral** |  |  |  | 10% → 11% |  |  |  |
| 2004 | **Linhares/ES (sede)** |  |  |  | 13% → 16% |  |  |  |
| 2005 | **Captação Alternativa - Adequação da captação na Lagoa Nova** |  | 2021-05-04 → 2021-05-05 (+1d) | 846d → 847d | 18% → 21% | 636d → 635d |  |  |
| 2009 | **Engenharia Básica e Detalhada** |  | 2019-11-19 → 2019-11-29 A (+10d) | 296d → 304d | 92% → 100% | 994d → none |  |  |
| 2010 | **Engenharia Captação Alternativa - Lagoa Nova (Recuperação de Erosões) - SE32128** |  | 2019-11-19 → 2019-11-29 A (+10d) | 296d → 304d | 90% → 100% | 994d → none |  |  |
| 2016 | Emitir RT/PQ para Infra (Guarda-chuva) - Recuperação Erosões - Captação Alternativa - Lagoa Nova - Linhares/ES | 2019-11-05 → 2019-11-18 A (+13d) | 2019-11-19 → 2019-11-29 A (+10d) |  | 0% → 100% | 663d → none |  |  |
| 2017 | Elaborar Projeto Executivo - Recuperação Erosões - Captação Alternativa - Lagoa Nova - Linhares/ES |  | 2019-11-19 → 2019-11-29 A (+10d) | 53d → 61d | 63% → 100% | 663d → none |  |  |
| 2018 | Elaboração do Projeto Executivo - Recuperação Erosões - Captação Alternativa - Lagoa Nova - Linhares/ES | 2019-11-19 → 2019-11-29 A (+10d) | 2019-11-19 → 2019-11-29 A (+10d) |  | 0% → 100% | 994d → none |  |  |
| 2019 | **Engenharia Captação Alternativa - Lagoa Nova (Adequação do Sistema Captação) e Captação Principal (Barrilete)** |  |  |  |  |  |  | was named Engenharia Captação Alternativa - Lagoa Nova (Adequação do Sistema Captação - Barrilete) |
| 2025 | **Suprimentos** |  |  |  | 37% → 33% |  |  |  |
| 2026 | **Captação Alternativa e Captação Principal** |  | 2019-10-04 A → 2020-01-24 (+112d) | 13d → 88d | 100% → 46% | none → 950d |  | was named Captação Alternativa |
| 2028 | Realizar contratação - Captação Alternativa - Sistema de Automação - e Captação Principal - Barrilete - Linhares/ES |  |  |  |  |  |  | was named Realizar contratação Captação Alternativa (Caiado) - Barrilete e Sistema de Automação - Linhares/ES |
| 2030 | Conclusão da Contratação de Suprimentos - Lagoa Nova - Captação Alternativa - Linhares/ES | 2019-10-04 A → 2020-01-24 (+112d) | 2019-10-04 A → 2020-01-24 (+112d) |  | 100% → 0% | none → 950d | 2028 → 2028, 2029 |  |
| 2033 | **Infraestrutura** | 2019-11-01 → 2020-01-27 (+87d) | 2021-05-04 → 2021-05-05 (+1d) | 370d → 315d |  | 636d → 635d |  |  |
| 2034 | **Obras** | 2019-11-01 → 2020-01-27 (+87d) | 2020-05-04 → 2020-05-05 (+1d) | 121d → 66d |  | 675d → 636d |  |  |
| 2035 | **Captação Alternativa** | 2019-11-01 → 2020-01-27 (+87d) | 2020-05-04 → 2020-05-05 (+1d) | 121d → 66d |  | 637d → 636d |  |  |
| 2036 | Executar adequação na Captação Alternativa - Recuperação de Erosões - Linhares/ES | 2019-11-20 → 2020-01-27 (+68d) | 2020-03-24 → 2020-05-05 (+42d) | 83d → 66d |  | 663d → 636d | 2016, 2017 → 2016, 2017, 2029 |  |
| 2038 | Conclusão das obras de adequação na Captação Alternativa - Linhares/ES | 2020-05-04 → 2020-05-05 (+1d) | 2020-05-04 → 2020-05-05 (+1d) |  |  | 637d → 636d | 2074, 2036, 2073, 2072, 2037 → 2036, 2037 |  |
| 2039 | Assinatura de Termo de Entrega das Obras de Melhoria do Sistema de Abastecimento de Água - Linhares/ES | 2020-05-04 → 2020-05-05 (+1d) | 2020-05-04 → 2020-05-05 (+1d) |  |  | 885d → 884d |  |  |
| 2040 | **Operação** | 2020-05-04 → 2020-05-05 (+1d) | 2021-05-04 → 2021-05-05 (+1d) |  |  | 636d → 635d |  |  |
| 2041 | Realizar Treinamento Operacional do Sistema - Linhares/ES | 2020-05-05 → 2020-05-06 (+1d) | 2020-05-11 → 2020-05-12 (+1d) |  |  | 866d → 865d |  |  |
| 2042 | Realizar Testes e Pré-operação (Para as adequações da ETA) - Linhares/ES | 2020-05-12 → 2020-05-13 (+1d) | 2020-05-29 → 2020-06-01 (+3d) |  |  | 866d → 865d |  |  |
| 2043 | Realizar Acompanhamento da Funcionalidade do Sistema - Captação Alternativa - Adequação da captação na Lagoa Nova - Linhares/ES (sede) | 2020-05-04 → 2020-05-05 (+1d) | 2021-05-04 → 2021-05-05 (+1d) |  |  | 2796d → 2793d |  |  |
| 2044 | **Operação Assistida** | 2020-05-04 → 2020-05-05 (+1d) | 2020-08-02 → 2020-08-03 (+1d) |  |  | 636d → 635d |  |  |
| 2045 | Realizar Operação Assistida - Linhares/ES | 2020-05-04 → 2020-05-05 (+1d) | 2020-08-02 → 2020-08-03 (+1d) |  |  | 2796d → 2793d |  |  |
| 2046 | **Melhorias em ETA e Captação Principal** |  | 2022-04-20 → 2022-01-05 (-105d) | 1087d → 1016d | 14% → 19% | 395d → 466d |  | baseline start 2016-12-02 → 2016-07-01 |
| 2050 | **Engenharia Básica e Detalhada** |  | 2020-05-04 → 2020-01-20 (-105d) | 327d → 258d | 53% → 80% | 885d → 954d |  |  |
| 2051 | **Engenharia Captação Principal (Pequenas Melhorias) - Rio Pequeno - SE32283** |  |  |  | 46% → 78% |  |  |  |
| 2055 | Elaborar Projeto Executivo - Captação Principal - Rio Pequeno - Linhares/ES |  |  |  | 40% → 78% | 623d → 468d |  |  |
| 2057 | **Engenharia Melhorias ETA** |  | 2020-05-04 → 2020-01-20 (-105d) | 326d → 257d | 57% → 81% | 885d → 954d |  |  |
| 2061 | Emitir RT/PQ para Infra - CGC - Melhorias na ETA - Linhares/ES | 2020-04-17 → 2020-01-07 (-101d) | 2020-05-04 → 2020-01-20 (-105d) |  |  | 554d → 468d | 2062FF, Elaborar Projeto Executivo - Automação das Válvulas - Linhares/ESFF → 2062FF |  |
| 2063 | Elaboração do Projeto Executivo - Melhorias na ETA - Linhares/ES | 2020-05-04 → 2020-01-20 (-105d) | 2020-05-04 → 2020-01-20 (-105d) |  |  | 885d → 954d | 2062, Elaborar Projeto Executivo - Automação das Válvulas - Linhares/ES → 2062 |  |
| 2070 | **Infraestrutura** | 2020-05-05 → 2019-10-30 A (-188d) | 2022-04-20 → 2022-01-05 (-105d) | 490d → 542d | 0% → 3% | 395d → 466d |  |  |
| 2071 | **Obras** | 2020-05-05 → 2019-10-30 A (-188d) | 2021-04-20 → 2021-01-05 (-105d) | 240d → 292d | 0% → 12% | 397d → 716d |  |  |
| 2072 | Executar adequação na Captação Principal - Manutenção nas 2 bombas de 50 cv do SAAE - Linhares/ES | 2019-11-01 → 2019-11-20 A (+19d) | 2019-12-10 → 2019-12-16 A (+6d) | 27d → 18d | 0% → 100% | 731d → none | 2027FS+31d → 2027FS+43d | was named Executar adequação na Captação Alternativa - Manutenção nas 2 bombas de 50 cv do SAAE - Linhares/ES |
| 2073 | Executar adequação na Captação Principal - Manutenção nas 6 bombas de 2 cv do SAAE - Linhares/ES | 2019-11-01 → 2019-10-30 A (-2d) | 2019-12-03 → 2019-11-22 A (-11d) | 22d → 17d | 0% → 100% | 736d → none | 2027FS+31d → 2027FS+29d | was named Executar adequação na Captação Alternativa - Manutenção nas 6 bombas de 2 cv do SAAE - Linhares/ES |
| 2074 | Executar adequação na Captação Principal - Barrilete e Sistema de Automação - Linhares/ES | 2019-11-04 → 2019-11-19 A (+15d) | 2019-12-09 → 2020-01-17 (+39d) | 25d → 40d | 0% → 25% | 732d → 955d | 2023, 2028FS+20d, 2030FS+20d → 2023, 2028FS+30d | was named Executar adequação na Captação Alternativa - Barrilete e Sistema de Automação - Linhares/ES |

| ID | Task | Start | Finish | Duration | Complete | Total float | Predecessors | Other |
| --- | --- | --- | --- | --- | --- | --- | --- | --- |
| 2075 | Executar Obras de melhoria na Captação Principal - Captação rio Pequeno - Linhares/ES | 2020-05-05 → 2020-06-01 (+27d) | 2020-08-28 → 2021-01-05 (+130d) | 83d → 150d |  | 554d → 468d | 2054, 2055, 2061 → 2069 |  |
| 2076 | Executar Melhorias na ETA - Linhares/ES | 2020-05-05 → 2020-06-01 (+27d) | 2021-04-20 → 2021-01-05 (-105d) | 240d → 150d |  | 397d → 468d | 2062, Elaborar Projeto Executivo - Automação das Válvulas - Linhares/ES → 2069 |  |
| 2078 | Assinatura de Termo de Entrega das Obras de Melhoria do Sistema de Abastecimento de Água - Linhares/ES | 2021-04-20 → 2021-01-05 (-105d) | 2021-04-20 → 2021-01-05 (-105d) |  |  | 645d → 716d | 2075, 2076, 2056, 2063 → 2056, 2063, 2069, 2077, 2068 |  |
| 2079 | **Operação** | 2021-04-20 → 2021-01-05 (-105d) | 2022-04-20 → 2022-01-05 (-105d) |  |  | 395d → 466d |  |  |
| 2080 | Realizar Treinamento Operacional do Sistema - Linhares/ES | 2021-04-22 → 2021-01-06 (-106d) | 2021-04-28 → 2021-01-12 (-106d) |  |  | 626d → 697d |  |  |
| 2081 | Realizar Testes e Pré-operação (Para as adequações da ETA) - Linhares/ES | 2021-04-29 → 2021-01-13 (-106d) | 2021-05-18 → 2021-02-01 (-106d) |  |  | 626d → 697d |  |  |
| 2082 | Realizar Acompanhamento da Funcionalidade do Sistema - Melhorias em ETA e Captação Principal - Linhares/ES (sede) | 2021-04-20 → 2021-01-05 (-105d) | 2022-04-20 → 2022-01-05 (-105d) |  |  | 1743d → 2058d |  |  |
| 2083 | **Operação Assistida** | 2021-04-20 → 2021-01-05 (-105d) | 2021-07-19 → 2021-04-05 (-105d) | 62d → 60d |  | 397d → 468d |  |  |
| 2084 | Realizar Operação Assistida - Linhares/ES | 2021-04-20 → 2021-01-05 (-105d) | 2021-07-19 → 2021-04-05 (-105d) |  |  | 1743d → 2058d |  |  |
| 2085 | **UTR** |  |  |  | 7% → 8% |  |  |  |
| 2089 | **Engenharia Básica e Detalhada** |  |  |  | 48% → 50% |  |  |  |
| 2090 | **Engenharia UTR** |  |  |  | 48% → 50% |  |  |  |
| 2093 | Realizar Sondagem - UTR - Linhares/ES | 2019-11-25 → 2020-01-07 (+43d) | 2019-11-28 → 2020-01-10 (+43d) |  |  | 369d → 347d | 2091FS+223d → 2091FS+250d |  |
| 2096 | Elaborar arranjo para obtenção de Dados de Entrada Licenciamento e Fundiário - UTR - Linhares/ES |  | 2020-01-02 → 2020-02-04 (+33d) | 65d → 88d | 27% → 25% |  |  |  |
| 2097 | Elaborar Projeto Básico - UTR - Linhares/ES | 2020-01-03 → 2020-02-05 (+33d) | 2020-04-06 → 2020-04-14 (+8d) | 64d → 46d |  |  |  |  |
| 2098 | Emitir RT/PQ para Suprimentos - UTR - Linhares/ES | 2020-04-07 → 2020-04-15 (+8d) |  | 10d → 5d |  |  |  |  |
| 2099 | Elaborar Projeto Executivo - UTR - Linhares/ES | 2020-04-07 → 2020-04-15 (+8d) |  | 69d → 64d |  |  |  |  |
| 2101 | **Fundiária** | 2020-01-03 → 2020-02-05 (+33d) |  | 183d → 160d |  |  |  |  |
| 2102 | Realizar regularização fundiária - UTR - Linhares/ES | 2020-01-03 → 2020-02-05 (+33d) |  | 183d → 160d |  |  |  |  |
| 2104 | **Licenciamento** | 2020-01-03 → 2020-02-05 (+33d) |  | 176d → 153d |  |  |  |  |
| 2105 | Obter DAIA para construção de UTR - Linhares/ES | 2020-01-03 → 2020-02-05 (+33d) |  | 176d → 153d |  |  |  |  |
| 2120 | **Regência (distrito Linhares/ES)** |  | 2022-08-05 → 2022-08-16 (+11d) | 1097d → 1103d | 7% → 5% | 320d → 314d |  |  |
| 2144 | **Captação Principal (rio Doce) e adequações na ETA/UTR** |  | 2022-08-05 → 2022-08-16 (+11d) | 783d → 789d | 6% → 3% | 320d → 314d |  |  |
| 2145 | **Engenharia** |  | 2020-09-16 → 2020-04-29 (-140d) | 313d → 216d | 17% → 18% | 790d → 887d |  |  |
| 2148 | **Engenharia Básica e Detalhada** |  | 2020-09-16 → 2020-04-29 (-140d) | 238d → 141d | 17% → 18% | 790d → 887d |  |  |
| 2149 | **Engenharia Captação Principal (rio Doce) e adequação da ETA - SE 32029** |  | 2020-09-16 → 2020-04-29 (-140d) | 238d → 141d | 17% → 18% | 790d → 887d |  |  |
| 2150 | Aprovação Plano de Trabalho /abertura OSE + Levantamento de Campo - Captação Principal - Rio Doce - Regência/ES |  | 2020-08-31 → 2020-01-14 (-230d) | 227d → 70d | 10% → 25% | 801d → 958d |  |  |
| 2151 | Executar Topografia - Captação Principal - Rio Doce - Regência/ES |  | 2020-01-17 → 2020-01-13 (-4d) | 73d → 69d | 30% → 35% | 322d → 358d |  |  |
| 2152 | Realizar Sondagem - Captação Principal - Rio Doce - Regência/ES |  | 2019-11-05 → 2020-01-13 (+69d) | 25d → 69d | 88% → 25% | 499d → 959d |  |  |
| 2153 | Elaborar arranjo para obtenção de Dados de Entrada Licenciamento e Fundiário - Captação Principal - Rio Doce - Regência/ES |  | 2019-11-12 → 2020-01-13 (+62d) | 22d → 61d | 64% → 25% | 354d → 315d |  |  |
| 2154 | Elaborar Projeto Básico - Captação Principal - Rio Doce - Regência/ES | 2020-01-20 → 2020-01-14 (-6d) | 2020-04-08 → 2020-03-26 (-13d) | 55d → 50d |  | 322d → 358d |  |  |
| 2155 | Obter aprovação do Projeto Básico Regência/ES | 2020-04-09 → 2020-03-27 (-13d) | 2020-05-13 → 2020-04-29 (-14d) |  |  | 322d → 868d |  |  |
| 2156 | Emitir RT/PQ para Suprimentos - Captação Principal - Rio Doce - Regência/ES | 2020-03-23 → 2020-02-28 (-24d) | 2020-04-13 → 2020-03-19 (-25d) |  |  | 342d → 358d | 2155FF-20d → 2157FF-25d |  |
| 2157 | Elaborar Projeto Executivo - Captação Principal - Rio Doce - Regência/ES | 2020-07-28 → 2020-02-11 (-168d) | 2020-09-16 → 2020-04-27 (-142d) | 36d → 50d |  | 322d → 358d | 2147FS-3d, 2151FS+129d, 2152, 2155FS-22d → 2154FS-30d |  |
| 2158 | Elaboração do Projeto Executivo - Captação Principal - Rio Doce - Regência/ES | 2020-09-16 → 2020-04-29 (-140d) | 2020-09-16 → 2020-04-29 (-140d) |  |  | 771d → 868d | 2157 → 2157, 2155 |  |
| 2159 | **Fundiária** | 2019-08-19 A → 2020-01-14 (+148d) | 2020-06-24 → 2020-09-15 (+83d) | 211d → 168d | 35% → 0% | 830d → 323d |  |  |
| 2160 | Captação Principal (rio Doce) - Desimpedimento de área - Regência/ES | 2019-08-19 A → 2020-01-14 (+148d) | 2020-06-24 → 2020-09-15 (+83d) | 211d → 168d | 35% → 0% | 381d → 323d | 2153SS-19d → 2153 |  |
| 2161 | Conclusão da Regularização Fundiária para as obras de Melhoria do Sistema de Abastecimento da Localidade - Regência/ES | 2020-06-24 → 2020-09-15 (+83d) | 2020-06-24 → 2020-09-15 (+83d) |  |  | 830d → 772d |  |  |
| 2162 | **Licenciamento** | 2019-11-13 → 2020-01-14 (+62d) | 2020-07-31 → 2020-09-25 (+56d) |  |  | 354d → 315d |  |  |
| 2163 | Captação Principal - Outorga e Autorizações rio Doce - Regência/ES | 2019-11-13 → 2020-01-14 (+62d) | 2020-07-31 → 2020-09-25 (+56d) |  |  | 354d → 315d |  |  |
| 2164 | Conclusão do Licenciamento Ambiental da Localidade - Regência/ES | 2020-07-31 → 2020-09-25 (+56d) | 2020-07-31 → 2020-09-25 (+56d) |  |  | 803d → 764d |  |  |
| 2165 | **Suprimentos** | 2020-05-14 → 2020-03-20 (-55d) | 2020-09-16 → 2020-07-27 (-51d) |  |  | 322d → 358d |  |  |
| 2166 | Processo contratação - Captação Principal rio Doce - Regência/ES | 2020-05-14 → 2020-03-20 (-55d) | 2020-09-16 → 2020-07-27 (-51d) |  |  | 322d → 358d | 2155, 2156 → 2156 |  |
| 2167 | Conclusão da Contratação de Suprimentos das obras de Melhoria do Sistema de Abastecimento de Água - Regência/ES | 2020-09-16 → 2020-07-27 (-51d) | 2020-09-16 → 2020-07-27 (-51d) |  |  | 771d → 807d |  |  |
| 2168 | **Infraestrutura** | 2020-09-17 → 2020-09-28 (+11d) | 2022-08-05 → 2022-08-16 (+11d) | 470d → 469d |  | 320d → 314d |  |  |
| 2169 | **Obras** | 2020-09-17 → 2020-09-28 (+11d) | 2021-08-05 → 2021-08-16 (+11d) |  |  | 322d → 315d |  |  |
| 2170 | Executar Captação Principal e adutora de 11km do Rio Doce - Regência/ES | 2020-09-17 → 2020-09-28 (+11d) | 2021-08-05 → 2021-08-16 (+11d) |  |  | 322d → 315d |  |  |
| 2171 | Executar Adequação ETA/UTR (caso haja nova captação no rio Doce) - Regência/ES | 2020-09-17 → 2020-09-28 (+11d) | 2021-03-15 → 2021-03-24 (+9d) |  |  | 651d → 644d |  |  |
| 2172 | Assinatura de Termo de Entrega das Obras de Melhoria do Sistema de Abastecimento de Água - Regência/ES | 2021-08-05 → 2021-08-16 (+11d) | 2021-08-05 → 2021-08-16 (+11d) |  |  | 551d → 544d |  |  |
| 2173 | **Operação** | 2021-08-05 → 2021-08-16 (+11d) | 2022-08-05 → 2022-08-16 (+11d) | 250d → 249d |  | 320d → 314d |  |  |
| 2174 | Realizar Treinamento Operacional do Sistema - Regência/ES | 2021-08-06 → 2021-08-17 (+11d) | 2021-08-12 → 2021-08-23 (+11d) |  |  | 551d → 544d |  |  |
| 2175 | Realizar Testes e Pré-operação - Regência/ES | 2021-08-13 → 2021-08-24 (+11d) | 2021-09-01 → 2021-09-13 (+12d) |  |  | 551d → 544d |  |  |
| 2176 | Realizar Acompanhamento da Funcionalidade do Sistema - Captação Principal (rio Doce) e adequações na ETA/UTR - Regência (distrito Linhares/ES) | 2021-08-05 → 2021-08-16 (+11d) | 2022-08-05 → 2022-08-16 (+11d) |  |  | 1422d → 1389d |  |  |
| 2177 | **Operação Assistida** | 2021-08-05 → 2021-08-16 (+11d) | 2021-11-03 → 2021-11-14 (+11d) |  |  | 322d → 315d |  |  |
| 2178 | Realizar Operação Assistida - Regência/ES | 2021-08-05 → 2021-08-16 (+11d) | 2021-11-03 → 2021-11-14 (+11d) |  |  | 1422d → 1389d |  |  |
| 2179 | **Captação Principal - Novo Poço** |  | 2021-11-16 → 2021-11-17 (+1d) | 916d → 917d |  | 501d → 500d |  | baseline start 2018-03-23 → 2017-06-30 |
| 2189 | **Estudos de Concepção do Sistema - Etapa 2** |  | 2020-03-04 → 2020-03-11 (+7d) | 270d → 275d |  | 906d → 901d |  |  |
| 2192 | **Serviços em Poços Tubulares - Novo Poço** | 2020-01-24 → 2020-01-31 (+7d) | 2020-03-04 → 2020-03-11 (+7d) |  |  | 501d → 500d |  |  |
| 2193 | Realizar Perfuração - Regência/ES | 2020-01-24 → 2020-01-31 (+7d) | 2020-01-24 → 2020-01-31 (+7d) |  |  | 501d → 500d |  |  |
| 2194 | Realizar Teste bombeamento - Regência/ES | 2020-01-27 → 2020-02-03 (+7d) | 2020-01-29 → 2020-02-05 (+7d) |  |  | 501d → 500d |  |  |
| 2195 | Elaborar Relatório Técnico - Regência/ES | 2020-01-30 → 2020-02-06 (+7d) | 2020-03-04 → 2020-03-11 (+7d) |  |  | 906d → 901d |  |  |
| 2196 | Realizar Laudo dos Serviços de Coleta e Análise de Água - Regência/ES | 2020-01-30 → 2020-02-06 (+7d) | 2020-03-04 → 2020-03-11 (+7d) |  |  | 501d → 500d |  |  |
| 2197 | Conclusão dos Serviços em poço tubular - Regência/ES | 2020-03-04 → 2020-03-11 (+7d) | 2020-03-04 → 2020-03-11 (+7d) |  |  | 906d → 901d |  |  |
| 2199 | **Engenharia Básica e Detalhada** | 2020-03-05 → 2020-03-11 (+6d) | 2020-07-16 → 2020-06-18 (-28d) | 92d → 68d |  | 506d → 500d |  | baseline start 2017-11-20 → 2020-01-30; baseline finish 2019-10-23 → 2020-08-07 |
| 2200 | **Engenharia Captação Principal (Novo Poço)** | 2020-03-05 → 2020-03-11 (+6d) | 2020-07-16 → 2020-06-18 (-28d) | 92d → 68d |  | 506d → 500d |  | was named Engenharia Captação Alternativa (Novo Poço); baseline finish 2020-06-16 → 2020-08-07 |
| 2201 | Aprovação Plano de Trabalho /abertura OSE - Captação Principal - Novo Poço - Regência/ES | 2020-03-05 → 2020-03-12 (+7d) | 2020-03-11 → 2020-03-18 (+7d) |  |  | 506d → 500d |  | was named Aprovação Plano de Trabalho /abertura OSE - Captação Alternativa - Novo Poço - Regência/ES |
| 2202 | Dados de Entrada (levantamento de campo, topografia e recebimento das informações do poço: perfil, vazão, análise água) - Captação Principal - Regência/ES | 2020-03-12 → 2020-03-19 (+7d) | 2020-04-13 → 2020-04-20 (+7d) |  |  | 506d → 500d |  | was named Dados de Entrada (levantamento de campo, topografia e recebimento das informações do poço: perfil, vazão, análise água) - Captação Alternativa - Regência/ES |
| 2204 | Elaborar Projeto Executivo - Captação Principal - Novo Poço - Regência/ES | 2020-04-14 → 2020-04-22 (+8d) | 2020-07-16 → 2020-06-18 (-28d) | 65d → 40d |  | 506d → 500d |  | was named Elaborar Projeto Executivo - Captação Alternativa - Novo Poço - Regência/ES |
| 2205 | Elaboração do Projeto Executivo - Captação Principal - Novo Poço - Regência/ES | 2020-07-16 → 2020-06-18 (-28d) | 2020-07-16 → 2020-06-18 (-28d) |  |  | 506d → 530d |  | was named Elaboração do Projeto Executivo - Captação Alternativa - Novo Poço - Regência/ES |
| 2206 | **Fundiária** |  | 2020-02-05 → 2020-05-15 (+100d) | 119d → 185d | 16% → 18% | 615d → 553d |  |  |

| ID | Task | Start | Finish | Duration | Complete | Total float | Predecessors |
| --- | --- | --- | --- | --- | --- | --- | --- |
| 2207 | Obter Termo de Autorização de Superficiário - Captação Principal (Novo Poço) - Regência/ES |  | 2019-11-29 → 2020-01-31 (+63d) | 75d → 116d |  | 506d → 509d |  |
| 2208 | Captação Principal (Novo Poço) - Desimpedimento de área - Regência/ES | 2019-12-02 → 2020-03-12 (+101d) | 2020-02-05 → 2020-05-15 (+100d) |  |  | 615d → 553d | 2207 → 2196 |
| 2209 | Conclusão da Regularização Fundiária para as obras de Melhoria do Sistema de Abastecimento da Localidade - Regência/ES | 2020-02-05 → 2020-05-15 (+100d) | 2020-02-05 → 2020-05-15 (+100d) |  |  | 615d → 553d |  |
| 2210 | **Licenciamento** | 2019-12-02 → 2020-01-06 (+35d) | 2020-11-16 → 2020-11-23 (+7d) | 237d → 221d |  | 501d → 509d |  |
| 2211 | Captação Principal - Autorização de Perfuração - Regência/ES | 2019-12-02 → 2020-01-06 (+35d) | 2020-01-16 → 2020-01-17 (+1d) | 30d → 10d |  | 506d → 509d | 2207 → 2207FS-20d |
| 2212 | Captação Principal - Outorga novo poço - Regência/ES | 2020-03-05 → 2020-03-12 (+7d) | 2020-11-16 → 2020-11-23 (+7d) |  |  | 501d → 744d |  |
| 2213 | Conclusão do Licenciamento Ambiental da Localidade - Regência/ES | 2020-11-16 → 2020-11-23 (+7d) | 2020-11-16 → 2020-11-23 (+7d) |  |  | 501d → 744d |  |
| 2214 | **Suprimentos** |  | 2020-01-23 → 2020-07-30 (+189d) | 110d → 238d | 25% → 14% | 624d → 500d |  |
| 2215 | Processo de Contratação Tintori - Novo Poço - Captação Principal - Regência/ES |  | 2020-01-23 → 2020-01-30 (+7d) | 110d → 115d |  | 501d → 500d |  |
| 2217 | Conclusão da Contratação de Suprimentos das obras de Melhoria do Sistema de Abastecimento de Água - Regência/ES | 2020-01-23 → 2020-07-30 (+189d) | 2020-01-23 → 2020-07-30 (+189d) |  |  | 624d → 500d | 2215 → 2215, 2216 |
| 2218 | **Infraestrutura** | 2020-07-24 → 2020-07-31 (+7d) | 2021-11-16 → 2021-11-17 (+1d) | 327d → 323d |  | 501d → 500d |  |
| 2219 | **Obras** | 2020-07-24 → 2020-07-31 (+7d) | 2020-11-16 → 2020-11-17 (+1d) | 79d → 75d |  | 501d → 500d |  |
| 2220 | Executar Obras de Captação Principal - Novo Poço - Regência/ES | 2020-07-24 → 2020-07-31 (+7d) | 2020-11-16 → 2020-11-17 (+1d) | 79d → 75d |  | 501d → 500d | 2212FF, 2217, 2213FF, 2209, 2205 → 2217, 2209, 2205 |
| 2221 | Assinatura de Termo de Entrega das Obras de Melhoria do Sistema de Abastecimento de Água - Regência/ES | 2020-11-16 → 2020-11-17 (+1d) | 2020-11-16 → 2020-11-17 (+1d) |  |  | 730d → 729d |  |
| 2222 | **Operação** | 2020-11-16 → 2020-11-17 (+1d) | 2021-11-16 → 2021-11-17 (+1d) |  |  | 501d → 500d |  |
| 2223 | Realizar Treinamento Operacional do Sistema - Regência/ES | 2020-11-17 → 2020-11-18 (+1d) | 2020-11-23 → 2020-11-24 (+1d) |  |  | 730d → 729d |  |
| 2224 | Realizar Testes e Pré-operação - Regência/ES | 2020-11-24 → 2020-11-25 (+1d) | 2020-12-11 → 2020-12-14 (+3d) |  |  | 730d → 729d |  |
| 2225 | Realizar Acompanhamento da Funcionalidade do Sistema - Captação Principal - Novo Poço - Regência (distrito Linhares/ES) | 2020-11-16 → 2020-11-17 (+1d) | 2021-11-16 → 2021-11-17 (+1d) |  |  | 2208d → 2205d |  |
| 2226 | **Operação Assistida** | 2020-11-16 → 2020-11-17 (+1d) | 2021-02-14 → 2021-02-15 (+1d) | 61d → 60d |  | 501d → 500d |  |
| 2227 | Realizar Operação Assistida - Regência/ES | 2020-11-16 → 2020-11-17 (+1d) | 2021-02-14 → 2021-02-15 (+1d) |  |  | 2208d → 2205d |  |
| 2236 | Fim da Execução |  |  |  |  |  | 265, 266, 267, 273, 312, 313, 314, 320, 327, 338, 407, 408, 409, 416, 423, 432, 459, 461, 464, 593, 594, 597, 600, 674, 676, 702, 703, 706, 709, 795, 796, 799, 802, 806, 834, 835, 836, 843, 846, 1209, 1210, 1213, 1216, 1275, 1278, 1274, 1281, 1284, 1287, 1379, 1380, 1383, 1386, 1427, 1442, 1446, 1460, 1539, 1563, 1564, 1567, 1570, 1575, 1616, 1617, 1618, 1619, 1620, 1624, 1626, 1632, 1670, 1671, 1672, 1676, 1678, 1776, 1777, 1780, 1783, 1788, 1825, 1826, 1829, 1832, 1911, 1912, 1915, 1918, 1923, 1925, 1995, 1993, 1996, 1999, 2002, 2088, 2112, 2113, 2116, 2119, 2190, 2185, 2187, 2221, 2224, 2227, 460, 837, 838, 839, 146, 155, 156, 202, 203, 209, 284, 306, 307, 467, 474, 477, 510, 511, 512, 515, 518, 522, 523, 529, 570, 573, 576, 605, 607, 663, 664, 667, 670, 714, 733, 755, 756, 760, 764, 767, 770, 851, 870, 874, 876, 881, 921, 922, 923, 928, 931, 936, 969, 970, 976, 979, 984, 1026, 1027, 1033, 1036, 1041, 1063, 1076, 1081, 1087, 1090, 1095, 1133, 1136, 1141, 1144, 1175, 1176, 1179, 1182, 1292, 1311, 1312, 1313, 1316, 1319, 1323, 1357, 1358, 1361, 1364, 1391, 1417, 1420, 1423, 1466, 1491, 1496, 1498, 1501, 1504, 1509, 1526, 1529, 1532, 1535, 1683, 1717, 1718, 1721, 1724, 1728, 1743, 1744, 1747, 1750, 1854, 1855, 1858, 1861, 1883, 1884, 1887, 1890, 2008, 2017, 2038, 2039, 2042, 2045, 2049, 2075, 2076, 2078, 2081, 2084, 2142, 2143, 2147, 2170, 2172, 2175, 2178, 210, 468, 516, 574, 598, 668, 707, 768, 800, 844, 875, 929, 977, 1034, 1088, 1142, 1180, 1214, 1285, 1317, 1362, 1384, 1421, 1502, 1533, 1568, 1621, 1673, 1722, 1748, 1781, 1830, 1859, 1888, 1916, 2000, 2043, 2082, 2117, 2176, 2225 → 265, 266, 267, 273, 312, 313, 314, 320, 327, 338, 407, 408, 409, 416, 423, 432, 459, 461, 464, 593, 594, 597, 600, 674, 676, 702, 703, 706, 709, 795, 796, 799, 802, 806, 834, 835, 836, 843, 846, 1209, 1210, 1213, 1216, 1275, 1278, 1274, 1281, 1284, 1287, 1379, 1380, 1383, 1386, 1427, 1442, 1446, 1460, 1539, 1563, 1564, 1567, 1570, 1575, 1616, 1617, 1618, 1619, 1620, 1624, 1626, 1632, 1670, 1671, 1672, 1676, 1678, 1776, 1777, 1780, 1783, 1788, 1825, 1826, 1829, 1832, 1911, 1912, 1915, 1918, 1923, 1925, 1995, 1993, 1996, 1999, 2002, 2088, 2112, 2113, 2116, 2119, 2190, 2185, 2187, 2221, 2224, 2227, 460, 837, 838, 839, 146, 155, 156, 202, 203, 209, 284, 306, 307, 467, 474, 477, 510, 511, 512, 515, 518, 522, 523, 529, 570, 573, 576, 605, 607, 663, 664, 667, 670, 714, 733, 755, 756, 760, 764, 767, 770, 851, 870, 874, 876, 881, 921, 922, 923, 928, 931, 936, 969, 970, 976, 979, 984, 1026, 1027, 1033, 1036, 1041, 1063, 1076, 1081, 1087, 1090, 1095, 1133, 1136, 1141, 1144, 1175, 1176, 1179, 1182, 1292, 1311, 1312, 1313, 1316, 1319, 1323, 1357, 1358, 1361, 1364, 1391, 1417, 1420, 1423, 1466, 1491, 1496, 1498, 1501, 1504, 1509, 1526, 1529, 1532, 1535, 1683, 1717, 1718, 1721, 1724, 1728, 1743, 1744, 1747, 1750, 1854, 1855, 1858, 1861, 1883, 1884, 1887, 1890, 2008, 2017, 2038, 2039, 2042, 2045, 2049, 2078, 2081, 2084, 2142, 2143, 2147, 2170, 2172, 2175, 2178, 210, 468, 516, 574, 598, 668, 707, 768, 800, 844, 875, 929, 977, 1034, 1088, 1142, 1180, 1214, 1285, 1317, 1362, 1384, 1421, 1502, 1533, 1568, 1621, 1673, 1722, 1748, 1781, 1830, 1859, 1888, 1916, 2000, 2043, 2082, 2117, 2176, 2225, 1134, 2077 |
